# BOOM Structure

Schedule from MS Project, 2000-12-11 to 2004-06-21, status date 2003-07-31, A marks actual dates.
Boom Structure Development Schedule
NASA GSFC
Status Date: 07/31/2003 / Baseline Date: 01/31/2003 R1

## Calendars

- Standard w/ 10 Gov't Holidays: Mon-Fri 08:00-12:00, 13:00-17:00; Sat-Sun off. Exceptions (off unless hours are given): 2000-12-25, 2001-01-01, 2001-01-15, 2001-02-19, 2001-05-28, 2001-07-04, 2001-09-03, 2001-10-08, 2001-11-12, 2001-11-22, 2001-12-25, 2002-01-01, 2002-01-14, 2002-02-18, 2002-05-27, 2002-07-04, 2002-09-02, 2002-10-07, 2002-11-11, 2002-11-28, 2002-12-25, 2003-01-01, 2003-01-13, 2003-02-17, 2003-05-26, 2003-07-04, 2003-09-01, 2003-10-06, 2003-11-10, 2003-11-27, 2003-12-25, 2004-01-01, 2004-01-12, 2004-02-16, 2004-05-31.

## Schedule

| ID | WBS | Task | Type | Duration | Start | Finish | Predecessors | Complete | Remaining | Baseline start | Baseline finish | Baseline duration | Total slack | Free slack | Constraint | Text14 | Text13 | Text20 | Text22 |
| --- | --- | --- | --- | --- | --- | --- | --- | --- | --- | --- | --- | --- | --- | --- | --- | --- | --- | --- | --- |
| 1 | 1 | **Management** |  | 413d | 2002-10-29 A | 2004-06-21 |  | 2% | 405.67d | 2002-10-29 | 2004-07-06 | 423d | 0d |  |  |  |  |  |  |
| 2 | 1.1 | **Milestones** |  | 413d | 2002-10-29 A | 2004-06-21 |  | 2% | 405.67d | 2002-10-29 | 2004-07-06 | 423d | 0d |  |  |  |  |  |  |
| 3 | 1.1.1 | Boom Review (Trigger) |  | 1d | 2002-10-29 A | 2002-10-29 A |  | 100% |  | 2002-10-29 | 2002-10-29 | 1d |  |  | start no earlier than 2002-09-30 | Boom |  |  |  |
| 4 | 1.1.2 | Protoflight Design Review |  | 1d | 2003-04-01 A | 2003-04-01 A | 56 | 100% |  | 2003-02-26 | 2003-02-26 | 1d |  |  | start no earlier than 2003-03-31 | Boom |  |  |  |
| 5 | 1.1.3 | Boom Structure Protoflight Test Preparation Workshop |  | 1d | 2003-06-04 A | 2003-06-04 A | 66, 75, 80 | 100% |  | 2003-04-24 | 2003-04-24 | 1d |  |  | start no earlier than 2003-06-04 | Boom |  |  |  |
| 6 | 1.1.4 | Boom Structure Protoflight Test Results Workshop and Deployment Demo |  | 1d | 2003-08-21 | 2003-08-21 | 85FF |  |  | 2003-07-24 | 2003-07-24 | 1d | 208d |  |  | Boom |  |  |  |
| 7 | 1.1.5 | Flight Model Design Update Workshop |  | 1d | 2003-10-14 | 2003-10-14 | 92 |  |  | 2003-08-28 | 2003-08-28 | 1d | 172d |  | start no earlier than 2003-08-28 | Boom |  |  |  |
| 8 | 1.1.6 | Flight Boom Structure Status and Flight Testing Preparation Workshop |  | 1d | 2003-12-04 | 2003-12-04 | 103SS+10d |  |  | 2003-10-20 | 2003-10-20 | 1d | 137d |  |  | Boom |  |  |  |
| 9 | 1.1.7 | Flight Model Boom Test Results Workshop |  | 1d | 2004-04-19 | 2004-04-19 | 121, 146 |  |  | 2004-03-05 | 2004-03-05 | 1d | 44d |  |  | Boom |  |  |  |
| 10 | 1.1.8 | **Contingency** |  | 208d | 2003-08-21 | 2004-06-21 |  |  |  | 2003-06-26 | 2004-07-06 | 258d | 0d |  |  |  |  |  |  |
| 11 | 1.1.8.1 | Protoflight Completion Contingency | milestone | 0d | 2003-08-21 | 2003-08-21 | 85 |  |  | 2003-06-26 | 2003-07-16 | 14d | 7d | 0d |  | Boom |  |  |  |
| 12 | 1.1.8.2 | Protoflight Contingency |  | 82d | 2003-08-22 | 2003-12-19 | 23 |  |  | 2003-07-17 | 2003-12-30 | 114d | 7d | 0d |  | Boom |  |  |  |
| 13 | 1.1.8.3 | Boom Structure FM 1 Contingency |  | 40d | 2004-04-26 | 2004-06-21 | 26 |  |  | 2004-03-12 | 2004-06-07 | 61d | 0d |  |  | Boom |  |  |  |
| 14 | 1.1.8.4 | Boom Structure FM 2 Contingency |  | 40d | 2004-04-26 | 2004-06-21 | 29 |  |  | 2004-03-12 | 2004-07-06 | 81d | 0d |  |  | Boom |  |  |  |
| 15 | 1.1.9 | **Receiveables** |  | 43d | 2003-03-31 A | 2003-06-02 |  |  | 43d | 2003-02-01 | 2003-02-01 | 64d | 266d |  |  |  |  |  |  |
| 16 | 1.1.9.1 | Receive Boom Test Plan Comments From APL | milestone | 0d | 2003-03-31 A | 2003-03-31 A |  | 100% |  | 2003-02-01 | 2003-02-01 | 0d |  |  | start no earlier than 2003-03-31 | Boom |  |  |  |
| 17 | 1.1.9.2 | Receive Safety Plan (IMPACT Schedule) Comments From APL | milestone | 0d | 2003-05-31 | 2003-05-31 |  |  |  | 2003-02-01 | 2003-02-01 | 0d | 266d |  | start no earlier than 2003-05-31 | Boom |  |  |  |
| 18 | 1.1.9.3 | Receive Thermal Blanketing Schedule from APL | milestone | 0d | 2003-05-31 A | 2003-05-31 A |  | 100% |  | 2003-02-01 | 2003-02-01 | 0d |  |  | start no earlier than 2003-05-31 | Boom |  |  |  |
| 19 | 1.1.9.4 | Receive Testing Level Input | milestone | 0d | 2003-05-31 A | 2003-05-31 A |  | 100% |  | 2003-05-01 | 2003-05-01 | 0d |  |  | start no earlier than 2003-05-31 | Boom |  |  |  |
| 20 | 1.1.9.5 | Receive EM Thermal Blankets from APL | milestone | 0d | 2003-06-02 | 2003-06-02 |  |  |  | 2003-06-02 | 2003-06-02 | 0d | 58d |  | start no earlier than 2003-06-02 | Boom |  |  |  |
| 21 | 1.1.10 | **Deliverables** |  | 280d | 2003-05-09 A | 2004-06-21 |  |  | 280d | 2003-07-16 | 2004-07-06 | 244d | 0d |  |  |  |  |  |  |
| 22 | 1.1.10.1 | Deliver Boom Structure Blanket Mockup to APL | milestone | 0d | 2003-05-09 A | 2003-05-09 A | 150FS+5d | 100% |  | 2003-05-09 | 2003-05-09 | 0d |  |  |  | Boom |  |  |  |
| 23 | 1.1.10.2 | Protoflight Boom Complete | milestone | 0d | 2003-08-21 | 2003-08-21 | 11 |  |  | 2003-07-16 | 2003-07-16 | 0d | 7d | 0d |  | Boom | Boom Suite | Protoflight Boom Structure | Boom - Completion of Boom Protoflight Unit |
| 24 | 1.1.10.3 | Deliver Protoflight Boom for I & T | milestone | 0d | 2003-12-19 | 2003-12-19 | 12 |  |  | 2003-12-30 | 2003-12-30 | 0d | 7d | 0d | finish no later than 2003-12-31 | Boom |  |  | Deliver Protoflight Boom for I & T |
| 25 | 1.2.5.2.4 | Receive Protoflight BOOM for FM 1 BOOM Suite I & T | milestone | 0d | 2003-12-29 | 2003-12-29 | 24FS+5d |  |  | 2004-01-07 | 2004-01-07 | 0d | 39d | 32d |  |  |  |  |  |
| 26 | 1.1.10.5 | FM 1 Boom Structure Avaliable | milestone | 0d | 2004-04-23 | 2004-04-23 | 121, 122 |  |  | 2004-03-11 | 2004-03-11 | 0d | 0d |  |  | Boom | Boom Suite |  |  |
| 27 | 1.1.10.6 | Delivery FM 1 Boom Structure | milestone | 0d | 2004-06-21 | 2004-06-21 | 13 |  |  | 2004-06-07 | 2004-06-07 | 0d | 0d |  | finish no later than 2004-06-25 | Boom |  | FM 1 Boom Structure | Boom - FM 1 Structure Delivered |
| 28 | 1.2.5.2.2 | Receive BOOM FM 1 For BOOM Suite I & T | milestone | 0d | 2004-06-21 | 2004-06-21 | 27 |  |  | 2004-06-25 | 2004-06-25 | 0d | 1d | 0d |  |  |  |  |  |
| 29 | 1.1.10.8 | FM 2 Boom Structure Available | milestone | 0d | 2004-04-23 | 2004-04-23 | 146, 147 |  |  | 2004-03-11 | 2004-03-11 | 0d | 0d |  |  | Boom | Boom Suite |  |  |
| 30 | 1.1.10.9 | Delivery FM 2 Boom Structure | milestone | 0d | 2004-06-21 | 2004-06-21 | 14 |  |  | 2004-07-06 | 2004-07-06 | 0d | 0d |  | finish no later than 2004-07-30 | Boom |  | FM 2 Boom Structure | Boom - FM 2 Structure Delivered |
| 31 | 1.2.5.3.2 | Receive BOOM FM 2 For BOOM Suite I & T | milestone | 0d | 2004-06-21 | 2004-06-21 | 30 |  |  | 2004-07-30 | 2004-07-30 | 0d | 0d |  |  |  |  |  |  |
| 32 | 1.1.10.11 | Deliver Updated Boom FEM to APL | milestone | 0d | 2003-10-27 | 2003-10-27 | 92FS+10d, 93FS+10d, 94FS+10d |  |  | 2003-09-11 | 2003-09-11 | 0d | 163d |  |  | Boom |  |  |  |

Notes:
- 4: Text23: Protoflight Design Reviewed
- 5: Text23: Protoflight Test Preparation Workshop
- 6: Text23: Protoflight Test Results Workshop and Deployment Demo
- 7: Text23: Flight Model Design Update Workshop
- 8: Text23: Flight Boom Structure Status and Flight Testing Preparation Workshop
- 9: Text23: Flight Model Boom Test Results Workshop
- 22: Text23: Boom Structure Blanket Mockup Delivered to APL
- 23: Text23: Protoflight Boom Complete
- 24: Text23: Protoflight Boom Delivered for Boom Suite I & T
- 26: Text23: FM 1 Boom Structure Complete
- 27: Text23: FM 1 Boom Structure Ready for Delivery
- 29: Text23: FM 2 Boom Structure Complete
- 30: Text23: FM 2 Boom Structure Ready for Delivery

| ID | WBS | Task | Type | Duration | Start | Finish | Predecessors | Complete | Remaining | Baseline start | Baseline finish | Baseline duration | Total slack | Constraint | Text11 | Text12 | Text13 | Text14 | Text16 | Text28 | Text21 |
| --- | --- | --- | --- | --- | --- | --- | --- | --- | --- | --- | --- | --- | --- | --- | --- | --- | --- | --- | --- | --- | --- |
| 33 | 2 | **Systems Engineering** |  | 599d | 2000-12-11 A | 2003-04-30 A |  | 100% |  | 2000-12-11 | 2003-02-04 | 538.25d |  |  | STEREO | IMPACT | Boom Suite | Boom | Boom | UC-B |  |
| 34 | 2.1 | **Prototype Demonstration Technology** |  | 347d | 2000-12-11 A | 2002-04-29 A |  | 100% |  | 2000-12-11 | 2002-04-29 | 347d |  |  | STEREO | IMPACT | Boom Suite | Boom | Boom | UC-B |  |
| 35 | 2.1.1 | BOOM Lock Button Ring |  | 210d | 2001-04-23 A | 2002-02-22 A |  | 100% |  | 2001-04-23 | 2002-02-22 | 210d |  | start no earlier than 2001-04-22 | STEREO | IMPACT | Boom Suite | Boom | Boom | UC-B |  |
| 36 | 2.1.2 | BOOM Tubes |  | 297d | 2000-12-11 A | 2002-02-15 A |  | 100% |  | 2000-12-11 | 2002-02-15 | 297d |  | start no earlier than 2000-12-11 | STEREO | IMPACT | Boom Suite | Boom | Boom | UC-B |  |
| 37 | 2.1.3 | BOOM Stacer Spring |  | 29d | 2002-01-21 A | 2002-03-01 A |  | 100% |  | 2002-01-21 | 2002-03-01 | 29d |  | start no earlier than 2002-01-20 | STEREO | IMPACT | Boom Suite | Boom | Boom | UC-B |  |
| 38 | 2.1.4 | BOOM Characterization |  | 56d | 2001-12-03 A | 2002-02-22 A |  | 100% |  | 2001-12-03 | 2002-02-22 | 56d |  | start no earlier than 2001-12-02 | STEREO | IMPACT | Boom Suite | Boom | Boom | UC-B |  |
| 39 | 2.1.5 | BOOM Rework |  | 20d | 2002-03-11 A | 2002-04-05 A | 35, 37, 38 | 100% |  | 2002-03-11 | 2002-04-05 | 20d |  |  | STEREO | IMPACT | Boom Suite | Boom | Boom | UC-B |  |
| 40 | 2.1.6 | BOOM Retest |  | 16d | 2002-04-08 A | 2002-04-29 A | 39 | 100% |  | 2002-04-08 | 2002-04-29 | 16d |  |  | STEREO | IMPACT | Boom Suite | Boom | Boom | UC-B |  |
| 41 | 2.2 | **Studies/Analysis** |  | 24d | 2002-03-11 A | 2002-04-12 A |  | 100% |  | 2002-03-11 | 2002-04-12 | 24d |  |  | STEREO | IMPACT | Boom Suite | Boom | Boom | UC-B |  |
| 42 | 2.2.1 | BOOM Carbon Fiber Tube Analysis |  | 24d | 2002-03-11 A | 2002-04-12 A | 36 | 100% |  | 2002-03-11 | 2002-04-12 | 24d |  |  | STEREO | IMPACT | Boom Suite | Boom | Boom | UC-B |  |
| 43 | 2.3 | **STE** |  | 453.25d | 2001-06-11 A | 2003-04-02 A |  | 100% |  | 2001-06-11 | 2003-02-04 | 413.25d |  |  | STEREO | IMPACT | Boom Suite | Boom | Boom | UC-B |  |
| 44 | 2.3.1 | BOOM Thermal Analysis |  | 40d | 2001-06-11 A | 2002-10-02 A |  | 100% |  | 2001-06-11 | 2002-10-02 | 40d |  |  | STEREO | IMPACT | Boom Suite | Boom | Boom | UC-B |  |
| 45 | 2.3.2 | BOOM Mechanical Analysis |  | 25d | 2002-03-18 A | 2003-04-02 A |  | 100% |  | 2002-03-18 | 2003-02-04 | 25d |  |  | STEREO | IMPACT | Boom Suite | Boom | Boom | UC-B |  |
| 46 | 2.4 | **Deployment** |  | 162d | 2002-02-19 A | 2002-10-08 A |  | 100% |  | 2002-02-19 | 2002-10-08 | 162d |  |  | STEREO | IMPACT | Boom Suite | Boom | Boom | UC-B |  |
| 47 | 2.4.1 | BOOM Stacer Analysis |  | 34d | 2002-02-19 A | 2002-04-05 A |  | 100% |  | 2002-02-19 | 2002-04-05 | 34d |  | start no earlier than 2002-02-18 | STEREO | IMPACT | Boom Suite | Boom | Boom | UC-B |  |
| 48 | 2.4.2 | BOOM Release Analysis |  | 20d | 2002-04-15 A | 2002-08-08 A | 47 | 100% |  | 2002-04-15 | 2002-08-08 | 20d |  |  | STEREO | IMPACT | Boom Suite | Boom | Boom | UC-B |  |
| 49 | 2.4.3 | BOOM Stability Analysis |  | 45.5d | 2002-03-04 A | 2002-10-08 A | 48FS-40d | 100% |  | 2002-03-04 | 2002-10-08 | 45.5d |  |  | STEREO | IMPACT | Boom Suite | Boom | Boom | UC-B |  |
| 50 | 2.5 | BOOM SWEA Mount Analysis |  | 25d | 2002-03-11 A | 2002-04-12 A |  | 100% |  | 2002-03-11 | 2002-04-12 | 25d |  | start no earlier than 2002-03-11 | STEREO | IMPACT | Boom Suite | Boom | Boom | UC-B |  |
| 51 | 2.6 | IMPACT / SC I/F Analysis |  | 33.75d | 2002-04-08 A | 2002-09-13 A |  | 100% |  | 2002-04-08 | 2002-09-13 | 33.75d |  |  | STEREO | IMPACT | Boom Suite | Boom | Boom | UC-B |  |
| 52 | 2.7 | BOOM Analysis Complete | milestone | 0d | 2003-04-30 A | 2003-04-30 A | 44, 45, 49, 51, 53 | 100% |  | 2003-02-04 | 2003-02-04 | 0d |  | start no earlier than 2003-04-30 | STEREO | IMPACT | Boom Suite | Boom | Boom | UC-B | Analysis Cmplt. |
| 53 | 2.8 | SMA ID Analysis |  | 5d | 2002-10-01 A | 2002-10-08 A |  | 100% |  | 2002-10-01 | 2002-10-08 | 5d |  | start no earlier than 2002-09-30 | STEREO | IMPACT | Boom Suite | Boom | Boom | UC-B |  |
| 54 | 3 | **Protoflight** |  | 197d | 2002-11-25 A | 2003-09-05 |  | 92% | 16.69d | 2002-11-25 | 2003-06-25 | 147d | 198d |  |  |  |  |  |  |  |  |
| 55 | 3.1 | **Telescoping** |  | 128.75d | 2002-11-25 A | 2003-05-30 A |  | 100% |  | 2002-11-25 | 2003-04-23 | 103d |  |  |  |  |  |  |  |  |  |
| 56 | 3.1.1 | Rework Boom Design Based on pre-CDR Test Results |  | 55d | 2002-11-25 A | 2003-02-13 A |  | 100% |  | 2002-11-25 | 2003-02-13 | 55d |  | start no earlier than 2002-11-25 |  |  |  | Boom |  |  |  |

| ID | WBS | Task | Duration | Start | Finish | Predecessors | Complete | Baseline start | Baseline finish | Baseline duration | Constraint | Text14 | Text23 |
| --- | --- | --- | --- | --- | --- | --- | --- | --- | --- | --- | --- | --- | --- |
| 57 | 3.1.2 | **Procurments** | 70d | 2003-01-24 A | 2003-05-02 A |  | 100% | 2003-01-24 | 2003-04-01 | 47d |  |  |  |
| 58 | 3.1.2.1 | Place Stacer Order | 1d | 2003-01-29 A | 2003-01-29 A |  | 100% | 2003-01-29 | 2003-01-29 | 1d | start no earlier than 2002-12-17 | Boom | Stacer Ordered |
| 59 | 3.1.2.2 | Receive and Inspect Stacer | 2d | 2003-04-01 A | 2003-04-02 A | 58FS+41d | 100% | 2003-03-31 | 2003-04-01 | 2d | start no earlier than 2003-03-31 | Boom | Stacer Received & Inspected |
| 60 | 3.1.2.3 | Order Tubes | 1d | 2003-01-24 A | 2003-01-24 A | 56SS+15d | 100% | 2003-01-24 | 2003-01-24 | 1d |  | Boom | Protoflight Tubes Ordered |
| 61 | 3.1.2.4 | Receive and Inspect Tubes | 2d | 2003-05-01 A | 2003-05-02 A | 60FS+40d | 100% | 2003-03-25 | 2003-03-26 | 2d | start no earlier than 2003-04-30 | Boom | Protoflight Tubes Received & Inspected |
| 62 | 3.1.3 | **Fabrication** | 44.75d | 2003-03-07 A | 2003-05-08 A |  | 100% | 2003-02-14 | 2003-04-02 | 33d |  |  |  |
| 63 | 3.1.3.1 | Machine Tubes as necessary | 5d | 2003-04-10 A | 2003-05-08 A | 61 | 100% | 2003-03-27 | 2003-04-02 | 5d |  | Boom |  |
| 64 | 3.1.3.2 | Machine Other Protoflight Telescoping Parts | 25d | 2003-03-07 A | 2003-04-10 A | 56 | 100% | 2003-02-14 | 2003-03-21 | 25d | finish no earlier than 2003-04-10 | Boom | Other Protoflight Telescoping Parts Fabricated |
| 65 | 3.1.4 | Assemble Telescoping Boom | 10d | 2003-05-08 A | 2003-05-22 A | 63, 64 | 100% | 2003-04-03 | 2003-04-16 | 10d | start no earlier than 2003-04-30 | Boom | Protoflight Telescoping Boom Assembled |
| 66 | 3.1.5 | Test Protoflight Telescoping Boom | 5d | 2003-05-22 A | 2003-05-30 A | 65 | 100% | 2003-04-17 | 2003-04-23 | 5d |  | Boom | Protoflight Telescoping Boom Subassembly Tested |
| 67 | 3.2 | **Harness** | 87d | 2003-01-31 A | 2003-06-04 A |  | 100% | 2003-01-31 | 2003-04-30 | 63d |  |  |  |
| 68 | 3.2.1 | **Procurements** | 87d | 2003-01-31 A | 2003-06-04 A |  | 100% | 2003-01-31 | 2003-04-30 | 63d |  |  |  |
| 69 | 3.2.1.1 | Place Pin Puller Order | 1d | 2003-01-31 A | 2003-01-31 A |  | 100% | 2003-01-31 | 2003-01-31 | 1d | start no earlier than 2002-12-17 | Boom | Pin Puller Ordered |
| 70 | 3.2.1.2 | Receive Pin Puller | 2d | 2003-06-03 A | 2003-06-04 A | 69FS+60d | 100% | 2003-04-29 | 2003-04-30 | 2d | start no earlier than 2003-06-03 | Boom | Pin Puller Received & Inspected |
| 71 | 3.2.2 | **Fabrication** | 26d | 2003-03-03 A | 2003-04-07 A |  | 100% | 2003-02-24 | 2003-03-28 | 25d |  |  |  |
| 72 | 3.2.2.1 | Machine Housing Parts | 25d | 2003-03-03 A | 2003-04-07 A | 56FS+5d | 100% | 2003-02-24 | 2003-03-28 | 25d | start no earlier than 2003-03-01 | Boom | Protoflight Harness Housing Fabricated |
| 73 | 3.2.3 | **Assembly** | 10d | 2003-05-01 A | 2003-05-14 A |  | 100% | 2003-03-31 | 2003-04-11 | 10d |  |  |  |
| 74 | 3.2.3.1 | Assemble Housing subassembly | 10d | 2003-05-01 A | 2003-05-14 A | 72 | 100% | 2003-03-31 | 2003-04-11 | 10d | start no earlier than 2003-04-30 | Boom | Protoflight Harness Housing Subassembly Assembled |
| 75 | 3.2.4 | Fit Test Housing | 5d | 2003-05-15 A | 2003-05-21 A | 74 | 100% | 2003-04-14 | 2003-04-18 | 5d | start no earlier than 2003-04-30 | Boom | Protoflight Harness Housing Fit Checked |
| 76 | 3.3 | **Mounting** | 63d | 2003-03-03 A | 2003-05-29 A |  | 100% | 2003-02-03 | 2003-04-21 | 55d |  |  |  |
| 77 | 3.3.1 | Design Protoflight Mountings | 25d | 2003-03-03 A | 2003-04-04 A |  | 100% | 2003-02-03 | 2003-03-10 | 25d | start no earlier than 2003-02-28 | Boom | Protoflight Mountings Designed |
| 78 | 3.3.2 | Fabrication Protoflight Mountings | 20d | 2003-04-07 A | 2003-05-14 A | 77 | 100% | 2003-03-11 | 2003-04-07 | 20d | start no earlier than 2003-03-17 | Boom | Protoflight Mountings Fabricated |
| 79 | 3.3.3 | Assemble Protoflight Mountings | 5d | 2003-05-15 A | 2003-05-21 A | 78 | 100% | 2003-04-08 | 2003-04-14 | 5d |  | Boom | Protoflight Mountings Assembled |
| 80 | 3.3.4 | Fit Check Protoflight Mountings Test | 5d | 2003-05-22 A | 2003-05-29 A | 79 | 100% | 2003-04-15 | 2003-04-21 | 5d |  | Boom | Protoflight Mountings Fit Checked |

| ID | WBS | Task | Duration | Start | Finish | Predecessors | Complete | Remaining | Baseline start | Baseline finish | Baseline duration | Total slack | Free slack | Constraint | Text14 | Text23 |
| --- | --- | --- | --- | --- | --- | --- | --- | --- | --- | --- | --- | --- | --- | --- | --- | --- |
| 81 | 3.4 | **Integration & Test** | 68.25d | 2003-05-30 A | 2003-09-05 |  | 38% | 42.66d | 2003-04-24 | 2003-06-25 | 44d | 198d |  |  |  |  |
| 82 | 3.4.1 | Integrate Protoflight subassemblies | 5d | 2003-05-30 A | 2003-06-06 A | 66, 75, 80, 59 | 100% |  | 2003-04-24 | 2003-05-14 | 15d |  |  |  | Boom | Protoflight Boom Integrated |
| 83 | 3.4.2 | Protoflight Deployment Test | 5d | 2003-06-06 A | 2003-06-13 A | 82, 70, 19 | 100% |  | 2003-05-15 | 2003-05-21 | 5d |  |  |  | Boom | Protoflight Deployment Test Complete |
| 84 | 3.4.3 | Protoflight Boom Vibration Test | 2d | 2003-07-21 A | 2003-07-22 A | 83 | 100% |  | 2003-05-22 | 2003-05-23 | 2d |  |  | start no earlier than 2003-07-21 | Boom | Protoflight Boom Vibration Test Complete |
| 85 | 3.4.4 | Protoflight Boom Themal Vac Testing | 10d | 2003-08-08 | 2003-08-21 | 84 |  |  | 2003-05-27 | 2003-06-16 | 15d | 0d |  | start no earlier than 2003-08-08 | Boom | Protoflight Boom Themal Vac Testing Complete |
| 86 | 3.4.5 | Install EM Blankets on Protoflight Boom | 1d | 2003-08-22 | 2003-08-22 | 20, 85 |  |  | 2003-06-26 | 2003-06-26 | 1d | 0d |  |  | Boom |  |
| 87 | 3.4.6 | Protoflight Boom Thermal Balance Testing | 2d | 2003-08-25 | 2003-08-26 | 86 |  |  | 2003-06-27 | 2003-06-30 | 2d | 0d |  |  | Boom | Protoflight Boom Thermal Balance Testing |
| 88 | 3.4.7 | Protoflight Boom Post Environmental Deployment Test | 2d | 2003-08-27 | 2003-08-28 | 87 |  |  | 2003-06-17 | 2003-06-18 | 2d | 0d |  |  | Boom | Protoflight Boom Post Environmental Deployment Test |
| 89 | 3.4.8 | Document Protoflight Boom Test Results | 5d | 2003-08-29 | 2003-09-05 | 88 |  |  | 2003-06-19 | 2003-06-25 | 5d | 198d |  |  | Boom |  |
| 90 | 4 | **FM 1 & FM 2** | 39d | 2003-08-18 A | 2003-10-13 |  | 1% | 38.5d | 2003-06-19 | 2003-08-27 | 49d | 15d |  |  |  |  |
| 91 | 4.1 | **Design** | 30d | 2003-08-29 | 2003-10-13 |  |  |  | 2003-06-19 | 2003-08-27 | 49d | 0d |  |  |  |  |
| 92 | 4.1.1 | Rework Telescoping Design Based on Protoflight Test Results | 30d | 2003-08-29 | 2003-10-13 | 88 |  |  | 2003-07-17 | 2003-08-27 | 30d | 0d |  |  | Boom | Telescoping Design Reworked (if necessary) |
| 93 | 4.1.2 | Rework Harness Design Based on Protoflight Test Results | 20d | 2003-08-29 | 2003-09-26 | 88 |  |  | 2003-06-19 | 2003-07-17 | 20d | 10d | 0d |  | Boom | Harness Design Reworked (if necessary) |
| 94 | 4.1.3 | Mounting Design rework based on Protoflight Results | 25d | 2003-08-29 | 2003-10-03 | 88 |  |  | 2003-06-19 | 2003-07-24 | 25d | 20d | 0d |  | Boom | Mounting Design Reworked (if necessary) |
| 95 | 4.2 | **Procurments** | 33d | 2003-08-18 A | 2003-10-02 |  | 33% | 22d | 2003-06-19 | 2003-08-05 | 33d | 21d |  |  |  |  |
| 96 | 4.2.1 | Trigger to Order Flight Boom Structure Tubes | 1d | 2003-08-18 A | 2003-08-18 A | 88 | 100% |  | 2003-06-19 | 2003-06-19 | 1d |  |  |  | Boom | Order Flight Tubes |
| 97 | 4.2.2 | Receive and Inspect Flight Boom Structure Tubes | 2d | 2003-10-01 | 2003-10-02 | 96FS+30d |  |  | 2003-08-04 | 2003-08-05 | 2d | 21d | 0d |  | Boom | Flight Tubes Received & Inspected |
| 98 | 5 | **FM 1** | 143d | 2003-09-29 | 2004-04-23 |  |  |  | 2003-07-18 | 2004-03-11 | 162d | 0d |  |  |  |  |
| 99 | 5.1 | **Telescoping** | 61d | 2003-10-03 | 2004-01-02 |  |  |  | 2003-08-06 | 2003-11-17 | 71d | 0d |  |  |  |  |
| 100 | 5.1.1 | **Fabrication** | 31d | 2003-10-03 | 2003-11-18 |  |  |  | 2003-08-06 | 2003-10-02 | 41d | 0d |  |  |  |  |
| 101 | 5.1.1.1 | Machine FM 1 Boom Structure Tubes as necessary | 10d | 2003-10-03 | 2003-10-17 | 97 |  |  | 2003-08-06 | 2003-08-19 | 10d | 21d |  |  | Boom |  |
| 102 | 5.1.1.2 | Machine FM 1 Boom Structure Parts | 25d | 2003-10-14 | 2003-11-18 | 92 |  |  | 2003-08-28 | 2003-10-02 | 25d | 0d |  |  | Boom | FM 1 Boom Structure Partes Fabricated |
| 103 | 5.1.2 | Assemble FM 1 Boom Structure Telescoping Assembly | 20d | 2003-11-19 | 2003-12-17 | 101, 102 |  |  | 2003-10-03 | 2003-10-31 | 20d | 0d |  |  | Boom | FM 1 Boom Structure Telescoping Assembly Assembled |
| 104 | 5.1.3 | Test FM 1 Boom Structure Telescoping Assembly | 10d | 2003-12-18 | 2004-01-02 | 103 |  |  | 2003-11-03 | 2003-11-17 | 10d | 0d |  |  | Boom | FM 1 Boom Structure Telescoping Assembly Tested |

| ID | WBS | Task | Duration | Start | Finish | Predecessors | Complete | Remaining | Baseline start | Baseline finish | Baseline duration | Total slack | Free slack | Text14 | Text23 |
| --- | --- | --- | --- | --- | --- | --- | --- | --- | --- | --- | --- | --- | --- | --- | --- |
| 105 | 5.2 | **Harness** | 55d | 2003-09-29 | 2003-12-17 |  |  |  | 2003-07-18 | 2003-10-03 | 55d | 10d |  |  |  |
| 106 | 5.2.1 | **Fabrication** | 25d | 2003-09-29 | 2003-11-03 |  |  |  | 2003-07-18 | 2003-08-21 | 25d | 10d |  |  |  |
| 107 | 5.2.1.1 | Machine FM 1 Harness Parts | 25d | 2003-09-29 | 2003-11-03 | 93 |  |  | 2003-07-18 | 2003-08-21 | 25d | 10d | 0d | Boom | FM 1 Harness Parts Fabricated |
| 108 | 5.2.2 | **Assembly** | 20d | 2003-11-04 | 2003-12-03 |  |  |  | 2003-08-22 | 2003-09-19 | 20d | 10d |  |  |  |
| 109 | 5.2.2.1 | Assemble FM 1 Harness subassembly | 20d | 2003-11-04 | 2003-12-03 | 107 |  |  | 2003-08-22 | 2003-09-19 | 20d | 10d | 0d | Boom | FM 1 Harness subassembly Assembled |
| 110 | 5.2.3 | FM1 Harness Test | 10d | 2003-12-04 | 2003-12-17 | 109 |  |  | 2003-09-22 | 2003-10-03 | 10d | 10d |  |  | FM 1 Harness Tested |
| 111 | 5.3 | **Mounting** | 40d | 2003-10-07 | 2003-12-03 |  |  |  | 2003-07-25 | 2003-09-19 | 40d | 20d |  |  |  |
| 112 | 5.3.1 | FM 1Boom Structure Mounting Fabrication | 20d | 2003-10-07 | 2003-11-03 | 94 |  |  | 2003-07-25 | 2003-08-21 | 20d | 20d | 0d | Boom | FM 1 Boom Structure Mounting Fabricated |
| 113 | 5.3.2 | FM 1Boom Structure Mounting Assembly | 10d | 2003-11-04 | 2003-11-18 | 112 |  |  | 2003-08-22 | 2003-09-05 | 10d | 20d | 0d | Boom | FM 1 Boom Structure Mounting Assemblies Assembled |
| 114 | 5.3.3 | FM 1 Boom Structure Mounting Test | 10d | 2003-11-19 | 2003-12-03 | 113 |  |  | 2003-09-08 | 2003-09-19 | 10d | 20d |  | Boom | FM 1 Boom Structure Mountings Tested |
| 115 | 5.4 | **Integration & Test** | 78d | 2004-01-05 | 2004-04-23 |  |  |  | 2003-11-18 | 2004-03-11 | 78d | 0d |  |  |  |
| 116 | 5.4.1 | Integrate FM 1 Boom Structure subassemblies | 20d | 2004-01-05 | 2004-02-02 | 104, 110, 114 |  |  | 2003-11-18 | 2003-12-16 | 20d | 0d |  | Boom | FM 1 Boom Structure subassemblies Integrated |
| 117 | 5.4.2 | FM 1 Boom Structure Deployment Test | 10d | 2004-02-03 | 2004-02-17 | 116 |  |  | 2003-12-17 | 2003-12-31 | 10d | 0d |  | Boom | FM 1 Boom Structure Deployment Testing Completed |
| 118 | 5.4.3 | FM 1 Boom Structure Vibration Testing Completed | 4d | 2004-02-18 | 2004-02-23 | 117 |  |  | 2004-01-02 | 2004-01-07 | 4d | 0d |  | Boom | FM 1 Boom Structure Vibration Test |
| 119 | 5.4.4 | FM 1 Boom Structure Themal Vac Testing Completed | 30d | 2004-02-24 | 2004-04-05 | 118 |  |  | 2004-01-08 | 2004-02-20 | 30d | 0d |  | Boom | FM 1 Boom Structure Themal Vac Testing |
| 120 | 5.4.5 | FM 1 Boom Structure Post Environmental Deployment Test Completed | 4d | 2004-04-06 | 2004-04-09 | 119 |  |  | 2004-02-23 | 2004-02-26 | 4d | 0d |  | Boom | FM 1 Boom Structure Post Environmental Deployment Test |
| 121 | 5.4.6 | Document FM 1 Boom Structure Test Results | 5d | 2004-04-12 | 2004-04-16 | 120 |  |  | 2004-02-27 | 2004-03-04 | 5d | 5d | 0d | Boom |  |
| 122 | 5.4.7 | FM 1 Boom Structure Bakeout | 10d | 2004-04-12 | 2004-04-23 | 120 |  |  | 2004-02-27 | 2004-03-11 | 10d | 0d |  | Boom |  |
| 123 | 6 | **FM 2** | 275d | 2003-03-24 A | 2004-04-23 |  | 11% | 244.78d | 2000-01-03 | 2004-03-11 | 1052d | 0d |  |  |  |
| 124 | 6.1 | **Telescoping** | 61d | 2003-10-03 | 2004-01-02 |  |  |  | 2000-01-03 | 2003-11-17 | 974d | 0d |  |  |  |
| 125 | 6.1.1 | **Fabrication** | 31d | 2003-10-03 | 2003-11-18 |  |  |  | 2003-08-06 | 2003-10-02 | 41d | 0d |  |  |  |
| 126 | 6.1.1.1 | Machine FM 2 Boom Structure Tubes as necessary | 10d | 2003-10-03 | 2003-10-17 | 97 |  |  | 2003-08-06 | 2003-08-19 | 10d | 21d |  | Boom |  |
| 127 | 6.1.1.2 | Machine FM 2 Boom Structure Telescoping Parts | 25d | 2003-10-14 | 2003-11-18 | 92 |  |  | 2003-08-28 | 2003-10-02 | 25d | 0d |  | Boom | FM 2 Boom Structure Partes Fabricated |
| 128 | 6.1.2 | Assemble FM 2 Boom Structure Telescoping Assembly | 20d | 2003-11-19 | 2003-12-17 | 126, 127 |  |  | 2003-10-03 | 2003-10-31 | 20d | 0d |  | Boom | FM 2 Boom Structure Telescoping Assembly Assembled |
| 129 | 6.1.3 | Test FM 2 Boom Structure Telescoping Assembly | 10d | 2003-12-18 | 2004-01-02 | 128 |  |  | 2003-11-03 | 2003-11-17 | 10d | 0d |  | Boom | FM 2 Boom Structure Telescoping Assembly Tested |

| ID | WBS | Task | Duration | Start | Finish | Predecessors | Complete | Baseline start | Baseline finish | Baseline duration | Total slack | Free slack | Constraint | Text14 | Text23 |
| --- | --- | --- | --- | --- | --- | --- | --- | --- | --- | --- | --- | --- | --- | --- | --- |
| 130 | 6.2 | **Harness** | 55d | 2003-09-29 | 2003-12-17 |  |  | 2003-07-18 | 2003-10-03 | 55d | 10d |  |  |  |  |
| 131 | 6.2.1 | **Fabrication** | 25d | 2003-09-29 | 2003-11-03 |  |  | 2003-07-18 | 2003-08-21 | 25d | 10d |  |  |  |  |
| 132 | 6.2.1.1 | Machine FM 2 Harness Parts | 25d | 2003-09-29 | 2003-11-03 | 93 |  | 2003-07-18 | 2003-08-21 | 25d | 10d | 0d |  | Boom | FM 2 Harness Parts Fabricated |
| 133 | 6.2.2 | **Assembly** | 20d | 2003-11-04 | 2003-12-03 |  |  | 2003-08-22 | 2003-09-19 | 20d | 10d |  |  |  |  |
| 134 | 6.2.2.1 | Assemble FM 2 Harness subassembly | 20d | 2003-11-04 | 2003-12-03 | 132 |  | 2003-08-22 | 2003-09-19 | 20d | 10d | 0d |  | Boom | FM 2 Harness subassembly Assembled |
| 135 | 6.2.3 | FM 2 Harness Test | 10d | 2003-12-04 | 2003-12-17 | 134 |  | 2003-09-22 | 2003-10-03 | 10d | 10d |  |  | Boom | FM 2 Harness Tested |
| 136 | 6.3 | **Mounting** | 40d | 2003-10-07 | 2003-12-03 |  |  | 2003-07-25 | 2003-09-19 | 40d | 20d |  |  |  |  |
| 137 | 6.3.1 | FM 2 Boom Structure Mountings Fabrication | 20d | 2003-10-07 | 2003-11-03 | 94 |  | 2003-07-25 | 2003-08-21 | 20d | 20d | 0d |  | Boom | FM 2 Boom Structure Mounting Fabricated |
| 138 | 6.3.2 | FM 2 Boom Structure Mountings Assembly | 10d | 2003-11-04 | 2003-11-18 | 137 |  | 2003-08-22 | 2003-09-05 | 10d | 20d | 0d |  | Boom | FM 2 Boom Structure Mounting Assemblies Assembled |
| 139 | 6.3.3 | FM 2 Boom Structure Mountings Test | 10d | 2003-11-19 | 2003-12-03 | 138 |  | 2003-09-08 | 2003-09-19 | 10d | 20d |  |  | Boom | FM 2 Boom Structure Mountings Tested |
| 140 | 6.4 | **Integration & Test** | 78d | 2004-01-05 | 2004-04-23 |  |  | 2003-11-18 | 2004-03-11 | 78d | 0d |  |  |  |  |
| 141 | 6.4.1 | Integrate FM 2 Boom Structure subassemblies | 20d | 2004-01-05 | 2004-02-02 | 129, 135, 139 |  | 2003-11-18 | 2003-12-16 | 20d | 0d |  |  | Boom | FM 2 Boom Structure subassemblies Integrated |
| 142 | 6.4.2 | FM 2 Boom Structure Deployment Test | 10d | 2004-02-03 | 2004-02-17 | 141 |  | 2003-12-17 | 2003-12-31 | 10d | 0d |  |  | Boom | FM 2 Boom Structure Deployment Testing Completed |
| 143 | 6.4.3 | FM 2 Boom Structure Vibration Test | 4d | 2004-02-18 | 2004-02-23 | 142 |  | 2004-01-02 | 2004-01-07 | 4d | 0d |  |  | Boom | FM 2 Boom Structure Vibration Test |
| 144 | 6.4.4 | FM 2 Boom Structure Themal Vac Testing | 30d | 2004-02-24 | 2004-04-05 | 143 |  | 2004-01-08 | 2004-02-20 | 30d | 0d |  |  | Boom | FM 2 Boom Structure Themal Vac Testing |
| 145 | 6.4.5 | FM 2 Boom Structure Post Environmental Deployment Test | 4d | 2004-04-06 | 2004-04-09 | 144 |  | 2004-02-23 | 2004-02-26 | 4d | 0d |  |  | Boom | FM 2 Boom Structure Post Environmental Deployment Test |
| 146 | 6.4.6 | Document FM 2 Boom Structure Test Results | 5d | 2004-04-12 | 2004-04-16 | 145 |  | 2004-02-27 | 2004-03-04 | 5d | 5d | 0d |  | Boom |  |
| 147 | 6.4.7 | FM 2 Boom Structure Bakeout | 10d | 2004-04-12 | 2004-04-23 | 145 |  | 2004-02-27 | 2004-03-11 | 10d | 0d |  |  | Boom |  |
| 148 | 6.5 | **Blanket Model** | 30d | 2003-03-24 A | 2003-05-02 A |  | 100% | 2003-03-24 | 2003-05-02 | 30d |  |  |  |  |  |
| 149 | 6.5.1 | Create Boom Structure Blanket Mockup Drawings | 5d | 2003-03-24 A | 2003-03-28 A | 18 | 100% | 2003-03-24 | 2003-03-28 | 5d |  |  | start no earlier than 2003-03-24 |  |  |
| 150 | 6.5.2 | Fabricate Boom Structure Blanket Mockup | 25d | 2003-03-31 A | 2003-05-02 A | 149 | 100% | 2003-03-31 | 2003-05-02 | 25d |  |  |  |  | Boom Structure Blanket Mockup Fabricated |
