# HET - High Energy Telescope

Schedule from MS Project, 2000-09-05 to 2004-03-15, status date 2003-07-31, A marks actual dates.
HET Instrument Development Schedule
NASA GSFC
Status Date: 07/31/2003 / Baseline Date: 01/31/2003 R1

## Calendars

- Standard w/ 10 Gov't Holidays: Mon-Fri 08:00-12:00, 13:00-17:00; Sat-Sun off. Exceptions (off unless hours are given): 2000-10-09, 2000-11-13, 2000-11-23, 2000-12-25, 2001-01-01, 2001-01-15, 2001-02-19, 2001-05-28, 2001-07-04, 2001-09-03, 2001-10-08, 2001-11-12, 2001-11-22, 2001-12-25, 2002-01-01, 2002-01-14, 2002-02-18, 2002-05-27, 2002-07-04, 2002-09-02, 2002-10-14, 2002-11-11, 2002-11-28, 2002-12-25, 2003-01-01, 2003-01-13, 2003-02-17, 2003-05-26, 2003-07-04, 2003-09-01, 2003-10-06, 2003-11-10, 2003-11-27, 2003-12-25, 2004-01-01, 2004-01-12, 2004-02-16.

## Schedule

| ID | WBS | Task | Type | Duration | Start | Finish | Predecessors | Complete | Remaining | Baseline start | Baseline finish | Baseline duration | Total slack | Free slack | Constraint | Text11 | Text12 | Text13 | Text14 | Text16 | Text28 | Text20 | Text22 | Text23 | Text21 |
| --- | --- | --- | --- | --- | --- | --- | --- | --- | --- | --- | --- | --- | --- | --- | --- | --- | --- | --- | --- | --- | --- | --- | --- | --- | --- |
| 1 | 1 | **Management** |  | 674.25d | 2001-06-27 A | 2004-03-08 |  | 90% | 70.12d | 2001-06-27 | 2004-01-22 | 644d | 0d |  |  | STEREO | IMPACT | SEP Package | HET | HET | GSFC |  |  |  |  |
| 2 | 1.1 | **Milestones** |  | 674.25d | 2001-06-27 A | 2004-03-08 |  | 50% | 337.12d | 2001-06-27 | 2004-01-22 | 644d | 0d |  |  | STEREO | IMPACT | SEP Package | HET | HET | GSFC |  |  |  |  |
| 3 | 1.1.1 | HET Software Requirements Review |  | 1d | 2002-08-22 A | 2002-08-22 A | 35 | 100% |  | 2002-08-22 | 2002-08-22 | 1d |  |  | start no earlier than 2002-08-06 | STEREO | IMPACT | SEP Package | HET | HET | GSFC |  |  |  |  |
| 4 | 1.1.2 | HET Flight Detectors Ordered | milestone | 0d | 2003-02-19 A | 2003-02-19 A | 82SS | 100% |  | 2003-02-05 | 2003-02-05 | 0d |  |  |  | STEREO | IMPACT | SEP Package | HET | HET | GSFC | Order HET Flight Detectors | HET - Place Flight Detector Order | Place Flight Detector Order |  |
| 5 | 1.1.3 | HET Flight Detectors Received | milestone | 0d | 2003-09-22 | 2003-09-22 | 4FS+150d, 20 |  |  | 2003-09-08 | 2003-09-08 | 0d | 67.25d | 0d |  | STEREO | IMPACT | SEP Package | HET | HET | GSFC | All HET Flight Detectors Received | HET - All Flight Detectors Received | All Flight Detectors Received |  |
| 6 | 1.1.4 | **Contingency** |  | 166.25d | 2003-07-07 | 2004-03-08 |  |  |  | 2003-02-06 | 2004-01-22 | 240d | 0d |  |  | STEREO | IMPACT | SEP Package | HET | HET | GSFC |  |  |  |  |
| 7 | 1.1.4.1 | CPU24 Multitasking System Design Contingency | milestone | 0d | 2003-07-07 | 2003-07-07 | 18 |  |  | 2003-02-06 | 2003-02-06 | 0d | 166.25d | 0d | start no earlier than 2003-05-31 | STEREO | IMPACT | SEP Package | HET | HET | GSFC |  |  |  |  |
| 8 | 1.1.4.2 | HET S/W Delivery to CIT for SEP Central I/F Testing Contingency | milestone | 0d | 2003-10-08 | 2003-10-08 | 191, 207, 206, 205 |  |  | 2003-05-28 | 2003-05-28 | 0d | 101.25d | 0d | finish no earlier than 2003-10-08 | STEREO | IMPACT | SEP Package | HET | HET | GSFC |  |  |  |  |
| 9 | 1.1.4.3 | HET FM 1 Delivery to CIT for SEP I & T Contingency | milestone | 0d | 2004-02-11 | 2004-02-11 | 195 |  |  | 2003-12-23 | 2003-12-23 | 0d | 6.75d | 0d |  | STEREO | IMPACT | SEP Package | HET | HET | GSFC |  |  |  |  |
| 10 | 1.1.4.4 | HET FM 2 Delivery to CIT for SEP I & T Contingency | milestone | 0d | 2004-03-08 | 2004-03-08 | 198 |  |  | 2004-01-22 | 2004-01-22 | 0d | 0d |  |  | STEREO | IMPACT | SEP Package | HET | HET | GSFC |  |  |  |  |
| 11 | 1.1.5 | **Receivables** |  | 211d | 2001-06-27 A | 2002-05-01 A |  | 100% |  | 2001-06-27 | 2002-05-01 | 211d |  |  |  | STEREO | IMPACT | SEP Package | HET | HET | GSFC |  |  |  |  |
| 12 | 1.2.4.15 | Deliver Sample Flight VLSI Chip to GSFC | milestone | 0d | 2002-05-01 A | 2002-05-01 A |  | 100% |  | 2002-05-01 | 2002-05-01 | 0d |  |  |  | STEREO | IMPACT | SEP Package | HET | HET | GSFC |  |  |  |  |
| 13 | 1.1.5.2 | Receive PHA Chip From CIT | milestone | 0d | 2002-05-01 A | 2002-05-01 A | 12 | 100% |  | 2002-05-01 | 2002-05-01 | 0d |  |  |  | STEREO | IMPACT | SEP Package | HET | HET | CIT |  |  |  |  |
| 14 | 1.1.5.3 | Receive MISC Design From CIT | milestone | 0d | 2001-08-01 A | 2001-08-01 A | 181FS-5d | 100% |  | 2001-08-01 | 2001-08-01 | 0d |  |  | start no earlier than 2001-08-01 | STEREO | IMPACT | SEP Package | HET | HET | CIT |  |  |  |  |
| 15 | 1.1.4.13 | Deliver VLSI Chip Definition to SIT and HET |  | 1d | 2001-06-27 A | 2001-06-27 A |  | 100% |  | 2001-06-27 | 2001-06-27 | 1d |  |  |  | STEREO | IMPACT | SEP Package | HET | HET | GSFC |  |  |  |  |
| 16 | 1.1.5.5 | Receive VLSI Chip Definition From CIT For SIT and HET | milestone | 0d | 2001-06-27 A | 2001-06-27 A | 15 | 100% |  | 2001-06-27 | 2001-06-27 | 0d |  |  |  | STEREO | IMPACT | SEP Package | HET | HET | GSFC |  |  |  |  |
| 17 | 1.1.6 | **Deliverables** |  | 179.25d | 2003-06-17 A | 2004-03-08 |  |  | 179.25d | 2003-02-06 | 2004-01-22 | 240d | 0d |  |  | STEREO | IMPACT | SEP Package | HET | HET | GSFC |  |  |  |  |
| 18 | 1.1.6.1 | Design of CPU24 Multitasking System Available For Delivery To SIT | milestone | 0d | 2003-07-07 | 2003-07-07 | 166 |  |  | 2003-02-06 | 2003-02-06 | 0d | 166.25d | 0d | start no earlier than 2003-05-31 | STEREO | IMPACT | SEP Package | HET | HET | GSFC |  |  |  |  |
| 19 | 1.1.6.2 | Deliver CPU24 Processing System Design to SIT | milestone | 0d | 2003-07-07 | 2003-07-07 | 7 |  |  | 2003-02-06 | 2003-02-06 | 0d | 166.25d |  | start no earlier than 2003-05-31 | STEREO | IMPACT | SEP Package | HET | HET | GSFC |  |  |  |  |
| 20 | 1.1.6.3 | Deliver HET H3 Mounts to MICRON |  | 1d | 2003-07-25 | 2003-07-28 | 111 |  |  | 2003-07-25 | 2003-07-28 | 1d | 106.75d | 39.5d | start no earlier than 2003-04-30 | STEREO | IMPACT | SEP Package | HET | HET | GSFC |  |  |  |  |
| 21 | 1.1.6.4 | Deliver HET EM to CIT | milestone | 0d | 2003-06-17 A | 2003-06-17 A | 149 | 100% |  | 2003-05-13 | 2003-05-13 | 0d |  |  | finish no later than 2003-05-30 | STEREO | IMPACT | SEP Package | HET | HET | GSFC | HET EM | HET - Deliver EM to CIT | Deliver EM to CIT |  |
| 22 | 1.2.6.6.2 | Receive HET EM for SEP EM I & T | milestone | 0d | 2003-07-08 A | 2003-07-08 A | 21FS+5d | 100% |  | 2003-07-08 | 2003-07-08 | 0d |  |  | start no earlier than 2003-07-08 | STEREO | IMPACT | SEP Package | HET | HET | GSFC |  |  |  |  |
| 23 | 1.1.6.6 | Deliver HET S/W for SEP Central MISC/HET CPU24 Testing | milestone | 0d | 2003-10-08 | 2003-10-08 | 8 |  |  | 2003-05-28 | 2003-05-28 | 0d | 101.25d |  |  | STEREO | IMPACT | SEP Package | HET | HET | GSFC |  |  | S/W Delivery for SEP Central MISC/HET CPU24 Testing |  |
| 24 | 1.1.5.2.2 | (OBSOLETE) Receive HET S/W for SEP Central I/F Testing | milestone | 0d | 2003-06-30 A | 2003-06-30 A | 23 | 100% |  | 2003-05-28 | 2003-05-28 | 0d |  |  |  | STEREO | IMPACT | SEP Package | HET | HET | GSFC |  |  |  |  |
| 25 | 1.1.6.8 | Deliver HET FM 1 for SEP I & T | milestone | 0d | 2004-02-11 | 2004-02-11 | 9 |  |  | 2003-12-23 | 2003-12-23 | 0d | 6.75d | 0d |  | STEREO | IMPACT | SEP Package | HET | HET | GSFC | HET FM 1 | HET - FM 1 Delivery for SEP I & T | FM 1 Delivery for SEP I & T | HET FM 1 & FM 2 to CIT |
| 26 | 1.2.6.6.4 | Receive HET FM 1 From GSFC For SEP FM 1 I & T | milestone | 0d | 2004-02-19 | 2004-02-19 | 25FS+5d |  |  | 2003-12-31 | 2003-12-31 | 0d | 6.75d | 0d |  | STEREO | IMPACT | SEP Package | HET | HET | GSFC |  |  |  |  |
| 27 | 1.1.6.10 | Deliver HET FM 2 for SEP I & T | milestone | 0d | 2004-03-08 | 2004-03-08 | 10 |  |  | 2004-01-22 | 2004-01-22 | 0d | 0d |  |  | STEREO | IMPACT | SEP Package | HET | HET | GSFC | HET FM 2 | HET - FM 2 Delivery for SEP I & T | FM 2 Delivery for SEP I & T | HET FM 1 & FM 2 to CIT |
| 28 | 1.2.6.6.6 | Receive HET FM 2 From GSFC For SEP FM 2 I & T | milestone | 0d | 2004-03-15 | 2004-03-15 | 27FS+5d |  |  | 2004-01-29 | 2004-01-29 | 0d | 7.75d | 0d |  | STEREO | IMPACT | SEP Package | HET | HET | GSFC |  |  |  |  |

Notes:
- 7: Removed 45 days of duration 1/9/03
- 8: Removed 11 days of duration 1/9/03
- 23: FNL of 4/15/03 removed 1/9/03
- 25: FNL of 12/9/03 removed 1/9/03
- 27: FNL of 12/9/03 removed 1/9/03

| ID | WBS | Task | Duration | Start | Finish | Predecessors | Complete | Remaining | Baseline start | Baseline finish | Baseline duration | Total slack | Free slack | Constraint | Text11 | Text12 | Text13 | Text14 | Text16 | Text28 | Text19 |
| --- | --- | --- | --- | --- | --- | --- | --- | --- | --- | --- | --- | --- | --- | --- | --- | --- | --- | --- | --- | --- | --- |
| 29 | 1.2 | **Documentation** | 468.25d | 2001-10-01 A | 2003-08-13 |  | 90% | 46.83d | 2001-10-01 | 2003-03-28 | 373d | 140d |  |  | STEREO | IMPACT | SEP Package | HET | HET | GSFC |  |
| 30 | 1.2.1 | HET Design Requirements Document | 61d | 2001-11-01 A | 2003-07-07 |  | 95% | 3.05d | 2001-11-01 | 2003-02-06 | 61d | 167.2d | 0d | start no earlier than 2001-11-01 | STEREO | IMPACT | SEP Package | HET | HET | GSFC |  |
| 31 | 1.2.2 | **HET On-Board Software Specification** | 468.25d | 2001-10-01 A | 2003-08-13 |  | 88% | 57.25d | 2001-10-01 | 2003-03-28 | 373d | 5d |  |  | STEREO | IMPACT | SEP Package | HET | HET | GSFC |  |
| 32 | 1.2.2.1 | Define HET PH Event Processing | 61d | 2001-10-01 A | 2003-07-23 |  | 75% | 15.25d | 2001-10-01 | 2003-02-25 | 61d | 18.5d | 0d |  | STEREO | IMPACT | SEP Package | HET | HET | GSFC |  |
| 33 | 1.2.2.2 | Produce HET Command List | 24d | 2003-05-01 A | 2003-07-08 A | 32FS-61d | 100% |  | 2003-02-03 | 2003-03-07 | 24d |  |  | start no earlier than 2003-04-30 | STEREO | IMPACT | SEP Package | HET | HET | GSFC |  |
| 34 | 1.2.2.3 | Define HET Telemetry Format | 24d | 2003-04-01 A | 2003-05-07 A | 32FS-56d | 100% |  | 2003-02-03 | 2003-03-07 | 24d |  |  | start no earlier than 2003-03-31 | STEREO | IMPACT | SEP Package | HET | HET | GSFC |  |
| 35 | 1.2.2.4 | Review Preliminary HET On-Board Software Specification | 13d | 2002-02-01 A | 2002-02-20 A | 34, 33, 32 | 100% |  | 2002-02-01 | 2002-02-20 | 13d |  |  | start no earlier than 2002-04-30 | STEREO | IMPACT | SEP Package | HET | HET | GSFC |  |
| 36 | 1.2.2.5 | Write Final HET On-Board Software Specification | 15d | 2003-07-23 A | 2003-08-13 | 35FS-5d, 3, 34, 33, 32 | 90% | 1.5d | 2003-03-10 | 2003-03-28 | 15d | 5d | 0d | start no earlier than 2003-02-01 | STEREO | IMPACT | SEP Package | HET | HET | GSFC |  |
| 37 | 2 | **Systems Engineering** | 738d | 2000-09-05 A | 2003-08-13 |  | 97% | 20.59d | 2000-09-05 | 2003-08-13 | 738d | 108.25d |  |  | STEREO | IMPACT | SEP Package | HET | HET | GSFC |  |
| 38 | 2.1 | **Documentation** | 503d | 2001-08-13 A | 2003-08-13 |  | 92% | 42.45d | 2001-08-13 | 2003-08-13 | 503d | 108.25d |  |  | STEREO | IMPACT | SEP Package | HET | HET | GSFC |  |
| 39 | 2.1.1 | HET ICD Drawings | 60d | 2001-08-13 A | 2001-11-06 A | 45 | 100% |  | 2001-08-13 | 2001-11-06 | 60d |  |  |  | STEREO | IMPACT | SEP Package | HET | HET | GSFC |  |
| 40 | 2.1.2 | Write PHA Chip Test Procedure | 13.5d | 2002-09-09 A | 2002-09-26 A | 147 | 100% |  | 2002-09-09 | 2002-09-26 | 13.5d |  |  | start no earlier than 2002-06-30 | STEREO | IMPACT | SEP Package | HET | HET | GSFC | Larry |
| 41 | 2.1.3 | Write HET Electronics Test Procedure | 10d | 2003-06-02 A | 2003-06-13 A | 131 | 100% |  | 2003-03-20 | 2003-04-02 | 10d |  |  | start no earlier than 2003-05-31 | STEREO | IMPACT | SEP Package | HET | HET | GSFC |  |
| 42 | 2.1.4 | Write CPU24 Processor Manual | 25d | 2001-12-27 A | 2002-02-01 A | 172FS-15d | 100% |  | 2001-12-27 | 2002-02-01 | 25d |  |  |  | STEREO | IMPACT | SEP Package | HET | HET | GSFC |  |
| 43 | 2.1.5 | Write HET Test Procedure | 10d | 2003-07-31 | 2003-08-13 |  |  |  | 2003-07-31 | 2003-08-13 | 10d | 108.25d |  | start no earlier than 2003-07-31 | STEREO | IMPACT | SEP Package | HET | HET | GSFC |  |
| 44 | 2.2 | **Studies** | 336d | 2000-09-05 A | 2002-01-08 A |  | 100% |  | 2000-09-05 | 2002-01-08 | 336d |  |  |  | STEREO | IMPACT | SEP Package | HET | HET | GSFC |  |
| 45 | 2.2.1 | Field of View Analysis | 235d | 2000-09-05 A | 2001-08-10 A |  | 100% |  | 2000-09-05 | 2001-08-10 | 235d |  |  | start no earlier than 2000-09-05 | STEREO | IMPACT | SEP Package | HET | HET | GSFC |  |
| 46 | 2.2.2 | Study PHA Chip Definition | 5d | 2002-01-02 A | 2002-01-08 A |  | 100% |  | 2002-01-02 | 2002-01-08 | 5d |  |  | start no earlier than 2002-01-02 | STEREO | IMPACT | SEP Package | HET | HET | GSFC |  |
| 47 | 3 | **Mechanical** | 314d | 2002-09-03 A | 2003-12-03 |  | 54% | 143.87d | 2002-09-03 | 2003-11-18 | 304d | 63.25d |  |  | STEREO | IMPACT | SEP Package | HET | HET | GSFC |  |
| 48 | 3.1 | **Design, Manufacture, Assembly and Test** | 314d | 2002-09-03 A | 2003-12-03 |  | 54% | 143.87d | 2002-09-03 | 2003-11-18 | 304d | 63.25d |  |  | STEREO | IMPACT | SEP Package | HET | HET | GSFC |  |
| 49 | 3.1.1 | **Procurements** | 2d | 2003-10-13 | 2003-10-15 |  |  |  | 2003-02-25 | 2003-02-26 | 2d | 27.65d |  |  | STEREO | IMPACT | SEP Package | HET | HET | GSFC |  |
| 50 | 3.1.1.1 | **FM 1 & FM 2** | 2d | 2003-10-13 | 2003-10-15 |  |  |  | 2003-02-25 | 2003-02-26 | 2d | 27.65d |  |  | STEREO | IMPACT | SEP Package | HET | HET | GSFC |  |
| 51 | 3.1.1.1.1 | Place Order For HET FM1, HET FM 2, HET Spare Housing | 2d | 2003-10-13 | 2003-10-15 | 124, 53 |  |  | 2003-02-25 | 2003-02-26 | 2d | 27.65d | 0d | start no earlier than 2003-05-31 | STEREO | IMPACT | SEP Package | HET | HET | GSFC | Sandy Shuman |
| 52 | 3.1.2 | **Design** | 278.6d | 2002-09-03 A | 2003-10-13 |  | 81% | 52.93d | 2002-09-03 | 2003-02-24 | 118d | 27.65d |  |  | STEREO | IMPACT | SEP Package | HET | HET | GSFC |  |
| 53 | 3.1.2.1 | Design HET Housing | 99d | 2002-09-03 A | 2003-10-13 | 88FS+4d, 86FS+4d | 81% | 18.81d | 2002-09-03 | 2003-02-24 | 34d | 27.65d | 0d | finish no earlier than 2003-02-24 | STEREO | IMPACT | SEP Package | HET | HET | GSFC | Sandy Shuman |

| ID | WBS | Task | Duration | Start | Finish | Predecessors | Complete | Remaining | Baseline start | Baseline finish | Baseline duration | Total slack | Free slack | Constraint | Text11 | Text12 | Text13 | Text14 | Text16 | Text28 | Text19 | Text23 |
| --- | --- | --- | --- | --- | --- | --- | --- | --- | --- | --- | --- | --- | --- | --- | --- | --- | --- | --- | --- | --- | --- | --- |
| 54 | 3.1.3 | **Fabrication** | 3d | 2003-10-30 | 2003-11-04 |  |  |  | 2003-03-14 | 2003-03-18 | 3d | 27.65d |  |  | STEREO | IMPACT | SEP Package | HET | HET | GSFC |  |  |
| 55 | 3.1.3.1 | **FM 1 & FM 2** | 3d | 2003-10-30 | 2003-11-04 |  |  |  | 2003-03-14 | 2003-03-18 | 3d | 27.65d |  |  | STEREO | IMPACT | SEP Package | HET | HET | GSFC |  |  |
| 56 | 3.1.3.1.1 | **FM 1** | 3d | 2003-10-30 | 2003-11-04 |  |  |  | 2003-03-14 | 2003-03-18 | 3d | 27.65d |  |  | STEREO | IMPACT | SEP Package | HET | HET | GSFC |  |  |
| 57 | 3.1.3.1.1.1 | Inspect HET FM 1 Housing | 3d | 2003-10-30 | 2003-11-04 | 51FS+11d |  |  | 2003-03-14 | 2003-03-18 | 3d | 27.65d | 0.4d | start no earlier than 2003-05-31 | STEREO | IMPACT | SEP Package | HET | HET | GSFC | Sandy Shuman | FM 1 Housing Fabricated and Inspected |
| 58 | 3.1.3.1.2 | **FM 2** | 3d | 2003-10-30 | 2003-11-04 |  |  |  | 2003-03-14 | 2003-03-18 | 3d | 41.65d |  |  | STEREO | IMPACT | SEP Package | HET | HET | GSFC |  |  |
| 59 | 3.1.3.1.2.1 | Inspect HET FM 2 Housing | 3d | 2003-10-30 | 2003-11-04 | 51FS+11d |  |  | 2003-03-14 | 2003-03-18 | 3d | 41.65d | 0.4d | start no earlier than 2003-05-31 | STEREO | IMPACT | SEP Package | HET | HET | GSFC | Sandy Shuman | FM 2 Housing Fabricated and Inspected |
| 60 | 3.1.3.2 | **Spare** | 3d | 2003-10-30 | 2003-11-04 |  |  |  | 2003-03-14 | 2003-03-18 | 3d | 82.65d |  |  | STEREO | IMPACT | SEP Package | HET | HET | GSFC |  |  |
| 61 | 3.1.3.2.1 | Inspect HET Spare Housing | 3d | 2003-10-30 | 2003-11-04 | 51FS+11d |  |  | 2003-03-14 | 2003-03-18 | 3d | 82.65d |  | start no earlier than 2003-05-31 | STEREO | IMPACT | SEP Package | HET | HET | GSFC | Sandy Shuman | Spare Housing Fabricated and Inspected |
| 62 | 3.1.4 | **Assembly** | 9d | 2003-11-05 | 2003-11-18 |  |  |  | 2003-10-22 | 2003-11-03 | 9d | 27.25d |  |  | STEREO | IMPACT | SEP Package | HET | HET | GSFC |  |  |
| 63 | 3.1.4.1 | **FM 1** | 9d | 2003-11-05 | 2003-11-18 |  |  |  | 2003-10-22 | 2003-11-03 | 9d | 27.25d |  |  | STEREO | IMPACT | SEP Package | HET | HET | GSFC |  |  |
| 64 | 3.1.4.1.1 | Assemble HET FM 1 Telescope Without Electronics | 9d | 2003-11-05 | 2003-11-18 | 57, 113 |  |  | 2003-10-22 | 2003-11-03 | 9d | 27.25d | 0d |  | STEREO | IMPACT | SEP Package | HET | HET | GSFC | Sandy Shuman | FM 1 Telescope Assembled without Electronics |
| 65 | 3.1.4.2 | **FM 2** | 9d | 2003-11-05 | 2003-11-18 |  |  |  | 2003-10-22 | 2003-11-03 | 9d | 41.25d |  |  | STEREO | IMPACT | SEP Package | HET | HET | GSFC |  |  |
| 66 | 3.1.4.2.1 | Assemble HET FM 2 Telescope Without Electronics | 9d | 2003-11-05 | 2003-11-18 | 59, 113 |  |  | 2003-10-22 | 2003-11-03 | 9d | 41.25d | 0d |  | STEREO | IMPACT | SEP Package | HET | HET | GSFC | Sandy Shuman | FM 2 Telescope Assembled without Electronics |
| 67 | 3.1.5 | **Test** | 10d | 2003-11-19 | 2003-12-03 |  |  |  | 2003-11-04 | 2003-11-18 | 10d | 27.25d |  |  | STEREO | IMPACT | SEP Package | HET | HET | GSFC |  |  |
| 68 | 3.1.5.1 | **FM 1** | 10d | 2003-11-19 | 2003-12-03 |  |  |  | 2003-11-04 | 2003-11-18 | 10d | 27.25d |  |  | STEREO | IMPACT | SEP Package | HET | HET | GSFC |  |  |
| 69 | 3.1.5.1.1 | Test HET FM 1 Telescope Without Electronics | 10d | 2003-11-19 | 2003-12-03 | 64 |  |  | 2003-11-04 | 2003-11-18 | 10d | 27.25d |  |  | STEREO | IMPACT | SEP Package | HET | HET | GSFC | Sandy Shuman | FM 1 Telescope Structure Available |
| 70 | 3.1.5.2 | **FM 2** | 10d | 2003-11-19 | 2003-12-03 |  |  |  | 2003-11-04 | 2003-11-18 | 10d | 41.25d |  |  | STEREO | IMPACT | SEP Package | HET | HET | GSFC |  |  |
| 71 | 3.1.5.2.1 | Test HET FM 2 Telescope Without Electronics | 10d | 2003-11-19 | 2003-12-03 | 66 |  |  | 2003-11-04 | 2003-11-18 | 10d | 41.25d | 32.25d |  | STEREO | IMPACT | SEP Package | HET | HET | GSFC | Sandy Shuman | FM 2 Telescope Structure Available |
| 72 | 4 | **Detector** | 445d | 2002-05-01 A | 2004-02-09 |  | 29% | 315.05d | 2002-05-01 | 2003-10-21 | 371d | 18.25d |  |  | STEREO | IMPACT | SEP Package | HET | HET | GSFC |  |  |
| 73 | 4.1 | **Design, Manufacture, Assembly and Test** | 445d | 2002-05-01 A | 2004-02-09 |  | 29% | 315.05d | 2002-05-01 | 2003-10-21 | 371d | 18.25d |  |  | STEREO | IMPACT | SEP Package | HET | HET | GSFC |  |  |
| 74 | 4.1.1 | **Procurements** | 340d | 2002-05-29 A | 2003-10-02 |  | 83% | 56.67d | 2002-05-29 | 2003-02-10 | 176d | 18.25d |  |  | STEREO | IMPACT | SEP Package | HET | HET | GSFC |  |  |
| 75 | 4.1.1.1 | **ETU** | 340d | 2002-05-29 A | 2003-10-02 |  | 80% | 68d | 2002-05-29 | 2003-02-10 | 176d | 18.25d |  |  | STEREO | IMPACT | SEP Package | HET | HET | GSFC |  |  |
| 76 | 4.1.1.1.1 | Place Order HET H1-H2 Mount Fabrication | 2d | 2002-05-29 A | 2002-05-30 A | 86 | 100% |  | 2002-05-29 | 2002-05-30 | 2d |  |  | start no earlier than 2002-04-30 | STEREO | IMPACT | SEP Package | HET | HET | GSFC | Sandy Shuman |  |
| 77 | 4.1.1.1.2 | Place Order HET H3-H6 Mounts Fabrication | 2d | 2002-06-25 A | 2002-06-26 A | 88 | 100% |  | 2002-06-25 | 2002-06-26 | 2d |  |  | start no earlier than 2002-04-30 | STEREO | IMPACT | SEP Package | HET | HET | GSFC | Sandy Shuman |  |
| 78 | 4.1.1.1.3 | Place Order for HET Test Holder Mount Fabrication | 2d | 2003-10-01 | 2003-10-02 | 89, 90 |  |  | 2003-02-07 | 2003-02-10 | 2d | 18.25d | 0d | start no earlier than 2003-10-01 | STEREO | IMPACT | SEP Package | HET | HET | GSFC | Sandy Shuman |  |
| 79 | 4.1.1.1.4 | Place Order For HET H1-H2 Prototype Detectors | 2d | 2002-10-03 A | 2002-10-04 A | 93 | 100% |  | 2002-10-03 | 2002-10-04 | 2d |  |  | start no earlier than 2002-09-30 | STEREO | IMPACT | SEP Package | HET | HET | CIT | Sandy Shuman |  |
| 80 | 4.1.1.1.5 | Place Order For HET H3-H6 Prototype Detectors | 2d | 2002-07-23 A | 2002-07-24 A | 94 | 100% |  | 2002-07-23 | 2002-07-24 | 2d |  |  | start no earlier than 2002-04-30 | STEREO | IMPACT | SEP Package | HET | HET | CIT | Sandy Shuman |  |

| ID | WBS | Task | Duration | Start | Finish | Predecessors | Complete | Remaining | Baseline start | Baseline finish | Baseline duration | Total slack | Free slack | Constraint | Text11 | Text12 | Text13 | Text14 | Text16 | Text28 | Text19 | Text23 |
| --- | --- | --- | --- | --- | --- | --- | --- | --- | --- | --- | --- | --- | --- | --- | --- | --- | --- | --- | --- | --- | --- | --- |
| 81 | 4.1.1.2 | **FM 1 & FM 2** | 2d | 2003-02-18 A | 2003-02-19 A |  | 100% |  | 2003-02-05 | 2003-02-06 | 2d |  |  |  | STEREO | IMPACT | SEP Package | HET | HET | GSFC |  |  |
| 82 | 4.1.1.2.1 | Place Order For Flight Detectors | 2d | 2003-02-18 A | 2003-02-19 A | 102, 103, 105, 106 | 100% |  | 2003-02-05 | 2003-02-06 | 2d |  |  | start no earlier than 2003-02-03 | STEREO | IMPACT | SEP Package | HET | HET | GSFC | Sandy Shuman | Flight Detectors Ordered |
| 83 | 4.1.2 | **Design** | 252d | 2002-05-01 A | 2003-05-01 A |  | 100% |  | 2002-05-01 | 2003-02-06 | 193d |  |  |  | STEREO | IMPACT | SEP Package | HET | HET | GSFC |  |  |
| 84 | 4.3.49.3 | Design LET L3 Mount | 16d | 2002-06-03 A | 2002-06-24 A |  | 100% |  | 2002-06-03 | 2002-06-24 | 16d |  |  | start no earlier than 2002-06-30 | STEREO | IMPACT | SEP Package | HET | HET | GSFC |  |  |
| 85 | 4.3.49.2 | Design LET L2 Mount | 16d | 2002-05-29 A | 2002-06-19 A |  | 100% |  | 2002-05-29 | 2002-06-19 | 16d |  |  | start no earlier than 2002-04-30 | STEREO | IMPACT | SEP Package | HET | HET | GSFC |  |  |
| 86 | 4.1.2.3 | Design H1-H2 Mounts | 19d | 2002-05-01 A | 2002-05-28 A | 39, 84, 85 | 100% |  | 2002-05-01 | 2002-05-28 | 19d |  |  | start no earlier than 2002-04-30 | STEREO | IMPACT | SEP Package | HET | HET | GSFC | Sandy Shuman |  |
| 87 | 3.1.2.1 | Design LET Housing | 90d | 2002-05-01 A | 2003-09-18 | 86, 88 | 85% | 13.5d | 2002-05-01 | 2003-02-21 | 40d | 44d | 0d | finish no earlier than 2003-02-21 | STEREO | IMPACT | SEP Package | HET | HET | GSFC |  |  |
| 88 | 4.1.2.5 | Design H3-H6 Mounts | 7d | 2002-05-22 A | 2002-06-26 A | 39, 84, 85 | 100% |  | 2002-05-22 | 2002-05-31 | 7d |  |  | start no earlier than 2002-04-30 | STEREO | IMPACT | SEP Package | HET | HET | GSFC | Sandy Shuman |  |
| 89 | 4.1.2.6 | Design H1-H2 Detector Test Holders | 5d | 2002-10-01 A | 2003-05-01 A | 86 | 100% |  | 2002-10-01 | 2003-02-06 | 5d |  |  | finish no earlier than 2003-04-01 | STEREO | IMPACT | SEP Package | HET | HET | GSFC | Sandy Shuman |  |
| 90 | 4.1.2.7 | Design H3-H6 Detector Test Holders | 5d | 2002-10-01 A | 2003-05-01 A | 88 | 100% |  | 2002-10-01 | 2003-02-06 | 5d |  |  | finish no earlier than 2003-04-01 | STEREO | IMPACT | SEP Package | HET | HET | GSFC | Sandy Shuman |  |
| 91 | 4.1.3 | **Fabrication** | 321d | 2002-07-19 A | 2003-10-28 |  | 78% | 69.1d | 2002-07-19 | 2003-06-18 | 230d | 87.25d |  |  | STEREO | IMPACT | SEP Package | HET | HET | GSFC |  |  |
| 92 | 4.1.3.1 | **ETU** | 321d | 2002-07-19 A | 2003-10-28 |  | 85% | 49.19d | 2002-07-19 | 2003-03-06 | 157d | 31.25d |  |  | STEREO | IMPACT | SEP Package | HET | HET | GSFC |  |  |
| 93 | 4.1.3.1.1 | Receive & Inspect HET ETU H1-H2 Mounts | 2d | 2002-11-01 A | 2002-11-04 A | 76FS+15d | 100% |  | 2002-11-01 | 2002-11-04 | 2d |  |  | start no earlier than 2002-10-31 | STEREO | IMPACT | SEP Package | HET | HET | GSFC | Sandy Shuman |  |
| 94 | 4.1.3.1.2 | Receive & Inspect HET ETU H3-H6 Mounts | 2d | 2002-07-19 A | 2002-07-22 A | 77FS+15d | 100% |  | 2002-07-19 | 2002-07-22 | 2d |  |  | start no earlier than 2002-04-30 | STEREO | IMPACT | SEP Package | HET | HET | GSFC | Sandy Shuman |  |
| 95 | 4.1.3.1.3 | Receive & Inspect HET Test Holder Mounts | 2d | 2003-10-27 | 2003-10-28 | 78FS+15d |  |  | 2003-03-05 | 2003-03-06 | 2d | 18.25d | 0d | start no earlier than 2003-05-31 | STEREO | IMPACT | SEP Package | HET | HET | GSFC | Sandy Shuman |  |
| 96 | 4.1.3.1.4 | Receive & Inspect HET H1-H2 ETU Detectors | 3d | 2003-04-01 A | 2003-07-01 A | 79FS+57d | 100% |  | 2003-02-03 | 2003-02-05 | 3d |  |  | start no earlier than 2003-03-31 | STEREO | IMPACT | SEP Package | HET | HET | GSFC | Sandy Shuman |  |
| 97 | 4.1.3.1.5 | Receive & Inspect HET H3-H6 ETU Detectors | 38d | 2002-11-01 A | 2002-12-27 A | 80FS+57d | 100% |  | 2002-11-01 | 2002-12-27 | 38d |  |  | start no earlier than 2002-11-30 | STEREO | IMPACT | SEP Package | HET | HET | GSFC | Sandy Shuman |  |
| 98 | 4.1.3.1.6 | Redesign and Remake H3 ETU | 15d | 2003-05-01 A | 2003-07-11 | 97 | 50% | 7.5d | 2003-05-01 | 2003-07-11 | 15d | 106.75d | 0d | start no earlier than 2003-04-30 | STEREO | IMPACT | SEP Package | HET | HET | GSFC |  |  |
| 99 | 4.1.3.2 | **FM 1 & FM 2** | 240d | 2002-08-28 A | 2003-08-12 |  | 40% | 144d | 2002-07-19 | 2003-06-18 | 230d | 140.25d |  |  | STEREO | IMPACT | SEP Package | HET | HET | GSFC |  |  |
| 100 | 4.1.3.2.1 | Receive & Inspect HET Flight Detectors | 2d | 2003-07-01 | 2003-07-02 | 82FS+89d |  |  | 2003-06-17 | 2003-06-18 | 2d | 27.25d | 0d | start no earlier than 2003-06-30 | STEREO | IMPACT | SEP Package | HET | HET | GSFC | Sandy Shuman | All Fight Detectors Received |
| 101 | 4.1.3.2.2 | **FM 1** | 240d | 2002-08-28 A | 2003-08-12 |  | 50% | 120d | 2002-07-19 | 2003-02-04 | 136d | 140.25d |  |  | STEREO | IMPACT | SEP Package | HET | HET | GSFC |  |  |
| 102 | 4.1.3.2.2.1 | Receive & Inspect HET H1-H2 Mounts For FM 1 | 2d | 2003-08-11 A | 2003-08-12 A | 76FS+15d | 100% |  | 2003-02-03 | 2003-02-04 | 2d |  |  | start no earlier than 2003-02-01 | STEREO | IMPACT | SEP Package | HET | HET | GSFC | Sandy Shuman |  |
| 103 | 4.1.3.2.2.2 | Receive & Inspect HET H3-H6 Mounts For FM 1 | 2d | 2002-08-28 | 2002-08-29 | 77 |  |  | 2002-07-19 | 2002-07-22 | 2d | 378.25d |  | start no earlier than 2002-08-28 | STEREO | IMPACT | SEP Package | HET | HET | GSFC | Sandy Shuman |  |
| 104 | 4.1.3.2.3 | **FM 2** | 240d | 2002-08-28 A | 2003-08-12 |  | 50% | 120d | 2002-07-19 | 2003-02-04 | 136d | 140.25d |  |  | STEREO | IMPACT | SEP Package | HET | HET | GSFC |  |  |
| 105 | 4.1.3.2.3.1 | Receive & Inspect HET H1-H2 Mounts For FM 2 | 2d | 2003-08-11 A | 2003-08-12 A | 76FS+15d | 100% |  | 2003-02-03 | 2003-02-04 | 2d |  |  | start no earlier than 2003-02-01 | STEREO | IMPACT | SEP Package | HET | HET | GSFC | Sandy Shuman |  |
| 106 | 4.1.3.2.3.2 | Receive & Inspect HET H3-H6 Mounts For FM 2 | 2d | 2002-08-28 | 2002-08-29 | 77 |  |  | 2002-07-19 | 2002-07-22 | 2d | 378.25d |  | start no earlier than 2002-08-28 | STEREO | IMPACT | SEP Package | HET | HET | GSFC | Sandy Shuman |  |

Notes:
- 82: This activity was delayed due to poor performance twice by the original vendor for the H1-H2 and L1 mounts. This date reflects the use of the same vendor who producted top quality H3-H6 mounts to produce the H1-H2 and L1.
- 93: This activity was delayed due to poor performance twice by the original vendor. This date reflects the use of the same vendor who producted top quality L3-L6 detectors.
- 97: Received 11/7/02
- 102: This activity was delayed due to poor performance twice by the original vendor. This date reflects the use of the same vendor who producted top quality H3-H6 detectors.
- 103: Coupons Passed
- 105: This activity was delayed due to poor performance twice by the original vendor. This date reflects the use of the same vendor who producted top quality H3-H6 detectors.
- 106: Coupons Passed

| ID | WBS | Task | Type | Duration | Start | Finish | Predecessors | Complete | Remaining | Baseline start | Baseline finish | Baseline duration | Total slack | Free slack | Constraint | Text11 | Text12 | Text13 | Text14 | Text16 | Text28 | Text21 | Text23 | Text19 |
| --- | --- | --- | --- | --- | --- | --- | --- | --- | --- | --- | --- | --- | --- | --- | --- | --- | --- | --- | --- | --- | --- | --- | --- | --- |
| 107 | 4.1.4 | **Test** |  | 150d | 2003-07-03 | 2004-02-09 |  |  |  | 2003-03-07 | 2003-10-21 | 159d | 18.25d |  |  | STEREO | IMPACT | SEP Package | HET | HET | GSFC |  |  |  |
| 108 | 4.1.4.1 | **ETU** |  | 69d | 2003-10-29 | 2004-02-09 |  |  |  | 2003-03-07 | 2003-06-12 | 69d | 18.25d |  |  | STEREO | IMPACT | SEP Package | HET | HET | GSFC |  |  |  |
| 109 | 4.1.4.1.1 | Evaluate HET ETU Detectors |  | 69d | 2003-10-29 | 2004-02-09 | 96FS-80d, 95, 97FS-30d |  |  | 2003-03-07 | 2003-06-12 | 69d | 18.25d |  | start no earlier than 2003-05-31 | STEREO | IMPACT | SEP Package | HET | HET | GSFC |  |  |  |
| 110 | 4.1.4.2 | **FM 1 & FM 2** |  | 86d | 2003-07-03 | 2003-11-04 |  |  |  | 2003-06-19 | 2003-10-21 | 86d | 27.25d |  |  | STEREO | IMPACT | SEP Package | HET | HET | GSFC |  |  |  |
| 111 | 4.1.4.2.1 | Mechanical Inspection Coupon Test & Mount Connectors |  | 10d | 2003-07-11 | 2003-07-25 | 98 |  |  | 2003-07-11 | 2003-07-25 | 10d | 106.75d | 0d | start no earlier than 2003-05-31 | STEREO | IMPACT | SEP Package | HET | HET | GSFC |  |  |  |
| 112 | 4.1.4.2.2 | Capacitance, Current, Depletion, Alpha Resin Testing |  | 76d | 2003-07-03 | 2003-10-21 | 100, 5FF-20d |  |  | 2003-06-19 | 2003-10-07 | 76d | 27.25d | 0d | start no earlier than 2003-06-30 | STEREO | IMPACT | SEP Package | HET | HET | GSFC |  |  |  |
| 113 | 4.1.4.2.3 | Life Test HET Detectors |  | 76d | 2003-07-18 | 2003-11-04 | 112SS+10d |  |  | 2003-07-03 | 2003-10-21 | 76d | 27.25d | 0d |  | STEREO | IMPACT | SEP Package | HET | HET | GSFC | HET Detect. Tested | Flight Detector Testing Completed |  |
| 114 | 5 | **Electronics** |  | 388.25d | 2002-06-28 A | 2004-01-19 |  | 53% | 182.07d | 2002-06-28 | 2003-11-14 | 347d | 12d |  |  | STEREO | IMPACT | SEP Package | HET | HET | GSFC |  |  |  |
| 115 | 5.1 | **Design, Manufacture, Assembly and Test** |  | 388.25d | 2002-06-28 A | 2004-01-19 |  | 53% | 182.07d | 2002-06-28 | 2003-11-14 | 347d | 12d |  |  | STEREO | IMPACT | SEP Package | HET | HET | GSFC |  |  |  |
| 116 | 5.1.1 | **Design** |  | 285d | 2002-06-28 A | 2003-08-15 |  | 79% | 58.76d | 2002-06-28 | 2003-06-18 | 244d | 5.25d |  |  | STEREO | IMPACT | SEP Package | HET | HET | GSFC |  |  |  |
| 117 | 5.1.1.1 | **ETU** |  | 241d | 2002-06-28 A | 2003-06-13 A |  | 100% |  | 2002-06-28 | 2003-02-19 | 160d |  |  |  | STEREO | IMPACT | SEP Package | HET | HET | GSFC |  |  |  |
| 118 | 5.1.1.1.1 | Design PHA Chip Test Board |  | 1d | 2002-06-28 A | 2002-06-28 A | 46FS+20d | 100% |  | 2002-06-28 | 2002-06-28 | 1d |  |  | start no earlier than 2002-07-01 | STEREO | IMPACT | SEP Package | HET | HET | GSFC |  |  | Larry |
| 119 | 5.1.1.1.2 | Layout PHA Chip Test Board |  | 1d | 2002-06-28 A | 2002-06-28 A | 118 | 100% |  | 2002-06-28 | 2002-06-28 | 1d |  |  | start no earlier than 2002-06-30 | STEREO | IMPACT | SEP Package | HET | HET | GSFC |  |  | Larry |
| 120 | 5.1.1.1.3 | Design HET Prototype Electronics Board |  | 14d | 2002-10-23 A | 2002-12-10 A | 30FS-13d, 148SS+13d | 100% |  | 2002-10-23 | 2002-12-10 | 14d |  |  |  | STEREO | IMPACT | SEP Package | HET | HET | GSFC |  |  | Larry |
| 121 | 5.1.1.1.4 | Layout HET Prototype Electronics Board |  | 38d | 2002-12-11 A | 2003-03-24 A | 120, 148 | 100% |  | 2002-12-11 | 2003-02-19 | 32d |  |  | finish no earlier than 2003-02-19 | STEREO | IMPACT | SEP Package | HET | HET | GSFC |  |  | Larry |
| 122 | 5.1.1.1.5 | (OBSOLETE) Conceptual Design of HET Front-End Electronics |  | 10d | 2003-06-02 A | 2003-06-13 A |  | 100% |  | 2003-02-03 | 2003-02-14 | 10d |  |  | start no earlier than 2003-05-31 | STEREO | IMPACT | SEP Package | HET | HET | GSFC |  |  |  |
| 123 | 5.1.1.2 | **FM 1 & FM 2** |  | 33d | 2003-07-01 A | 2003-08-15 |  | 39% | 20d | 2003-05-14 | 2003-06-18 | 25d | 5.25d |  |  | STEREO | IMPACT | SEP Package | HET | HET | GSFC |  |  |  |
| 124 | 1.1.13 | Instrument CDR | milestone | 3d | 2002-11-20 A | 2002-11-22 A | 53 | 100% |  | 2002-11-20 | 2002-11-22 | 3d |  |  | finish no earlier than 2002-11-22 | STEREO | IMPACT | SEP Package | HET | HET | GSFC |  |  |  |
| 125 | 5.1.1.2.2 | Finalize HET Electronics Board Design |  | 13d | 2003-07-01 A | 2003-07-18 A | 124, 149 | 100% |  | 2003-05-14 | 2003-05-28 | 10d |  |  | start no earlier than 2003-06-30 | STEREO | IMPACT | SEP Package | HET | HET | GSFC |  |  | Larry |
| 126 | 5.1.1.2.3 | Layout HET Flight Electronics Board |  | 20d | 2003-07-21 | 2003-08-15 | 125 |  |  | 2003-05-29 | 2003-06-18 | 15d | 5.25d | 0d |  | STEREO | IMPACT | SEP Package | HET | HET | GSFC |  |  | Larry |
| 127 | 5.1.2 | **Fabrication** |  | 305d | 2002-06-28 A | 2003-09-15 |  | 46% | 164.23d | 2002-06-28 | 2003-07-24 | 269d | 5.25d |  |  | STEREO | IMPACT | SEP Package | HET | HET | GSFC |  |  |  |
| 128 | 5.1.2.1 | **ETU** |  | 250d | 2002-06-28 A | 2003-06-26 A |  | 100% |  | 2002-06-28 | 2003-03-19 | 180d |  |  |  | STEREO | IMPACT | SEP Package | HET | HET | GSFC |  |  |  |
| 129 | 5.1.2.1.1 | Fabricate PHA Chip Test Board |  | 1d | 2002-06-28 A | 2002-06-28 A | 119 | 100% |  | 2002-06-28 | 2002-06-28 | 1d |  |  | start no earlier than 2002-04-30 | STEREO | IMPACT | SEP Package | HET | HET | GSFC |  |  |  |
| 130 | 5.1.2.1.2 | (OBSOLETE) Fabricate HET Prototype Electronics Board |  | 19d | 2003-06-02 A | 2003-06-26 A |  | 100% |  | 2003-02-03 | 2003-02-28 | 19d |  |  | start no earlier than 2003-05-31 | STEREO | IMPACT | SEP Package | HET | HET | GSFC |  |  | Larry |
| 131 | 5.1.2.1.3 | Fabricate Prototype HET Electronics Board |  | 10d | 2003-03-25 A | 2003-04-07 A | 121 | 100% |  | 2003-02-20 | 2003-03-19 | 20d |  |  | start no earlier than 2003-03-01 | STEREO | IMPACT | SEP Package | HET | HET | GSFC |  | EM Electronics Board Fabricated | Larry |

Notes:
- 109: Remove successor of Flight Detector Order
- 118: CIT provided GSFC with a Test Board that they had which was close enough. (Cost savings)
- 119: CIT provided GSFC with a Test Board that they had which was close enough. (Cost savings)
- 122: This was a duplicate of Design HET Electronics Board and is now obsolete as of status date of 7/31/02
- 129: CIT provided GSFC with a Test Board that they had which was close enough. (Cost savings)
- 130: This activity is a duplicate of the old activity Fabricate HET Electronics Board, which is now renamed / Fabricate Prototype HET Electronics Board as of status date 7/31/02

| ID | WBS | Task | Duration | Start | Finish | Predecessors | Complete | Remaining | Baseline start | Baseline finish | Baseline duration | Total slack | Free slack | Text11 | Text12 | Text13 | Text14 | Text16 | Text28 | Text19 | Text23 |
| --- | --- | --- | --- | --- | --- | --- | --- | --- | --- | --- | --- | --- | --- | --- | --- | --- | --- | --- | --- | --- | --- |
| 132 | 5.1.2.2 | **FM 1 & FM 2** | 20d | 2003-08-18 | 2003-09-15 |  |  |  | 2003-06-19 | 2003-07-24 | 25d | 5.25d |  | STEREO | IMPACT | SEP Package | HET | HET | GSFC |  |  |
| 133 | 5.1.2.2.1 | **FM 1** | 15d | 2003-08-18 | 2003-09-08 |  |  |  | 2003-06-19 | 2003-07-24 | 25d | 5.25d |  | STEREO | IMPACT | SEP Package | HET | HET | GSFC |  |  |
| 134 | 5.1.2.2.1.1 | Fabricate HET FM 1 Electronics Board | 15d | 2003-08-18 | 2003-09-08 | 126 |  |  | 2003-06-19 | 2003-07-24 | 25d | 5.25d | 0d | STEREO | IMPACT | SEP Package | HET | HET | GSFC | Larry | FM 1 Electronics Board Fabricated |
| 135 | 5.1.2.2.2 | **FM 2** | 20d | 2003-08-18 | 2003-09-15 |  |  |  | 2003-06-19 | 2003-07-24 | 25d | 5.25d |  | STEREO | IMPACT | SEP Package | HET | HET | GSFC |  |  |
| 136 | 5.1.2.2.2.1 | Fabricate HET FM 2 Electronics Board | 15d | 2003-08-18 | 2003-09-08 | 126 |  |  | 2003-06-19 | 2003-07-24 | 25d | 5.25d | 0d | STEREO | IMPACT | SEP Package | HET | HET | GSFC | Larry | FM 2 Electronics Board Fabricated |
| 137 | 5.1.2.2.2.2 | Coupon Test HET FM 1 & 2 Electronics Boards | 5d | 2003-09-09 | 2003-09-15 | 134, 136 |  |  |  |  |  | 5.25d | 0d | STEREO | IMPACT | SEP Package | HET | HET | GSFC |  |  |
| 138 | 5.1.3 | **Assemble** | 132d | 2003-04-08 A | 2003-10-14 |  | 20% | 105.6d | 2003-03-20 | 2003-08-19 | 107d | 25.25d |  | STEREO | IMPACT | SEP Package | HET | HET | GSFC |  |  |
| 139 | 5.1.3.1 | **ETU** | 5d | 2003-04-08 A | 2003-04-14 A |  | 100% |  | 2003-03-20 | 2003-04-01 | 9d |  |  | STEREO | IMPACT | SEP Package | HET | HET | GSFC |  |  |
| 140 | 5.1.3.1.1 | Populate HET Electronics Prototype Board | 5d | 2003-04-08 A | 2003-04-14 A | 131 | 100% |  | 2003-03-20 | 2003-04-01 | 9d |  |  | STEREO | IMPACT | SEP Package | HET | HET | GSFC |  | EM Electronics Board Assembled |
| 141 | 5.1.3.2 | **FM 1** | 10d | 2003-09-16 | 2003-09-29 |  |  |  | 2003-07-25 | 2003-08-06 | 9d | 5.25d |  | STEREO | IMPACT | SEP Package | HET | HET | GSFC |  |  |
| 142 | 5.1.3.2.1 | Populate HET Electronics FM 1 Board | 10d | 2003-09-16 | 2003-09-29 | 134, 137 |  |  | 2003-07-25 | 2003-08-06 | 9d | 5.25d | 0d | STEREO | IMPACT | SEP Package | HET | HET | GSFC |  | FM 1 Electronics Board Assembled |
| 143 | 5.1.3.3 | **FM 2** | 10d | 2003-09-30 | 2003-10-14 |  |  |  | 2003-08-07 | 2003-08-19 | 9d | 25.25d |  | STEREO | IMPACT | SEP Package | HET | HET | GSFC |  |  |
| 144 | 5.1.3.3.1 | Populate HET Electronics FM 2 Board | 10d | 2003-09-30 | 2003-10-14 | 136, 142, 137 |  |  | 2003-08-07 | 2003-08-19 | 9d | 25.25d |  | STEREO | IMPACT | SEP Package | HET | HET | GSFC |  | FM 2 Electronics Board Assembled |
| 145 | 5.1.4 | **Test** | 374.25d | 2002-07-19 A | 2004-01-19 |  | 44% | 210.69d | 2002-07-19 | 2003-11-14 | 333d | 12d |  | STEREO | IMPACT | SEP Package | HET | HET | GSFC |  |  |
| 146 | 5.1.4.1 | **ETU** | 229d | 2002-07-19 A | 2003-06-17 A |  | 100% |  | 2002-07-19 | 2003-05-13 | 205d |  |  | STEREO | IMPACT | SEP Package | HET | HET | GSFC |  |  |
| 147 | 5.1.4.1.1 | Preliminary Testing of PHA Chip | 13d | 2002-07-19 A | 2002-09-06 A | 129 | 100% |  | 2002-07-19 | 2002-09-06 | 13d |  |  | STEREO | IMPACT | SEP Package | HET | HET | GSFC | Larry |  |
| 148 | 5.1.4.1.2 | Test PHA Chip | 17d | 2002-09-18 A | 2002-12-04 A | 40SS+3d, 13 | 100% |  | 2002-09-18 | 2002-12-04 | 17d |  |  | STEREO | IMPACT | SEP Package | HET | HET | GSFC | Larry |  |
| 149 | 5.1.4.1.3 | Test HET Prototype Electronics Board | 29d | 2003-04-21 A | 2003-06-17 A | 41FF, 140, 188 | 100% |  | 2003-04-03 | 2003-05-13 | 29d |  |  | STEREO | IMPACT | SEP Package | HET | HET | GSFC |  |  |
| 150 | 5.1.4.2 | **FM 1** | 66d | 2003-10-08 | 2004-01-15 |  |  |  | 2003-08-07 | 2003-11-06 | 64d | 0d |  | STEREO | IMPACT | SEP Package | HET | HET | GSFC |  |  |
| 151 | 5.1.4.2.1 | Test HET FM 1 Electronics Board | 30d | 2003-10-08 | 2003-11-20 | 142, 191 |  |  | 2003-08-07 | 2003-09-04 | 20d | 0d |  | STEREO | IMPACT | SEP Package | HET | HET | GSFC | Larry | FM 1 Electronics Board Tested |
| 152 | 5.1.4.2.2 | Conformal Coat HET FM 1 Electronics Board | 2d | 2003-11-20 | 2003-11-24 | 151 |  |  | 2003-09-05 | 2003-09-11 | 5d | 28d |  | STEREO | IMPACT | SEP Package | HET | HET | GSFC | Larry |  |
| 153 | 5.1.4.2.3 | Retest Conformal Coated HET FM 1 Electronics Board | 2d | 2004-01-06 | 2004-01-08 | 152, 157 |  |  | 2003-10-17 | 2003-10-23 | 5d | 0d |  | STEREO | IMPACT | SEP Package | HET | HET | GSFC | Larry |  |
| 154 | 5.1.4.2.4 | Bakeout HET FM 1 Electronics Board | 2d | 2004-01-08 | 2004-01-13 | 153 |  |  | 2003-10-24 | 2003-10-30 | 5d | 0d |  | STEREO | IMPACT | SEP Package | HET | HET | GSFC | Larry |  |
| 155 | 5.1.4.2.5 | Retest Bakedout HET FM 1 Electronics Board | 2d | 2004-01-13 | 2004-01-15 | 154, 159 |  |  | 2003-10-31 | 2003-11-06 | 5d | 0d |  | STEREO | IMPACT | SEP Package | HET | HET | GSFC | Larry | FM 1 Electronics Board Available |

Notes:
- 149: This activity should have the CDR as its successor but can't due to it being completed late. Will connect it to something flight related for now. Need to talk to Tyco about this.

| ID | WBS | Task | Duration | Start | Finish | Predecessors | Complete | Remaining | Baseline start | Baseline finish | Baseline duration | Total slack | Free slack | Constraint | Text11 | Text12 | Text13 | Text14 | Text16 | Text28 | Text19 | Text23 |
| --- | --- | --- | --- | --- | --- | --- | --- | --- | --- | --- | --- | --- | --- | --- | --- | --- | --- | --- | --- | --- | --- | --- |
| 156 | 5.1.4.3 | **FM 2** | 38d | 2003-11-20 | 2004-01-19 |  |  |  | 2003-09-05 | 2003-11-14 | 49d | 0d |  |  | STEREO | IMPACT | SEP Package | HET | HET | GSFC |  |  |
| 157 | 5.1.4.3.1 | Test HET FM 2 Electronics Board | 30d | 2003-11-20 | 2004-01-06 | 144, 151, 191 |  |  | 2003-09-05 | 2003-10-16 | 29d | 0d |  |  | STEREO | IMPACT | SEP Package | HET | HET | GSFC | Larry | FM 2 Electronics Board Tested |
| 158 | 5.1.4.3.2 | Conformal Coat HET FM 2 Electronics Board | 2d | 2004-01-06 | 2004-01-08 | 157 |  |  | 2003-10-17 | 2003-10-23 | 5d | 0d |  |  | STEREO | IMPACT | SEP Package | HET | HET | GSFC | Larry |  |
| 159 | 5.1.4.3.3 | Retest Conformal Coated HET FM 2 Electronics Board | 2d | 2004-01-08 | 2004-01-13 | 158, 153 |  |  | 2003-10-24 | 2003-10-30 | 5d | 0d |  |  | STEREO | IMPACT | SEP Package | HET | HET | GSFC | Larry |  |
| 160 | 5.1.4.3.4 | Bakeout HET FM 2 Electronics Board | 2d | 2004-01-13 | 2004-01-15 | 159 |  |  | 2003-10-31 | 2003-11-06 | 5d | 12d | 0d |  | STEREO | IMPACT | SEP Package | HET | HET | GSFC | Larry |  |
| 161 | 5.1.4.3.5 | Retest Bakedout HET FM 2 Electronics Board | 2d | 2004-01-15 | 2004-01-19 | 160, 155 |  |  | 2003-11-07 | 2003-11-14 | 5d | 12d | 3d |  | STEREO | IMPACT | SEP Package | HET | HET | GSFC | Larry | FM 2 Electronics Board Available |
| 162 | 6 | **Flight Software** | 548.25d | 2001-08-01 A | 2003-10-08 |  | 83% | 95.08d | 2001-08-01 | 2003-05-28 | 457d | 102d |  |  | STEREO | IMPACT | SEP Package | HET | HET | GSFC |  |  |
| 163 | 6.1 | **Design, Manufacture, Assembly and Test** | 548.25d | 2001-08-01 A | 2003-10-08 |  | 83% | 95.08d | 2001-08-01 | 2003-05-28 | 457d | 102d |  |  | STEREO | IMPACT | SEP Package | HET | HET | GSFC |  |  |
| 164 | 6.1.1 | **Design** | 461d | 2001-09-04 A | 2003-07-07 |  | 89% | 52.69d | 2001-09-04 | 2003-02-06 | 357d | 166.25d |  |  | STEREO | IMPACT | SEP Package | HET | HET | GSFC |  |  |
| 165 | 6.1.1.1 | Develop MISC Software Design Approach | 15d | 2001-09-04 A | 2001-09-24 A |  | 100% |  | 2001-09-04 | 2001-09-24 | 15d |  |  | start no earlier than 2001-09-04 | STEREO | IMPACT | SEP Package | HET | HET | GSFC |  |  |
| 166 | 6.1.1.2 | Design CPU24 Multitasking System | 20d | 2002-06-19 A | 2003-07-07 | 165, 175, 42 | 80% | 4d | 2002-06-19 | 2003-02-06 | 20d | 166.25d | 0d | start no earlier than 2002-05-31 | STEREO | IMPACT | SEP Package | HET | HET | GSFC |  |  |
| 167 | 6.1.2 | **Fabrication** | 519.25d | 2001-08-01 A | 2003-08-26 |  | 92% | 41.55d | 2001-08-01 | 2003-04-16 | 428d | 4d |  |  | STEREO | IMPACT | SEP Package | HET | HET | GSFC |  |  |
| 168 | 6.1.2.1 | **ETU** | 492d | 2001-08-01 A | 2003-07-17 |  | 95% | 22.2d | 2001-08-01 | 2003-02-25 | 392d | 23.25d |  |  | STEREO | IMPACT | SEP Package | HET | HET | GSFC |  |  |
| 169 | 6.1.2.1.1 | Translate CIT MISC Design into Verilog | 42d | 2001-08-01 A | 2001-09-28 A | 14 | 100% |  | 2001-08-01 | 2001-09-28 | 42d |  |  |  | STEREO | IMPACT | SEP Package | HET | HET | GSFC |  |  |
| 170 | 6.1.2.1.2 | Add UARTS | 10d | 2001-10-01 A | 2001-10-15 A | 169 | 100% |  | 2001-10-01 | 2001-10-15 | 10d |  |  |  | STEREO | IMPACT | SEP Package | HET | HET | GSFC |  |  |
| 171 | 6.1.2.1.3 | Code Boot-up Sequence | 10d | 2001-10-16 A | 2001-10-29 A | 170 | 100% |  | 2001-10-16 | 2001-10-29 | 10d |  |  |  | STEREO | IMPACT | SEP Package | HET | HET | GSFC |  |  |
| 172 | 6.1.2.1.4 | Code Low-Power Clocking | 34d | 2001-11-29 A | 2002-01-18 A | 187 | 100% |  | 2001-11-29 | 2002-01-18 | 34d |  |  |  | STEREO | IMPACT | SEP Package | HET | HET | GSFC |  |  |
| 173 | 6.1.2.1.5 | Code CPU24 Assembler | 10d | 2001-09-25 A | 2001-10-09 A | 165 | 100% |  | 2001-09-25 | 2001-10-09 | 10d |  |  |  | STEREO | IMPACT | SEP Package | HET | HET | GSFC |  |  |
| 174 | 6.1.2.1.6 | Code CPU24 Debug Monitor | 15d | 2001-10-10 A | 2001-10-30 A | 173 | 100% |  | 2001-10-10 | 2001-10-30 | 15d |  |  |  | STEREO | IMPACT | SEP Package | HET | HET | GSFC |  |  |
| 175 | 6.1.2.1.7 | Code Windows I/F to Debug Monitor | 15d | 2002-05-29 A | 2002-06-18 A | 174 | 100% |  | 2002-05-29 | 2002-06-18 | 15d |  |  | start no earlier than 2002-05-31 | STEREO | IMPACT | SEP Package | HET | HET | GSFC |  |  |
| 176 | 6.1.2.1.8 | Code HET PH Event Processing for Simulated Data Testing | 30d | 2002-08-01 A | 2003-07-17 | 201 | 65% | 10.5d | 2002-08-01 | 2003-02-25 | 30d | 23.25d | 0d | finish no earlier than 2003-02-25 | STEREO | IMPACT | SEP Package | HET | HET | GSFC |  |  |
| 177 | 6.1.2.1.9 | Code HET Command Processing for Simulated Data Testing | 22d | 2002-08-01 A | 2002-08-30 A | 176FS-12d, 166 | 100% |  | 2002-08-01 | 2002-08-30 | 22d |  |  |  | STEREO | IMPACT | SEP Package | HET | HET | GSFC |  |  |
| 178 | 6.1.2.1.10 | Code HET Data Acquisition for Simulated Data Testing | 19.7d | 2002-08-01 A | 2002-10-22 A | 176FS-12d | 100% |  | 2002-08-01 | 2002-10-22 | 19.7d |  |  |  | STEREO | IMPACT | SEP Package | HET | HET | GSFC |  |  |
| 179 | 6.1.2.1.11 | Code HET Telemetry Formatting for Simulated Data Testing | 25d | 2002-08-01 A | 2003-04-23 A | 176 | 100% |  | 2002-08-01 | 2003-02-13 | 25d |  |  |  | STEREO | IMPACT | SEP Package | HET | HET | GSFC |  |  |

| ID | WBS | Task | Duration | Start | Finish | Predecessors | Complete | Remaining | Baseline start | Baseline finish | Baseline duration | Total slack | Free slack | Constraint | Text11 | Text12 | Text13 | Text14 | Text16 | Text28 | Text23 |
| --- | --- | --- | --- | --- | --- | --- | --- | --- | --- | --- | --- | --- | --- | --- | --- | --- | --- | --- | --- | --- | --- |
| 180 | 6.1.2.2 | **FM 1 & FM 2** | 206.25d | 2002-10-30 A | 2003-08-26 |  | 69% | 63.02d | 2002-10-30 | 2003-04-16 | 115d | 4d |  |  | STEREO | IMPACT | SEP Package | HET | HET | GSFC |  |
| 181 | 6.1.2.2.1 | Code HET PH Event Processing Update for Flight | 10d | 2002-10-30 A | 2003-08-25 | 176, 36 | 20% | 8d | 2002-10-30 | 2003-04-09 | 10d | 5d | 0d |  | STEREO | IMPACT | SEP Package | HET | HET | GSFC |  |
| 182 | 6.1.2.2.2 | Code HET Command Processing Update for Flight | 10d | 2003-02-25 A | 2003-08-26 | 177, 189SS+10d, 181FS-5d | 90% | 1d | 2003-04-03 | 2003-04-16 | 10d | 0d |  |  | STEREO | IMPACT | SEP Package | HET | HET | GSFC |  |
| 183 | 6.1.2.2.3 | Code HET Data Acquisition Update for Flight | 6d | 2002-10-31 A | 2003-05-30 A | 178, 189SS+10d, 181FS-5d | 100% |  | 2002-10-31 | 2003-04-09 | 10d |  |  |  | STEREO | IMPACT | SEP Package | HET | HET | GSFC |  |
| 184 | 6.1.2.2.4 | Code HET Telemetry Formatting Update for Flight | 10d | 2003-02-28 A | 2003-07-02 | 179, 189SS+10d | 80% | 2d | 2003-03-03 | 2003-03-14 | 10d | 37.25d |  |  | STEREO | IMPACT | SEP Package | HET | HET | GSFC |  |
| 185 | 6.1.3 | **Test** | 486.25d | 2001-10-30 A | 2003-10-08 |  | 46% | 262.84d | 2001-10-30 | 2003-05-28 | 395d | 0d |  |  | STEREO | IMPACT | SEP Package | HET | HET | GSFC |  |
| 186 | 6.1.3.1 | **ETU** | 433d | 2001-10-30 A | 2003-07-22 |  | 76% | 105.84d | 2001-10-30 | 2003-03-14 | 343d | 24.25d |  |  | STEREO | IMPACT | SEP Package | HET | HET | GSFC |  |
| 187 | 6.1.3.1.1 | Verify CPU24 Operation | 20d | 2001-10-30 A | 2001-11-28 A | 171 | 100% |  | 2001-10-30 | 2001-11-28 | 20d |  |  | start no earlier than 2002-05-31 | STEREO | IMPACT | SEP Package | HET | HET | GSFC |  |
| 188 | 6.1.3.1.2 | Test Integrated HET S/W w/Simulated for Prototype Electronics Board Testing | 5d | 2002-12-02 A | 2002-12-06 A | 177, 178 | 100% |  | 2002-12-02 | 2002-12-06 | 5d |  |  |  | STEREO | IMPACT | SEP Package | HET | HET | GSFC |  |
| 189 | 6.1.3.1.3 | Test Integrated HET S/W with Simulated Data | 20d | 2003-04-24 A | 2003-07-22 | 177, 178, 179 | 45% | 11d | 2003-02-14 | 2003-03-14 | 20d | 24.25d | 0d | start no earlier than 2003-03-31 | STEREO | IMPACT | SEP Package | HET | HET | GSFC |  |
| 190 | 6.1.3.2 | **FM 1 & FM 2** | 29d | 2003-08-26 | 2003-10-08 |  |  |  | 2003-04-17 | 2003-05-28 | 29d | 0d |  |  | STEREO | IMPACT | SEP Package | HET | HET | GSFC |  |
| 191 | 6.1.3.2.1 | Verify HET On-Board Software | 29d | 2003-08-26 | 2003-10-08 | 184, 183, 182, 189 |  |  | 2003-04-17 | 2003-05-28 | 29d | 0d |  |  | STEREO | IMPACT | SEP Package | HET | HET | GSFC | Flight S/W Tested |
| 192 | 7 | **Integration & Test** | 36d | 2004-01-15 | 2004-03-08 |  |  |  | 2003-11-19 | 2004-01-22 | 43d | 0d |  |  | STEREO | IMPACT | SEP Package | HET | HET | GSFC |  |
| 193 | 7.1 | **FM 1** | 19d | 2004-01-15 | 2004-02-11 |  |  |  | 2003-11-19 | 2003-12-23 | 24d | 0d |  |  | STEREO | IMPACT | SEP Package | HET | HET | GSFC |  |
| 194 | 7.1.1 | Integrate HET FM 1 Electronics Telescope (Ahead) | 5d | 2004-01-15 | 2004-01-22 | 69, 155 |  |  | 2003-11-19 | 2003-11-25 | 5d | 0d |  |  | STEREO | IMPACT | SEP Package | HET | HET | GSFC | FM 1 Telescope Integrated |
| 195 | 7.1.2 | Test HET FM 1 Telescope (Ahead) | 14d | 2004-01-22 | 2004-02-11 | 194, 43 |  |  | 2003-11-26 | 2003-12-23 | 19d | 0d |  |  | STEREO | IMPACT | SEP Package | HET | HET | GSFC | FM 1 Telescope Ready For Delivery |
| 196 | 7.2 | **FM 2** | 31d | 2004-01-22 | 2004-03-08 |  |  |  | 2003-11-26 | 2004-01-22 | 38d | 0d |  |  | STEREO | IMPACT | SEP Package | HET | HET | GSFC |  |
| 197 | 7.2.1 | Integrate HET FM 2 Electronics Telescope (Behind) | 5d | 2004-01-22 | 2004-01-29 | 71, 194, 161 |  |  | 2003-11-26 | 2003-12-03 | 5d | 9d |  |  | STEREO | IMPACT | SEP Package | HET | HET | GSFC | FM 2 Telescope Integrated |
| 198 | 7.2.2 | Test HET FM 2 Telescope (Behind) | 17d | 2004-02-11 | 2004-03-08 | 197, 43, 195 |  |  | 2003-12-24 | 2004-01-22 | 19d | 0d |  |  | STEREO | IMPACT | SEP Package | HET | HET | GSFC | FM 2 Telescope Ready For Delivery |
| 199 | 8 | **Emulators/Simulators/GSE** | 322d | 2002-01-02 A | 2003-04-14 A |  | 100% |  | 2002-01-02 | 2003-02-14 | 282d |  |  |  | STEREO | IMPACT | SEP Package | HET | HET | GSFC |  |
| 200 | 8.1 | **Simulators** | 123d | 2002-01-02 A | 2002-06-26 A |  | 100% |  | 2002-01-02 | 2002-06-26 | 123d |  |  |  | STEREO | IMPACT | SEP Package | HET | HET | GSFC |  |
| 201 | 8.1.1 | Simulate HET PH Events | 59.3d | 2002-01-02 A | 2002-06-26 A |  | 100% |  | 2002-01-02 | 2002-06-26 | 59.3d |  |  | start no earlier than 2002-01-02 | STEREO | IMPACT | SEP Package | HET | HET | GSFC |  |
| 202 | 8.2 | **GSE** | 217d | 2002-06-03 A | 2003-04-14 A |  | 100% |  | 2002-06-03 | 2003-02-14 | 177d |  |  |  | STEREO | IMPACT | SEP Package | HET | HET | GSFC |  |
| 203 | 8.2.1 | Specify HET GSE | 19d | 2002-06-03 A | 2002-06-27 A |  | 100% |  | 2002-06-03 | 2002-06-27 | 19d |  |  | start no earlier than 2002-05-31 | STEREO | IMPACT | SEP Package | HET | HET | GSFC |  |
| 204 | 8.2.2 | Develop HET Command Sending Capability | 20d | 2002-06-03 A | 2002-06-28 A | 203 | 100% |  | 2002-06-03 | 2002-06-28 | 20d |  |  | start no earlier than 2002-05-31 | STEREO | IMPACT | SEP Package | HET | HET | GSFC |  |
| 205 | 8.2.3 | Display HET Rates | 10d | 2002-07-02 A | 2002-07-16 A | 204 | 100% |  | 2002-07-02 | 2002-07-16 | 10d |  |  | start no earlier than 2002-07-01 | STEREO | IMPACT | SEP Package | HET | HET | GSFC |  |
| 206 | 8.2.4 | Display HET Pulse-Height Data | 10d | 2002-07-02 A | 2002-08-07 A | 204 | 100% |  | 2002-07-02 | 2002-08-07 | 10d |  |  | start no earlier than 2002-07-01 | STEREO | IMPACT | SEP Package | HET | HET | GSFC |  |
| 207 | 8.2.5 | Display HET Housekeeping Data | 10d | 2003-04-01 A | 2003-04-14 A | 204 | 100% |  | 2003-02-03 | 2003-02-14 | 10d |  |  | start no earlier than 2003-03-31 | STEREO | IMPACT | SEP Package | HET | HET | GSFC |  |
| 208 | 14.2.6.4 | Display SIT Rates | 9d | 2002-07-17 A | 2003-04-18 A | 207, 206, 205 | 100% |  | 2002-07-17 | 2003-02-21 | 9d |  |  |  | STEREO | IMPACT | SEP Package | HET | HET | GSFC |  |
