# IMPACT SEP

Schedule from MS Project, 2001-08-15 to 2004-07-07, status date 2003-07-31, A marks actual dates.
SEP Package Development With I & T
NASA GSFC
Status Date: 07/31/2003 / Baseline Date: 01/31/2003 R1

## Calendars

- Standard w/ 10 Gov't Holidays: Mon-Fri 08:00-12:00, 13:00-17:00; Sat-Sun off. Exceptions (off unless hours are given): 2001-09-03, 2001-10-08, 2001-11-12, 2001-11-22, 2001-12-25, 2002-01-01, 2002-01-14, 2002-02-18, 2002-05-27, 2002-07-04, 2002-09-02, 2002-10-07, 2002-11-11, 2002-11-28, 2002-12-25, 2003-01-01, 2003-01-13, 2003-02-17, 2003-05-26, 2003-07-04, 2003-09-01, 2003-10-06, 2003-11-10, 2003-11-27, 2003-12-25, 2004-01-01, 2004-01-12, 2004-02-16, 2004-05-31, 2004-07-05.

## Schedule

| ID | WBS | Task | Type | Duration | Start | Finish | Predecessors | Complete | Remaining | Baseline start | Baseline finish | Baseline duration | Total slack | Free slack | Constraint | Text11 | Text12 | Text13 | Text28 | Text14 | Text16 | Text22 | Text23 | Text17 | Text20 |
| --- | --- | --- | --- | --- | --- | --- | --- | --- | --- | --- | --- | --- | --- | --- | --- | --- | --- | --- | --- | --- | --- | --- | --- | --- | --- |
| 1 | 1 | **Management** |  | 566d | 2002-01-15 A | 2004-04-14 |  | 99% | 0d | 2002-01-15 | 2004-03-30 | 555d | 58d |  |  | STEREO | IMPACT | SEP Package | CIT |  |  |  |  |  |  |
| 2 | 1.1 | **Milestones** |  | 566d | 2002-01-15 A | 2004-04-14 |  | 99% | 0d | 2002-01-15 | 2004-03-30 | 555d | 58d |  |  | STEREO | IMPACT | SEP Package | CIT |  |  |  |  |  |  |
| 3 | 1.1.1 | SEP Software Design Review | milestone | 0d | 2002-05-21 A | 2002-05-21 A |  | 100% |  | 2002-05-21 | 2002-05-21 | 0d |  |  | start no earlier than 2002-07-31 | STEREO | IMPACT | SEP Package | CIT | SEP Cen | MAG |  |  |  |  |
| 4 | 1.1.2 | SEP Central EM Ready for I & T | milestone | 0d | 2003-06-09 A | 2003-06-09 A | 41, 55, 61 | 100% |  | 2003-05-29 | 2003-05-29 | 0d |  |  | start no earlier than 2003-06-30 | STEREO | IMPACT | SEP Package |  | SEP Cen |  | SEP Central - EM Ready for I & T | EM Boards Available for EM I & T |  |  |
| 5 | 1.1.3 | SEP Central FM 1 Ready for I & T | milestone | 0d | 2004-01-14 | 2004-01-14 | 32, 45, 51FS+1d, 57, 63 |  |  | 2003-12-12 | 2003-12-12 | 0d | 122d |  |  | STEREO | IMPACT | SEP Package |  | SEP Cen |  | SEP Central - FM 1 Ready for I & T | FM 1 Ready for I & T |  |  |
| 6 | 1.1.4 | SEP Central FM 2 Ready for I & T | milestone | 0d | 2004-02-03 | 2004-02-03 | 47, 53, 59, 65, 34 |  |  | 2004-01-02 | 2004-01-02 | 0d | 108d |  |  | STEREO | IMPACT | SEP Package |  | SEP Cen |  | SEP Central - FM 2 Ready for I & T | FM 2 Ready for I & T |  |  |
| 7 | 1.1.5 | **Receivables** |  | 262d | 2003-03-31 A | 2004-04-14 |  | 99% | 0d | 2003-02-01 | 2004-03-30 | 291d | 58d |  |  | STEREO | IMPACT | SEP Package | CIT |  |  |  |  |  |  |
| 8 | 1.1.5.1 | Receive Instrument Simulator | milestone | 0d | 2003-03-31 A | 2003-03-31 A |  | 100% |  | 2003-02-01 | 2003-02-01 | 0d |  |  | start no earlier than 2003-03-31 | STEREO | IMPACT | SEP Package |  |  |  |  |  |  |  |
| 9 | 1.1.5.2 | **HET** |  | 0d | 2003-06-30 A | 2003-06-30 A |  | 100% |  | 2003-05-28 | 2003-05-28 | 0d |  |  |  | STEREO | IMPACT | SEP Package |  |  |  |  |  |  |  |
| 10 | 1.1.6.6 | Deliver HET S/W for SEP Central MISC/HET CPU24 Testing | milestone | 0d | 2003-10-08 | 2003-10-08 |  |  |  |  |  |  | 101.25d |  |  | STEREO | IMPACT | SEP Package |  |  |  |  |  |  |  |
| 11 | 1.1.5.2.2 | (OBSOLETE) Receive HET S/W for SEP Central I/F Testing | milestone | 0d | 2003-06-30 A | 2003-06-30 A | 10 | 100% |  | 2003-05-28 | 2003-05-28 | 0d |  |  |  | STEREO | IMPACT | SEP Package | CIT | HET | HET |  |  |  |  |
| 12 | 1.1.5.3 | **SIT** |  | 21d | 2003-05-30 A | 2003-06-30 A |  | 100% |  | 2003-04-25 | 2003-04-25 | 0d |  |  |  | STEREO | IMPACT | SEP Package |  |  |  |  |  |  |  |
| 13 | 1.1.3.12 | Delivery SIT S/W to CIT for SEP Central I/F Testing | milestone | 0d | 2003-07-23 A | 2003-07-23 A |  | 100% |  |  |  |  |  |  |  | STEREO | IMPACT | SEP Package |  |  |  |  |  |  |  |
| 14 | 1.1.5.3.2 | (OBSOLETE) Receive SIT S/W for SEP Central I/F Testing |  | 21d | 2003-05-30 A | 2003-06-30 A | 13 | 100% |  | 2003-04-25 | 2003-04-25 | 0d |  |  |  | STEREO | IMPACT | SEP Package | CIT | HET | SIT |  |  |  |  |
| 15 | 1.1.5.4 | **LVPS** |  | 93d | 2003-09-02 | 2004-01-19 |  |  |  | 2003-05-05 | 2003-12-17 | 156d | 0d |  |  | STEREO | IMPACT | SEP Package |  |  |  |  |  |  |  |
| 16 | 1.1.3.3.3 | Deliver SEP ETU LVPS to CIT | milestone | 0d | 2003-09-02 | 2003-09-02 |  |  |  |  |  |  | 0d |  |  | STEREO | IMPACT | SEP Package |  |  |  |  |  |  |  |
| 17 | 1.1.5.4.2 | Receive SEP LVPS ETU From UC-B | milestone | 0d | 2003-09-02 | 2003-09-02 | 16 |  |  | 2003-05-05 | 2003-05-05 | 0d | 0d |  |  | STEREO | IMPACT | SEP Package | CIT | SEP Cen | SEP DPU |  | ETU LVPS Received | LVPS | SEP ETU LVPS |
| 18 | 1.1.3.4.4 | Deliver SEP FM 1 LVPS to CIT | milestone | 0d | 2003-12-24 | 2003-12-24 |  |  |  |  |  |  | 0d |  |  | STEREO | IMPACT | SEP Package |  |  |  |  |  |  |  |
| 19 | 1.1.5.4.4 | Receive SEP LVPS FM 1 From UC-B | milestone | 0d | 2003-12-24 | 2003-12-24 | 18 |  |  | 2003-10-13 | 2003-10-13 | 0d | 8d | 0d | start no earlier than 2003-10-13 | STEREO | IMPACT | SEP Package | CIT | SEP Cen | SEP DPU |  | FM 1 LVPS Received | LVPS | SEP FM 1 LVPS |
| 20 | 1.1.3.5.4 | Deliver SEP FM 2 LVPS to CIT | milestone | 0d | 2004-01-19 | 2004-01-19 |  |  |  |  |  |  | 22d | 0d |  | STEREO | IMPACT | SEP Package |  |  |  |  |  |  |  |
| 21 | 1.1.5.4.6 | Receive SEP LVPS FM 2 From UC-B | milestone | 0d | 2004-01-19 | 2004-01-19 | 20 |  |  | 2003-12-17 | 2003-12-17 | 0d | 46d | 0d | start no earlier than 2003-12-17 | STEREO | IMPACT | SEP Package | CIT | SEP Cen | SEP DPU |  | FM 2 LVPS Received | LVPS | SEP FM 2 LVPS |
| 22 | 1.1.5.5 | **LET** |  | 110d | 2003-08-18 | 2004-01-28 |  |  |  | 2003-05-05 | 2003-10-09 | 109d | 112.4d |  |  | STEREO | IMPACT | SEP Package |  |  |  |  |  |  |  |
| 23 | 1.2.4.9 | Deliver LET S/W Build 2 | milestone | 0d | 2003-08-18 | 2003-08-18 |  |  |  |  |  |  | 222.4d | 0d |  | STEREO | IMPACT | SEP Package |  |  |  |  |  |  |  |
| 24 | 1.1.5.5.2 | Receive LET S/W Build 2 | milestone | 0d | 2003-08-18 | 2003-08-18 | 23 |  |  | 2003-05-05 | 2003-05-05 | 0d | 222.4d |  |  | STEREO | IMPACT | SEP Package | CIT | LET | LET |  |  |  |  |
| 25 | 1.2.4.12 | Deliver LET S/W Build 3 | milestone | 0d | 2004-01-28 | 2004-01-28 |  |  |  |  |  |  | 17.4d | 0d |  | STEREO | IMPACT | SEP Package |  |  |  |  |  |  |  |
| 26 | 1.1.5.5.4 | Receive LET S/W Build 3 | milestone | 0d | 2004-01-28 | 2004-01-28 | 25 |  |  | 2003-10-09 | 2003-10-09 | 0d | 92.4d | 0d |  | STEREO | IMPACT | SEP Package | CIT | LET | LET |  |  |  |  |

Notes:
- 11: March 03 Status Upd: CIT to produce 2nd SepCen EM Logic Board for GSFC/UMD.
- 14: March 03 Status Upd: CIT to produce 2nd SepCen EM Logic Board for GSFC/UMD.

| ID | WBS | Task | Type | Duration | Start | Finish | Predecessors | Complete | Remaining | Baseline start | Baseline finish | Baseline duration | Total slack | Free slack | Constraint | Text11 | Text12 | Text13 | Text14 | Text16 | Text28 | Text19 | Text17 | Text20 |
| --- | --- | --- | --- | --- | --- | --- | --- | --- | --- | --- | --- | --- | --- | --- | --- | --- | --- | --- | --- | --- | --- | --- | --- | --- |
| 27 | 1.1.5.6 | **IDPU** |  | 235d | 2003-05-08 A | 2004-04-14 |  |  | 235d | 2003-02-01 | 2004-03-30 | 291d | 58d |  |  | STEREO | IMPACT | SEP Package |  |  |  |  |  |  |
| 28 | 1.1.5.6.1 | Receive ETU IDPU From UC-B For SEP ETU/IDPU ETU I/F Test | milestone | 0d | 2003-05-08 A | 2003-05-08 A |  | 100% |  | 2003-02-01 | 2003-02-01 | 0d |  |  | start no earlier than 2003-03-31 | STEREO | IMPACT | SEP Package | IDPU | IDPU | CIT |  |  |  |
| 29 | 1.1.5.33 | Deliver IDPU FM 2 For SEP Package/IDPU I & T | milestone | 0d | 2004-04-14 | 2004-04-14 |  |  |  |  |  |  | 58d | 0d |  | STEREO | IMPACT | SEP Package |  |  |  |  |  |  |
| 30 | 1.1.5.6.3 | Receive IDPU FM 2 From UC-B For SEP FM 1/IDPU FM 1 Testing | milestone | 0d | 2004-04-14 | 2004-04-14 | 29 |  |  | 2004-03-30 | 2004-03-30 | 0d | 58d |  |  | STEREO | IMPACT | SEP Package | IDPU | IDPU | CIT |  |  |  |
| 31 | 1.1.6 | **Deliverables** |  | 516d | 2002-01-15 A | 2004-02-03 |  | 99% | 0d | 2002-01-15 | 2004-02-03 | 516d | 108d |  |  | STEREO | IMPACT | SEP Package |  |  | CIT |  |  |  |
| 32 | 1.1.6.1 | Deliver SEP FM 1 Common Electronics Enclosure to CIT | milestone | 0d | 2003-10-30 | 2003-10-30 | 100 |  |  | 2003-05-30 | 2003-05-30 | 0d | 56.5d | 0d |  | STEREO | IMPACT | SEP Package | SEP Cen | SEP DPU | GSFC | Sandy Shuman |  |  |
| 33 | 1.2.6.5.2.10 | Receive SEP FM 1 Common Electronics Enclosure from GSFC | milestone | 0d | 2003-10-30 | 2003-10-30 | 32 |  |  | 2003-05-30 | 2003-05-30 | 0d | 56.5d | 48.5d |  | STEREO | IMPACT | SEP Package |  |  |  |  |  |  |
| 34 | 1.1.6.3 | Deliver SEP FM 2 Common Electronics Enclosure to CIT | milestone | 0d | 2003-10-30 | 2003-10-30 | 102 |  |  | 2003-05-30 | 2003-05-30 | 0d | 56.5d | 0d |  | STEREO | IMPACT | SEP Package | SEP Cen | SEP DPU | GSFC | Sandy Shuman |  |  |
| 35 | 1.2.6.5.3.10 | Receive SEP FM 2 Common Electronics Enclosure from GSFC | milestone | 0d | 2003-10-30 | 2003-10-30 | 34 |  |  | 2003-05-30 | 2003-05-30 | 0d | 56.5d | 48.5d |  | STEREO | IMPACT | SEP Package |  |  |  |  |  |  |
| 36 | 1.1.6.5 | Deliver SEP LVPS SPEC to UC-B | milestone | 0d | 2002-07-05 A | 2002-07-05 A | 84 | 100% |  | 2002-07-05 | 2002-07-05 | 0d |  |  | start no earlier than 2002-06-30 | STEREO | IMPACT | SEP Package | PS |  | CIT |  | LVPS |  |
| 37 | 1.1.6.6 | Deliver SEP ETU LVPS Test Feedback to UC-B | milestone | 0d | 2003-09-12 | 2003-09-12 | 196 |  |  | 2003-06-05 | 2003-06-05 | 0d | 0d |  |  | STEREO | IMPACT | SEP Package | PS |  | CIT |  | LVPS |  |
| 38 | 1.1.2.6 | Receive SEP LVPS ETU/SEP Central ETU I/F Test Results | milestone | 0d | 2003-09-12 | 2003-09-12 | 37 |  |  |  |  |  | 0d |  |  | STEREO | IMPACT | SEP Package |  |  |  |  |  |  |
| 39 | 1.1.6.8 | Deliver Software Requirements Doc To LET |  | 1d | 2002-01-15 A | 2002-01-15 A | 79 | 100% |  | 2002-01-15 | 2002-01-15 | 1d |  |  |  | STEREO | IMPACT | SEP Package | LET | LET | CIT |  |  |  |
| 40 | 1.2.3.5 | Receive Software Requirements Doc |  | 1d | 2002-01-15 A | 2002-01-15 A | 39 | 100% |  |  |  |  |  |  |  | STEREO | IMPACT | SEP Package |  |  |  |  |  |  |
| 41 | 1.1.6.10 | Deliver SEP Central EM Logic Board (intial) for SEP EM/IDPU ETU I & T | milestone | 0d | 2003-05-31 A | 2003-05-31 A | 170 | 100% |  | 2003-05-15 | 2003-05-15 | 0d |  |  | start no earlier than 2003-05-31 | STEREO | IMPACT | SEP Package | SEP Cen |  |  |  |  | SEP Cen EM (Use latest date) |
| 42 | 1.1.6.11 | Deliver SEP Central EM Logic Board (final) for SEP EM I & T | milestone | 0d | 2003-06-05 A | 2003-06-05 A | 171 | 100% |  | 2003-06-05 | 2003-06-05 | 0d |  |  | start no earlier than 2003-05-31 | STEREO | IMPACT | SEP Package |  |  |  |  |  |  |
| 43 | 1.2.6.5.1.4 | Receive SEP Central EM Logic Board for SEP EM I & T |  | 1d | 2003-06-05 A | 2003-06-06 A | 42 | 100% |  |  |  |  |  |  | start no earlier than 2003-05-31 | STEREO | IMPACT | SEP Package |  |  |  |  |  |  |
| 44 | 1.2.6.5.1.2 | Receive SEP Central EM Logic Board for SEP EM /IDPU I & T |  | 1d | 2003-05-08 A | 2003-05-08 A | 41 | 100% |  | 2003-05-15 | 2003-05-15 | 0d |  |  |  | STEREO | IMPACT | SEP Package |  |  |  |  |  |  |
| 45 | 1.1.6.14 | Deliver SEP Central FM 1 Logic Board to SEP FM 1 I & T | milestone | 0d | 2003-12-01 | 2003-12-01 | 180 |  |  | 2003-10-15 | 2003-10-15 | 0d | 36.55d | 0d |  | STEREO | IMPACT | SEP Package | SEP Cen |  |  |  |  | SEP Cen FM 1 (Use latest date) |
| 46 | 1.2.6.5.2.2 | Receive SEP Central FM 1 Logic Board for SEP FM 1 I & T | milestone | 0d | 2003-12-01 | 2003-12-01 | 45 |  |  | 2003-10-15 | 2003-10-15 | 0d | 36.55d | 28.55d |  | STEREO | IMPACT | SEP Package |  |  |  |  |  |  |
| 47 | 1.1.6.16 | Deliver SEP Central FM 2 Logic Board to SEP FM 2 I & T | milestone | 0d | 2003-12-01 | 2003-12-01 | 180 |  |  | 2003-10-15 | 2003-10-15 | 0d | 36.55d | 0d |  | STEREO | IMPACT | SEP Package | SEP Cen |  |  |  |  | SEP Cen FM 2 (Use latest date) |
| 48 | 1.2.6.5.3.2 | Receive SEP Central FM 2 Logic Board for SEP FM 2 I & T | milestone | 0d | 2003-12-01 | 2003-12-01 | 47 |  |  | 2003-10-15 | 2003-10-15 | 0d | 36.55d | 28.55d |  | STEREO | IMPACT | SEP Package |  |  |  |  |  |  |
| 49 | 1.1.6.18 | Deliver Bench Tested SEP Cental ETU LVPS for SEP EM I & T | milestone | 0d | 2003-09-03 | 2003-09-03 | 193 |  |  | 2003-05-27 | 2003-05-27 | 0d | 71d | 0d |  | STEREO | IMPACT | SEP Package | SEP Cen |  |  |  |  | SEP Cen EM (Use latest date) |
| 50 | 1.2.6.5.1.10 | Receive SEP Central EM Bench Tested LVPS for SEP EM I & T | milestone | 0d | 2003-09-03 | 2003-09-03 | 49 |  |  | 2003-05-27 | 2003-05-27 | 0d | 71d | 0d |  | STEREO | IMPACT | SEP Package |  |  |  |  |  |  |
| 51 | 1.1.6.20 | Deliver Bench Tested SEP Central FM 1 LVPS to SEP FM 1 I & T | milestone | 0d | 2004-01-13 | 2004-01-13 | 202 |  |  | 2003-10-28 | 2003-10-28 | 0d | 8d | 0d |  | STEREO | IMPACT | SEP Package | SEP Cen |  |  |  |  | SEP Cen FM 1 (Use latest date) |
| 52 | 1.2.6.5.2.8 | Receive SEP Central FM 1 Bench Tested LVPS for SEP FM 1 I & T | milestone | 0d | 2004-01-13 | 2004-01-13 | 51 |  |  | 2003-10-28 | 2003-10-28 | 0d | 8d | 0d |  | STEREO | IMPACT | SEP Package |  |  |  |  |  |  |
| 53 | 1.1.6.22 | Deliver Bench Tested SEP Central FM 2 LVPS to SEP FM 2 I & T | milestone | 0d | 2004-02-03 | 2004-02-03 | 205 |  |  | 2004-01-05 | 2004-01-05 | 0d | 46d | 0d |  | STEREO | IMPACT | SEP Package | SEP Cen |  |  |  |  | SEP Cen FM 2 (Use latest date) |
| 54 | 1.2.6.5.3.8 | Receive SEP Central FM 2 Bench Tested LVPS for SEP FM 2 I & T | milestone | 0d | 2004-02-03 | 2004-02-03 | 53 |  |  | 2004-01-05 | 2004-01-05 | 0d | 46d | 38.25d |  | STEREO | IMPACT | SEP Package |  |  |  |  |  |  |
| 55 | 1.1.6.24 | Deliver Bench Tested SEP Cental EM Analog/Post-Reg Board for SEP EM I & T | milestone | 0d | 2003-05-29 A | 2003-05-29 A | 261 | 100% |  | 2003-05-28 | 2003-05-28 | 0d |  |  |  | STEREO | IMPACT | SEP Package | SEP Cen |  |  |  |  | SEP Cen EM (Use latest date) |
| 56 | 1.2.6.5.1.6 | Receive SEP Central EM Analog/Post-Reg Board for SEP EM I & T | milestone | 0d | 2003-05-29 A | 2003-05-29 A | 55 | 100% |  | 2003-05-28 | 2003-05-28 | 0d |  |  |  | STEREO | IMPACT | SEP Package |  |  |  |  |  |  |
| 57 | 1.1.6.26 | Deliver Bench Tested SEP Cental FM 1 Analog/Post-Reg Board for SEP FM 1 I & T | milestone | 0d | 2003-11-20 | 2003-11-20 | 269 |  |  | 2003-11-20 | 2003-11-20 | 0d | 42d | 1d | finish no earlier than 2003-11-20 | STEREO | IMPACT | SEP Package | SEP Cen |  |  |  |  | SEP Cen FM 1 (Use latest date) |
| 58 | 1.2.6.5.2.4 | Receive SEP Central FM 1Analog/Post-Reg Board for SEP FM 1 I & T | milestone | 0d | 2003-11-21 | 2003-11-21 | 57 |  |  | 2003-11-21 | 2003-11-21 | 0d | 41d | 33d | finish no earlier than 2003-11-21 | STEREO | IMPACT | SEP Package |  |  |  |  |  |  |
| 59 | 1.1.6.28 | Deliver Bench Tested SEP Cental FM 2 Analog/Post-Reg Board for SEP FM 2 I & T | milestone | 0d | 2003-11-20 | 2003-11-20 | 269 |  |  | 2003-11-20 | 2003-11-20 | 0d | 42d | 1d | finish no earlier than 2003-11-20 | STEREO | IMPACT | SEP Package | SEP Cen |  |  |  |  | SEP Cen FM 2 (Use latest date) |
| 60 | 1.2.6.5.3.4 | Receive SEP Central FM 2Analog/Post-Reg Board for SEP FM 2 I & T | milestone | 0d | 2003-11-21 | 2003-11-21 | 59 |  |  | 2003-11-21 | 2003-11-21 | 0d | 41d | 33d | finish no earlier than 2003-11-21 | STEREO | IMPACT | SEP Package |  |  |  |  |  |  |
| 61 | 1.1.6.30 | Deliver Bench Tested SEP Cental EM SSD Bias Supply for SEP EM I & T | milestone | 0d | 2003-06-25 A | 2003-07-07 | 336 | 50% | 0d | 2003-05-28 | 2003-05-28 | 0d | 112.65d | 0d |  | STEREO | IMPACT | SEP Package | SEP Cen |  |  |  |  | SEP Cen EM (Use latest date) |
| 62 | 1.2.6.5.1.8 | Receive SEP Central EM SSD Bias Supply for SEP EM I & T | milestone | 0d | 2003-06-25 A | 2003-07-07 | 61 | 50% | 0d | 2003-05-28 | 2003-05-28 | 0d | 112.65d | 41.65d |  | STEREO | IMPACT | SEP Package |  |  |  |  |  |  |
| 63 | 1.1.6.32 | Deliver Bench Tested SEP Cental FM 1 SSD Bias Supply for SEP FM 1 I & T | milestone | 0d | 2003-11-27 | 2003-11-27 | 345 |  |  | 2003-11-27 | 2003-11-27 | 0d | 38d | 1d | finish no earlier than 2003-11-27 | STEREO | IMPACT | SEP Package | SEP Cen |  |  |  |  | SEP Cen FM 1 (Use latest date) |
| 64 | 1.2.6.5.2.6 | Receive SEP Central FM 1 SSD Bias Supply Board for SEP FM 1 I & T | milestone | 0d | 2003-11-28 | 2003-11-28 | 63 |  |  | 2003-11-28 | 2003-11-28 | 0d | 37d | 29d | finish no earlier than 2003-11-28 | STEREO | IMPACT | SEP Package |  |  |  |  |  |  |
| 65 | 1.1.6.34 | Deliver Bench Tested SEP Cental FM 2 SSD Bias Supply for SEP FM 2 I & T | milestone | 0d | 2003-11-27 | 2003-11-27 | 345 |  |  | 2003-11-27 | 2003-11-27 | 0d | 38d | 1d | finish no earlier than 2003-11-27 | STEREO | IMPACT | SEP Package | SEP Cen |  |  |  |  | SEP Cen FM 2 (Use latest date) |
| 66 | 1.1.6.35 | Deliver SEP Central Build 1 For SEP I & T | milestone | 0d | 2003-04-08 A | 2003-04-08 A | 361 | 100% |  | 2003-05-30 | 2003-05-30 | 0d |  |  |  | STEREO | IMPACT | SEP Package |  |  |  |  |  |  |
| 67 | 1.2.6.5.1.12 | Receive SEP Central S/W Build 1 for SEP I & T | milestone | 0d | 2003-04-08 A | 2003-04-08 A | 66 | 100% |  | 2003-05-30 | 2003-05-30 | 0d |  |  |  | STEREO | IMPACT | SEP Package |  |  |  |  |  |  |
| 68 | 1.1.6.37 | Deliver SEP Central Build 2 For SEP I & T | milestone | 0d | 2003-07-29 A | 2003-07-29 A | 362 | 100% |  | 2003-08-27 | 2003-08-27 | 0d |  |  |  | STEREO | IMPACT | SEP Package |  |  |  |  |  |  |
| 69 | 1.2.6.5.1.14 | Receive SEP Central S/W Build 2 for SEP I & T | milestone | 0d | 2003-07-29 A | 2003-07-29 A | 68 | 100% |  | 2003-08-27 | 2003-08-27 | 0d |  |  |  | STEREO | IMPACT | SEP Package |  |  |  |  |  |  |
| 70 | 1.1.6.39 | Deliver SEP Central Build 3 For SEP I & T | milestone | 0d | 2003-12-05 | 2003-12-05 | 363 |  |  | 2004-02-03 | 2004-02-03 | 0d | 147d | 0d |  | STEREO | IMPACT | SEP Package |  |  |  |  |  |  |
| 71 | 1.2.6.5.1.16 | Receive SEP Central S/W Build 3 for SEP I & T | milestone | 0d | 2003-12-05 | 2003-12-05 | 70 |  |  | 2004-02-03 | 2004-02-03 | 0d | 448d |  |  | STEREO | IMPACT | SEP Package |  |  |  |  |  |  |
| 72 | 1.2.6.5.3.6 | Receive SEP Central FM 2 SSD Bias Supply Board for SEP FM 2 I & T | milestone | 0d | 2003-11-28 | 2003-11-28 | 65 |  |  | 2003-11-28 | 2003-11-28 | 0d | 37d | 29d | finish no earlier than 2003-11-28 | STEREO | IMPACT | SEP Package |  |  |  |  |  |  |

| ID | WBS | Task | Type | Duration | Start | Finish | Predecessors | Complete | Remaining | Baseline start | Baseline finish | Baseline duration | Total slack | Free slack | Constraint | Text11 | Text12 | Text13 | Text28 | Text14 | Text16 | Text23 | Text17 | Text19 |
| --- | --- | --- | --- | --- | --- | --- | --- | --- | --- | --- | --- | --- | --- | --- | --- | --- | --- | --- | --- | --- | --- | --- | --- | --- |
| 73 | 1.2 | **Documentation** |  | 0d | 2003-04-22 A | 2003-04-22 A |  | 100% |  | 2003-02-25 | 2003-02-25 | 0d |  |  |  | STEREO | IMPACT | SEP Package | CIT |  |  |  |  |  |
| 74 | 1.2.1 | Data Transfer Protocol ICD Finished | milestone | 0d | 2003-04-22 A | 2003-04-22 A | 80 | 100% |  | 2003-02-25 | 2003-02-25 | 0d |  |  | start no earlier than 2003-03-31 | STEREO | IMPACT | SEP Package | CIT | SEP Cen |  |  |  |  |
| 75 | 2 | **Systems Engineering** |  | 588d | 2001-08-15 A | 2003-12-18 |  | 96% | 25.23d | 2001-08-15 | 2004-01-06 | 599d | 138d |  |  | STEREO | IMPACT | SEP Package | CIT |  |  |  |  |  |
| 76 | 2.1 | **Documentation** |  | 588d | 2001-08-15 A | 2003-12-18 |  | 96% | 25.23d | 2001-08-15 | 2004-01-06 | 599d | 138d |  |  | STEREO | IMPACT | SEP Package | CIT |  |  |  |  |  |
| 77 | 2.1.1 | Write preliminary software dev plan |  | 71d | 2001-08-15 A | 2001-11-27 A |  | 100% |  | 2001-08-15 | 2001-11-27 | 71d |  |  | start no earlier than 2001-08-15 | STEREO | IMPACT | SEP Package | CIT | SEP Cen | SEP DPU |  |  |  |
| 78 | 2.1.2 | Write final Software Development Plan |  | 5d | 2002-09-23 A | 2002-09-27 A | 77, 94FS-8d | 100% |  | 2002-09-23 | 2002-09-27 | 5d |  |  |  | STEREO | IMPACT | SEP Package | CIT | SEP Cen | SEP DPU |  |  |  |
| 79 | 2.1.3 | Write software requirements doc |  | 41d | 2001-11-14 A | 2002-01-15 A | 77FS-9d | 100% |  | 2001-11-14 | 2002-01-15 | 41d |  |  |  | STEREO | IMPACT | SEP Package | CIT | SEP Cen | SEP DPU |  |  |  |
| 80 | 2.1.4 | Write data transfer protocol section of SEP ICD |  | 21d | 2002-07-02 A | 2003-04-22 A | 79FS-9d | 100% |  | 2002-07-02 | 2003-02-25 | 21d |  |  | start no earlier than 2002-07-01 | STEREO | IMPACT | SEP Package | CIT | SEP Cen | SEP DPU |  |  |  |
| 81 | 2.1.5 | Software Design Review Preparation |  | 6d | 2002-05-13 A | 2002-05-20 A | 3FS-10d | 100% |  | 2002-05-13 | 2002-05-20 | 6d |  |  | start no earlier than 2002-08-31 | STEREO | IMPACT | SEP Package | CIT | SEP Cen | SEP DPU |  |  |  |
| 82 | 2.1.6 | Update Flight Software User's Manual |  | 5d | 2003-12-12 | 2003-12-18 |  |  |  | 2003-12-12 | 2003-12-18 | 5d | 138d |  | start no earlier than 2003-12-12 | STEREO | IMPACT | SEP Package | CIT | SEP Cen | SEP DPU | B3 Flight Software Available W/User Manual |  |  |
| 83 | 2.1.7 | Collect & verify SEP power requirements |  | 2d | 2001-09-11 A | 2001-09-12 A | 291 | 100% |  | 2001-09-11 | 2001-09-12 | 2d |  |  |  | STEREO | IMPACT | SEP Package | CIT | PS | SEP DPU |  | LVPS |  |
| 84 | 2.1.8 | Prepare SEP LVPS design spec & communicate to UCB |  | 5.5d | 2002-01-02 A | 2002-07-05 A | 83FS+75d | 100% |  | 2002-01-02 | 2002-07-05 | 5.5d |  |  |  | STEREO | IMPACT | SEP Package | CIT | PS | SEP DPU |  | LVPS |  |
| 85 | 2.1.9 | Collect SEP power req update |  | 1d | 2003-09-18 | 2003-09-18 | 197, 94 |  |  | 2003-06-11 | 2003-06-11 | 1d | 199.2d | 0d |  | STEREO | IMPACT | SEP Package | CIT | PS | SEP DPU |  | LVPS |  |
| 86 | 2.1.10 | Update SEP LVPS design spec & communicate to UC-B |  | 1d | 2003-05-09 A | 2003-09-19 | 85 | 20% | 0.8d | 2003-06-12 | 2003-06-12 | 1d | 199.2d |  |  | STEREO | IMPACT | SEP Package | CIT | PS | SEP DPU |  | LVPS |  |
| 87 | 3 | **Structures** |  | 358.5d | 2002-05-29 A | 2003-10-30 |  | 36% | 230.46d | 2002-05-29 | 2003-05-30 | 253d | 56.5d |  |  | STEREO | IMPACT | SEP Package | GSFC |  |  |  |  |  |
| 88 | 3.1 | **Design, Manufacture, Assembly and Test** |  | 358.5d | 2002-05-29 A | 2003-10-30 |  | 36% | 230.46d | 2002-05-29 | 2003-05-30 | 253d | 56.5d |  |  | STEREO | IMPACT | SEP Package | GSFC |  |  |  |  |  |
| 89 | 3.1.1 | **Design** |  | 338.5d | 2002-05-29 A | 2003-10-01 |  | 50% | 169.25d | 2002-05-29 | 2003-05-01 | 233d | 56.5d |  |  | STEREO | IMPACT | SEP Package | GSFC |  |  |  |  |  |
| 90 | 3.1.1.1 | Design SEP Common Electronics Enclosure |  | 100d | 2002-05-29 A | 2003-10-01 |  | 50% | 50d | 2002-05-29 | 2003-05-01 | 71d | 56.5d | 0d | finish no earlier than 2003-05-01 | STEREO | IMPACT | SEP Package | GSFC | SEP Cen | SEP DPU |  |  | Sandy Shuman |
| 91 | 3.1.2 | **Fabrication** |  | 15d | 2003-10-01 | 2003-10-23 |  |  |  | 2003-05-02 | 2003-05-22 | 15d | 56.5d |  |  | STEREO | IMPACT | SEP Package | GSFC |  | SEP DPU |  |  |  |
| 92 | 3.1.2.1 | **FM 1 & FM 2** |  | 15d | 2003-10-01 | 2003-10-23 |  |  |  | 2003-05-02 | 2003-05-22 | 15d | 56.5d |  |  | STEREO | IMPACT | SEP Package | GSFC |  | SEP DPU |  |  |  |
| 93 | 3.1.2.1.1 | **FM 1** |  | 15d | 2003-10-01 | 2003-10-23 |  |  |  | 2003-05-02 | 2003-05-22 | 15d | 56.5d |  |  | STEREO | IMPACT | SEP Package | GSFC |  | SEP DPU |  |  |  |
| 94 | 1.1.13 | Instrument CDR | milestone | 3d | 2002-11-20 A | 2002-11-22 A |  | 100% |  |  |  |  |  |  | finish no earlier than 2002-11-22 | STEREO | IMPACT | SEP Package |  |  |  |  |  |  |
| 95 | 3.1.2.1.1.2 | Fabricate SEP FM 1 Common Electronics Enclosure |  | 15d | 2003-10-01 | 2003-10-23 | 90, 94 |  |  | 2003-05-02 | 2003-05-22 | 15d | 56.5d | 0d |  | STEREO | IMPACT | SEP Package | GSFC | SEP Cen | SEP DPU | FM 1 SEP Central Common Enclosure Fabricated |  | Sandy Shuman |
| 96 | 3.1.2.1.2 | **FM 2** |  | 15d | 2003-10-01 | 2003-10-23 |  |  |  | 2003-05-02 | 2003-05-22 | 15d | 56.5d |  |  | STEREO | IMPACT | SEP Package | GSFC |  | SEP DPU |  |  |  |
| 97 | 3.1.2.1.2.1 | Fabricate SEP FM 2 Common Electronics Enclosure |  | 15d | 2003-10-01 | 2003-10-23 | 90, 94 |  |  | 2003-05-02 | 2003-05-22 | 15d | 56.5d | 0d |  | STEREO | IMPACT | SEP Package | GSFC | SEP Cen | SEP DPU | FM 2 SEP Central Common Enclosure Fabricated |  | Sandy Shuman |

Notes:
- 90: Removed as dependency on CDR for 10/31 reporting
- 95: Added SNL date due to TYCHO CDR Schedule slip, need to adjust later
- 97: Added SNL date due to TYCHO CDR Schedule slip, need to adjust later

| ID | WBS | Task | Type | Duration | Start | Finish | Predecessors | Complete | Remaining | Baseline start | Baseline finish | Baseline duration | Total slack | Free slack | Constraint | Text11 | Text12 | Text13 | Text16 | Text28 | Text14 | Text19 | Text23 | Text15 | Text20 | Text21 |
| --- | --- | --- | --- | --- | --- | --- | --- | --- | --- | --- | --- | --- | --- | --- | --- | --- | --- | --- | --- | --- | --- | --- | --- | --- | --- | --- |
| 98 | 3.1.3 | **Assembly** |  | 5d | 2003-10-23 | 2003-10-30 |  |  |  | 2003-05-23 | 2003-05-30 | 5d | 56.5d |  |  | STEREO | IMPACT | SEP Package | SEP DPU | GSFC |  |  |  |  |  |  |
| 99 | 3.1.3.1 | **FM 1** |  | 5d | 2003-10-23 | 2003-10-30 |  |  |  | 2003-05-23 | 2003-05-30 | 5d | 56.5d |  |  | STEREO | IMPACT | SEP Package | SEP DPU | GSFC |  |  |  |  |  |  |
| 100 | 3.1.3.1.1 | Assemble SEP FM 1 Common Electronics Enclosure |  | 5d | 2003-10-23 | 2003-10-30 | 95 |  |  | 2003-05-23 | 2003-05-30 | 5d | 56.5d | 0d |  | STEREO | IMPACT | SEP Package | SEP DPU | GSFC | SEP Cen | Sandy Shuman | FM 1 SEP Central Common Electronics Enclosesure Assembled |  |  |  |
| 101 | 3.1.3.2 | **FM 2** |  | 5d | 2003-10-23 | 2003-10-30 |  |  |  | 2003-05-23 | 2003-05-30 | 5d | 56.5d |  |  | STEREO | IMPACT | SEP Package | SEP DPU | GSFC |  |  |  |  |  |  |
| 102 | 3.1.3.2.1 | Assemble SEP FM 2 Common Electronics Enclosure |  | 5d | 2003-10-23 | 2003-10-30 | 97 |  |  | 2003-05-23 | 2003-05-30 | 5d | 56.5d | 0d |  | STEREO | IMPACT | SEP Package | SEP DPU | GSFC | SEP Cen | Sandy Shuman | FM 2 SEP Central Common Electronics Encloure Assembled |  |  |  |
| 103 | 4 | **SEP Central Logic Board** |  | 406.45d | 2002-05-01 A | 2003-12-12 |  | 80% | 82.11d | 2002-05-01 | 2003-11-11 | 385d | 142.55d |  |  | STEREO | IMPACT | SEP Package | SEP DPU | CIT |  |  |  | Logic Bd |  |  |
| 104 | 4.1 | **Design, Manufacture, Assembly and Test** |  | 406.45d | 2002-05-01 A | 2003-12-12 |  | 80% | 82.11d | 2002-05-01 | 2003-11-11 | 385d | 142.55d |  |  | STEREO | IMPACT | SEP Package | SEP DPU | CIT |  |  |  | Logic Bd |  |  |
| 105 | 4.1.1 | **Procurements** |  | 306.5d | 2002-05-01 A | 2003-07-21 |  | 94% | 17.9d | 2002-05-01 | 2003-07-01 | 294d | 76.5d |  |  | STEREO | IMPACT | SEP Package | SEP DPU | CIT |  |  |  | Logic Bd |  |  |
| 106 | 4.1.1.1 | **ETU** |  | 251.5d | 2002-05-01 A | 2003-05-01 A |  | 100% |  | 2002-05-01 | 2003-02-18 | 200d |  |  |  | STEREO | IMPACT | SEP Package | SEP DPU | CIT |  |  |  | Logic Bd |  |  |
| 107 | 4.1.1.1.1 | Procure SEP Central Logic Actel 54SX72A FPGA - EM | milestone | 0d | 2002-05-01 A | 2003-04-30 A |  | 100% |  | 2002-05-01 | 2003-02-01 | 0d |  |  | finish no earlier than 2002-08-01 | STEREO | IMPACT | SEP Package | SEP DPU | CIT | SEP Cen |  |  |  |  |  |
| 108 | 4.1.1.1.2 | Procure SEP Central Logic SRAM 128K x 8, 3.3V - EM |  | 29d | 2002-07-01 A | 2003-01-14 A |  | 100% |  | 2002-07-01 | 2003-01-14 | 29d |  |  | finish no earlier than 2002-08-01 | STEREO | IMPACT | SEP Package | SEP DPU | CIT | SEP Cen |  |  |  |  |  |
| 109 | 4.1.1.1.3 | Procure SEP Central Logic EEPROM 128K x 8, 3.3V - EM |  | 1d | 2002-05-01 A | 2002-08-01 A |  | 100% |  | 2002-05-01 | 2002-08-01 | 1d |  |  | finish no earlier than 2002-08-01 | STEREO | IMPACT | SEP Package | SEP DPU | CIT | SEP Cen |  |  |  |  |  |
| 110 | 4.1.1.1.4 | Procure SEP Central Logic Board EM Parts |  | 10d | 2003-01-22 A | 2003-05-01 A | 126, 127 | 100% |  | 2003-01-22 | 2003-02-07 | 10d |  |  | start no earlier than 2003-01-22 | STEREO | IMPACT | SEP Package | SEP DPU | CIT | SEP Cen |  |  |  |  |  |
| 111 | 4.1.1.1.5 | Procure SEP Central Logic EM Printed Circuit Board |  | 1d | 2003-02-18 A | 2003-02-18 A | 130 | 100% |  | 2003-02-18 | 2003-02-18 | 1d |  |  | start no earlier than 2003-02-03 | STEREO | IMPACT | SEP Package | SEP DPU | CIT | SEP Cen |  |  | Logic Bd |  |  |
| 112 | 4.1.1.2 | **FM 1 & FM 2** |  | 264.5d | 2002-07-01 A | 2003-07-21 |  | 91% | 23.57d | 2002-07-01 | 2003-07-01 | 252d | 76.5d |  |  | STEREO | IMPACT | SEP Package | SEP DPU | CIT |  |  |  | Logic Bd |  |  |
| 113 | 4.1.1.2.1 | Procure SEP Central Logic Actel RTSX72S FPGA - flight |  | 22d | 2002-07-01 A | 2002-07-31 A |  | 100% |  | 2002-07-01 | 2002-07-31 | 22d |  |  | start no earlier than 2002-07-01 | STEREO | IMPACT | SEP Package | SEP DPU | CIT | SEP Cen |  |  |  |  |  |
| 114 | 4.1.1.2.2 | Procure SEP Central Logic EEPROM 128K x 8, 3.3V - flight |  | 1d | 2002-07-01 A | 2002-08-01 A |  | 100% |  | 2002-07-01 | 2002-08-01 | 1d |  |  | finish no earlier than 2002-08-01 | STEREO | IMPACT | SEP Package | SEP DPU | CIT | SEP Cen |  |  |  |  |  |
| 115 | 4.1.1.2.3 | Procure SEP Central Logic SRAM 128K x 8, 3.3V - flight |  | 29d | 2002-07-01 A | 2003-01-14 A |  | 100% |  | 2002-07-01 | 2003-01-14 | 29d |  |  | finish no earlier than 2002-08-01 | STEREO | IMPACT | SEP Package | SEP DPU | CIT | SEP Cen |  |  |  |  |  |
| 116 | 4.1.1.2.4 | Procure SEP Central Logic Clock Oscillator, 16 MHz |  | 1d | 2002-07-02 A | 2003-05-01 A |  | 100% |  | 2002-07-02 | 2003-02-03 | 1d |  |  | start no earlier than 2002-07-01 | STEREO | IMPACT | SEP Package | SEP DPU | CIT | SEP Cen |  |  |  |  |  |
| 117 | 4.1.1.2.5 | Procure SEP Central Logic Board Flight Parts |  | 19d | 2003-05-07 A | 2003-07-07 | 170, 133 | 95% | 0.95d | 2003-05-08 | 2003-06-04 | 19d | 36.55d | 0d |  | STEREO | IMPACT | SEP Package | SEP DPU | CIT | SEP Cen |  |  |  |  |  |
| 118 | 4.1.1.2.6 | Procure SEP Central Logic Flight Printed Circuit Boards |  | 6d | 2003-07-11 | 2003-07-21 | 138 |  |  | 2003-06-24 | 2003-07-01 | 6d | 76.5d | 0d |  | STEREO | IMPACT | SEP Package | SEP DPU | CIT | SEP Cen |  |  | Logic Bd |  |  |
| 119 | 4.1.2 | **Design** |  | 346.45d | 2002-07-02 A | 2003-11-18 |  | 93% | 23.99d | 2002-07-02 | 2003-10-16 | 325d | 159.55d |  |  | STEREO | IMPACT | SEP Package | SEP DPU | CIT |  |  |  | Logic Bd |  |  |
| 120 | 4.1.2.1 | **ETU** |  | 229.5d | 2002-07-02 A | 2003-06-02 A |  | 100% |  | 2002-07-02 | 2003-05-08 | 214d |  |  |  | STEREO | IMPACT | SEP Package | SEP DPU | CIT |  |  |  | Logic Bd |  |  |
| 121 | 4.1.2.1.1 | SEP Central Logic Design Complete |  | 1d | 2003-05-06 A | 2003-05-06 A | 131FF-1d | 100% |  | 2003-05-07 | 2003-05-07 | 0d |  |  |  | STEREO | IMPACT | SEP Package |  | CIT | SEP Cen |  |  |  | SEP Central Logic EM Design | SEP Cntrl. Logic EM Dsgn |
| 122 | 5.1.2.1.1 | Design and sketch LET MISC Printed Circuit Board schematics for EM |  | 40d | 2002-07-02 A | 2002-11-06 A |  | 100% |  |  |  |  |  |  | start no earlier than 2002-07-01 | STEREO | IMPACT | SEP Package |  |  |  |  |  |  |  |  |
| 123 | 4.1.2.1.3 | Design and sketch Printed Circuit Board schematics for SEP Central Logic EM |  | 56.7d | 2002-07-02 A | 2002-11-12 A | 122SS | 100% |  | 2002-07-02 | 2002-11-12 | 56.7d |  |  |  | STEREO | IMPACT | SEP Package | SEP DPU | CIT | SEP Cen |  |  | Logic Bd |  |  |
| 124 | 4.1.2.1.4 | Design Printed Circuit Board schematics for SEP Central Logic EM version |  | 5d | 2002-11-13 A | 2002-11-19 A | 123 | 100% |  | 2002-11-13 | 2002-11-19 | 5d |  |  |  | STEREO | IMPACT | SEP Package | SEP DPU | CIT | SEP Cen |  |  | Logic Bd |  |  |
| 125 | 4.1.2.1.5 | Design FPGA schem/EEPROM for SEP Central Logic EM version |  | 29d | 2002-12-02 A | 2003-01-14 A | 124 | 100% |  | 2002-12-02 | 2003-01-14 | 29d |  |  | start no earlier than 2002-11-30 | STEREO | IMPACT | SEP Package | SEP DPU | CIT | SEP Cen |  |  | Logic Bd |  |  |
| 126 | 4.1.2.1.6 | FMA/design review/risk assessment |  | 5d | 2003-01-15 A | 2003-01-21 A | 125 | 100% |  | 2003-01-15 | 2003-01-21 | 5d |  |  |  | STEREO | IMPACT | SEP Package | SEP DPU | CIT | SEP Cen |  |  | Logic Bd |  |  |
| 127 | 4.1.2.1.7 | Assess SEP Central Logic EM and Flight Parts |  | 19d | 2002-11-13 A | 2002-12-10 A | 123 | 100% |  | 2002-11-13 | 2002-12-10 | 19d |  |  |  | STEREO | IMPACT | SEP Package | SEP DPU | CIT | SEP Cen |  |  |  |  |  |
| 128 | 4.1.2.1.8 | Obtain samples & footprints, provide to Printed Circuit Board designer |  | 6d | 2002-12-11 A | 2002-12-18 A | 127 | 100% |  | 2002-12-11 | 2002-12-18 | 6d |  |  |  | STEREO | IMPACT | SEP Package | SEP DPU | CIT | SEP Cen |  |  | Logic Bd |  |  |
| 129 | 4.1.2.1.9 | Design SEP Central Logic EM Printed Circuit Board layout |  | 28d | 2002-12-19 A | 2003-02-14 A | 128 | 100% |  | 2002-12-19 | 2003-02-14 | 28d |  |  |  | STEREO | IMPACT | SEP Package | SEP DPU | CIT | SEP Cen |  |  | Logic Bd |  |  |
| 130 | 4.1.2.1.10 | Review & approve SEP Central Logic EM Printed Circuit Board layout |  | 1d | 2003-02-14 A | 2003-02-14 A | 129FS-1d | 100% |  | 2003-02-14 | 2003-02-14 | 1d |  |  |  | STEREO | IMPACT | SEP Package | SEP DPU | CIT | SEP Cen |  |  | Logic Bd |  |  |
| 131 | 4.1.2.1.11 | Doc SEP Central Logic EM board rework (traveler, ECR) |  | 1d | 2003-05-09 A | 2003-06-02 A | 162FF-1d | 100% |  | 2003-05-08 | 2003-05-08 | 1d |  |  |  | STEREO | IMPACT | SEP Package | SEP DPU | CIT | SEP Cen |  |  | Logic Bd |  |  |

Notes:
- 110: May 2003 Status Update Analysis - How could the IDPU/SEP Central I/F test occur if Cal Tech had not completed the procurement of all the EM parts? Assumed these activities were missed during the April or May status update, took 100% credit. The note field identified this action so that no misunderstanding occurs.
- 113: GSFC Now Procuring talk to Antonio re activities

| ID | WBS | Task | Duration | Start | Finish | Predecessors | Complete | Remaining | Baseline start | Baseline finish | Baseline duration | Total slack | Free slack | Constraint | Text11 | Text12 | Text13 | Text15 | Text16 | Text28 | Text14 | Text23 |
| --- | --- | --- | --- | --- | --- | --- | --- | --- | --- | --- | --- | --- | --- | --- | --- | --- | --- | --- | --- | --- | --- | --- |
| 132 | 4.1.2.2 | **FM 1 & FM 2** | 138.45d | 2003-05-01 A | 2003-11-18 |  | 72% | 39.27d | 2003-05-01 | 2003-10-16 | 117d | 159.55d |  |  | STEREO | IMPACT | SEP Package | Logic Bd | SEP DPU | CIT |  |  |
| 133 | 4.1.2.2.1 | FMA/design review/risk assessment | 5d | 2003-05-01 A | 2003-07-03 |  | 50% | 2.5d | 2003-05-01 | 2003-05-07 | 5d | 36.55d | 0d | start no earlier than 2003-05-01 | STEREO | IMPACT | SEP Package |  |  |  |  |  |
| 134 | 4.1.2.2.2 | Revise/update Printed Circuit Board schematics for flight version | 10d | 2003-06-09 A | 2003-07-02 | 172SS+6d | 80% | 2d | 2003-05-08 | 2003-05-21 | 10d | 76.5d | 0d |  | STEREO | IMPACT | SEP Package | Logic Bd | SEP DPU | CIT | SEP Cen |  |
| 135 | 4.1.2.2.3 | Revise/update FPGA schem/EEPROM for flight ver | 19d | 2003-06-03 A | 2003-07-03 | 172 | 90% | 1.9d | 2003-05-08 | 2003-06-04 | 19d | 77.1d | 0d |  | STEREO | IMPACT | SEP Package | Logic Bd | SEP DPU | CIT | SEP Cen |  |
| 136 | 4.1.2.2.4 | Obtain samples & footprints, provide to Printed Circuit Board designer | 6d | 2003-06-06 A | 2003-06-16 A | 117 | 100% |  | 2003-06-05 | 2003-06-12 | 6d |  |  |  | STEREO | IMPACT | SEP Package | Logic Bd | SEP DPU | CIT | SEP Cen |  |
| 137 | 4.1.2.2.5 | Revise/update Printed Circuit Board layout for flight version | 5d | 2003-06-27 A | 2003-07-09 | 136, 135FS-1d, 134 | 30% | 3.5d | 2003-06-13 | 2003-06-19 | 5d | 76.5d | 0d |  | STEREO | IMPACT | SEP Package | Logic Bd | SEP DPU | CIT | SEP Cen |  |
| 138 | 4.1.2.2.6 | Review & approve flight Printed Circuit Board layout | 2d | 2003-07-09 | 2003-07-11 | 137 |  |  | 2003-06-20 | 2003-06-23 | 2d | 76.5d | 0d |  | STEREO | IMPACT | SEP Package | Logic Bd | SEP DPU | CIT | SEP Cen |  |
| 139 | 4.1.2.2.7 | Doc flight board rework (traveler, ECR) | 1d | 2003-11-14 | 2003-11-17 | 167, 127 |  |  | 2003-10-15 | 2003-10-15 | 1d | 36.55d | 0d |  | STEREO | IMPACT | SEP Package | Logic Bd | SEP DPU | CIT | SEP Cen |  |
| 140 | 4.1.2.2.8 | Final update of Printed Circuit Board schematics & layout | 1d | 2003-11-17 | 2003-11-18 | 139 |  |  | 2003-10-16 | 2003-10-16 | 1d | 159.55d |  |  | STEREO | IMPACT | SEP Package | Logic Bd | SEP DPU | CIT | SEP Cen |  |
| 141 | 4.1.3 | **Fabrication** | 144.45d | 2003-03-19 A | 2003-10-13 |  | 46% | 78.57d | 2003-02-03 | 2003-09-10 | 154d | 36.55d |  |  | STEREO | IMPACT | SEP Package | Logic Bd | SEP DPU | CIT |  |  |
| 142 | 4.1.3.1 | **ETU** | 31d | 2003-03-19 A | 2003-04-30 A |  | 100% |  | 2003-03-12 | 2003-03-24 | 9d |  |  |  | STEREO | IMPACT | SEP Package | Logic Bd | SEP DPU | CIT |  |  |
| 143 | 4.1.3.1.1 | Receive/inspect/database SEP Central Logic EM parts | 4d | 2003-04-22 A | 2003-04-25 A | 107FS+4d, 108FS+39d, 109FS+39d, 110FS+10d | 100% |  | 2003-03-12 | 2003-03-17 | 4d |  |  | start no earlier than 2003-03-31 | STEREO | IMPACT | SEP Package | Logic Bd | SEP DPU | CIT | SEP Cen |  |
| 144 | 4.1.3.1.2 | Inspect SEP Central Logic EM Printed Circuit Board | 1d | 2003-03-19 A | 2003-03-19 A | 111FS+20d | 100% |  | 2003-03-19 | 2003-03-19 | 0.5d |  |  |  | STEREO | IMPACT | SEP Package | Logic Bd | SEP DPU | CIT | SEP Cen | EM Logic Board Fabricated |
| 145 | 4.1.3.1.3 | Generate SEP Central Logic EM kit list in database | 2d | 2003-04-28 A | 2003-04-29 A | 143 | 100% |  | 2003-03-18 | 2003-03-19 | 2d |  |  | start no earlier than 2003-03-31 | STEREO | IMPACT | SEP Package | Logic Bd | SEP DPU | CIT | SEP Cen |  |
| 146 | 4.1.3.1.4 | Burn in SEP Central Logic EM FPGA/EEPROM | 1d | 2003-04-28 A | 2003-04-28 A | 143 | 100% |  | 2003-03-18 | 2003-03-18 | 1d |  |  | start no earlier than 2003-03-31 | STEREO | IMPACT | SEP Package | Logic Bd | SEP DPU | CIT | SEP Cen |  |
| 147 | 4.1.3.1.5 | Bend leads on SEP Central Logic EM ICs | 1d | 2003-04-28 A | 2003-04-28 A | 143 | 100% |  | 2003-03-18 | 2003-03-18 | 1d |  |  | start no earlier than 2003-03-31 | STEREO | IMPACT | SEP Package | Logic Bd | SEP DPU | CIT | SEP Cen |  |
| 148 | 4.1.3.1.6 | Generate SEP Central Logic EM kit book | 2d | 2003-04-29 A | 2003-04-30 A | 145FS-1d | 100% |  | 2003-03-19 | 2003-03-20 | 2d |  |  | start no earlier than 2003-03-31 | STEREO | IMPACT | SEP Package | Logic Bd | SEP DPU | CIT | SEP Cen |  |
| 149 | 4.1.3.1.7 | Kit SEP Central Logic EM parts | 2d | 2003-03-21 A | 2003-03-24 A | 148 | 100% |  | 2003-03-21 | 2003-03-24 | 2d |  |  |  | STEREO | IMPACT | SEP Package | Logic Bd | SEP DPU | CIT | SEP Cen |  |
| 150 | 4.1.3.2 | **FM 1 & FM 2** | 113.45d | 2003-05-01 A | 2003-10-13 |  | 10% | 101.82d | 2003-02-03 | 2003-09-10 | 154d | 36.55d |  |  | STEREO | IMPACT | SEP Package | Logic Bd | SEP DPU | CIT |  |  |
| 151 | 4.1.3.2.1 | Receive/inspect/database SEP Central Logic flight parts | 4d | 2003-09-29 | 2003-10-03 | 117FS+59d, 116, 115, 114, 113 |  |  | 2003-08-28 | 2003-09-03 | 4d | 36.55d | 0d |  | STEREO | IMPACT | SEP Package | Logic Bd | SEP DPU | CIT | SEP Cen |  |
| 152 | 4.1.3.2.2 | Inspect flight SEP Central Printed Circuit Boards (coupons & elec continuity) | 3d | 2003-08-11 | 2003-08-14 | 118FS+15d |  |  | 2003-07-24 | 2003-07-28 | 3d | 76.5d | 39.95d |  | STEREO | IMPACT | SEP Package | Logic Bd | SEP DPU | CIT | SEP Cen | Flight Logic Boards Fabricated |
| 153 | 4.1.3.2.3 | Generate SEP Central flight kit list in database | 1d | 2003-10-03 | 2003-10-07 | 151 |  |  | 2003-09-04 | 2003-09-04 | 1d | 36.55d | 0d |  | STEREO | IMPACT | SEP Package | Logic Bd | SEP DPU | CIT | SEP Cen |  |
| 154 | 4.1.3.2.4 | Rescreen heritage flight parts for SEP Central Logic Board | 5d | 2003-05-01 A | 2003-07-07 | 127 | 25% | 3.75d | 2003-02-03 | 2003-02-07 | 5d | 101.25d | 64.7d | start no earlier than 2003-04-30 | STEREO | IMPACT | SEP Package | Logic Bd | SEP DPU | CIT | SEP Cen |  |
| 155 | 4.1.3.2.5 | Burn-in flight FPGA/EEPROM for SEP Central Logic Board | 1d | 2003-07-03 | 2003-07-07 | 135 |  |  | 2003-06-05 | 2003-06-05 | 1d | 104.6d | 68.05d | start no earlier than 2003-06-30 | STEREO | IMPACT | SEP Package | Logic Bd | SEP DPU | CIT | SEP Cen |  |
| 156 | 4.1.3.2.6 | Bend leads on SEP Central Logic Boardflight Ics | 2d | 2003-07-09 A | 2003-07-14 | 138 | 40% | 1.2d | 2003-06-24 | 2003-06-25 | 2d | 99.3d | 62.75d |  | STEREO | IMPACT | SEP Package | Logic Bd | SEP DPU | CIT | SEP Cen |  |
| 157 | 4.1.3.2.7 | Generate flight SEP Central Logic Board kit book | 1d | 2003-10-07 | 2003-10-08 | 153 |  |  | 2003-09-05 | 2003-09-05 | 1d | 36.55d | 0d |  | STEREO | IMPACT | SEP Package | Logic Bd | SEP DPU | CIT | SEP Cen |  |
| 158 | 4.1.3.2.8 | Kit SEP Central Logic Board flight parts | 3d | 2003-10-08 | 2003-10-13 | 154, 157 |  |  | 2003-09-08 | 2003-09-10 | 3d | 36.55d | 0d |  | STEREO | IMPACT | SEP Package | Logic Bd | SEP DPU | CIT | SEP Cen |  |

Notes:
- 143: How could the IDPU/SEP Central I/F test occur if Cal Tech had not completed the procurement of all the EM parts? Assumed these activities were missed during the April or May status update, took 100% credit. The note field identified this action so that no misunderstanding occurs.

| ID | WBS | Task | Duration | Start | Finish | Predecessors | Complete | Remaining | Baseline start | Baseline finish | Baseline duration | Total slack | Free slack | Constraint | Text11 | Text12 | Text13 | Text15 | Text16 | Text28 | Text14 | Text23 | Text17 |
| --- | --- | --- | --- | --- | --- | --- | --- | --- | --- | --- | --- | --- | --- | --- | --- | --- | --- | --- | --- | --- | --- | --- | --- |
| 159 | 4.1.4 | **Assembly** | 163.45d | 2003-03-25 A | 2003-11-14 |  | 65% | 57.84d | 2003-03-25 | 2003-10-14 | 142d | 160.05d |  |  | STEREO | IMPACT | SEP Package | Logic Bd | SEP DPU | CIT |  |  |  |
| 160 | 4.1.4.1 | **ETU** | 69.2d | 2003-03-25 A | 2003-07-01 |  | 99% | 0.81d | 2003-03-25 | 2003-05-07 | 32d | 254.3d |  |  | STEREO | IMPACT | SEP Package | Logic Bd | SEP DPU | CIT |  |  |  |
| 161 | 4.1.4.1.1 | Assemble SEP Central Logic EM board and Preliminary Checkout | 15d | 2003-03-25 A | 2003-05-13 A | 144, 146, 147, 149 | 100% |  | 2003-03-25 | 2003-04-14 | 15d |  |  |  | STEREO | IMPACT | SEP Package | Logic Bd | SEP DPU | CIT | SEP Cen | EM Logic Board Assembled |  |
| 162 | 4.1.4.1.2 | Rework/Haywire/Trim SEP Central Logic EM Board | 2d | 2003-05-09 A | 2003-07-01 | 170 | 90% | 0.2d | 2003-05-06 | 2003-05-07 | 2d | 254.3d | 0d |  | STEREO | IMPACT | SEP Package | Logic Bd | SEP DPU | CIT | SEP Cen |  |  |
| 163 | 4.1.4.2 | **FM 1 & FM 2** | 23d | 2003-10-13 | 2003-11-14 |  |  |  | 2003-09-11 | 2003-10-14 | 23d | 36.55d |  |  | STEREO | IMPACT | SEP Package | Logic Bd | SEP DPU | CIT |  |  |  |
| 164 | 4.1.4.2.1 | Assemble flight SEP Central Logic boards | 5d | 2003-10-13 | 2003-10-20 | 118, 152, 154, 155, 156, 158 |  |  | 2003-09-11 | 2003-09-17 | 5d | 36.55d | 0d |  | STEREO | IMPACT | SEP Package | Logic Bd | SEP DPU | CIT | SEP Cen | Flight Logic Boards Assembled |  |
| 165 | 4.1.4.2.2 | Post-assembly QA inspection of SEP Central Logic Boards | 1d | 2003-10-17 | 2003-10-20 | 164FS-1d |  |  | 2003-09-17 | 2003-09-17 | 1d | 36.55d | 0d |  | STEREO | IMPACT | SEP Package | Logic Bd | SEP DPU | CIT | SEP Cen |  |  |
| 166 | 4.1.4.2.3 | Rework/haywire/trim flight SEP Central Logic boards | 2d | 2003-11-11 | 2003-11-13 | 174 |  |  | 2003-10-10 | 2003-10-13 | 2d | 36.55d | 0d |  | STEREO | IMPACT | SEP Package | Logic Bd | SEP DPU | CIT | SEP Cen |  |  |
| 167 | 4.1.4.2.4 | Post-rework QA inspection SEP Central Logic Boards | 1d | 2003-11-13 | 2003-11-14 | 166 |  |  | 2003-10-14 | 2003-10-14 | 1d | 36.55d | 0d |  | STEREO | IMPACT | SEP Package | Logic Bd | SEP DPU | CIT | SEP Cen |  |  |
| 168 | 4.1.5 | **Test** | 155.45d | 2003-05-01 A | 2003-12-12 |  | 19% | 125.68d | 2003-04-15 | 2003-11-11 | 146d | 142.55d |  |  | STEREO | IMPACT | SEP Package | Logic Bd | SEP DPU | CIT |  |  |  |
| 169 | 4.1.5.1 | **ETU** | 43.7d | 2003-05-01 A | 2003-07-02 |  | 82% | 7.95d | 2003-04-15 | 2003-05-07 | 17d | 254.3d |  |  | STEREO | IMPACT | SEP Package | Logic Bd | SEP DPU | CIT |  |  |  |
| 170 | 4.1.5.1.1 | Test SEP Central Logic EM board (Initial) | 6d | 2003-05-01 A | 2003-05-08 A | 161, 369 | 100% |  | 2003-04-15 | 2003-05-05 | 15d |  |  |  | STEREO | IMPACT | SEP Package | Logic Bd | SEP DPU | CIT | SEP Cen | EM Logic Board Tested |  |
| 171 | 4.1.5.1.2 | Test SEP Central Logic EM board (Final) | 3d | 2003-06-02 A | 2003-07-02 | 162 | 50% | 1.5d | 2003-06-02 | 2003-07-02 | 3d | 254.3d |  | start no earlier than 2003-05-31 | STEREO | IMPACT | SEP Package |  |  |  |  |  |  |
| 172 | 4.1.5.1.3 | Document SEP Central Logic EM Board Test Results | 2d | 2003-05-30 A | 2003-07-01 | 170FF-1d | 75% | 0.5d | 2003-05-06 | 2003-05-07 | 2d | 77.1d | 0d |  | STEREO | IMPACT | SEP Package | Logic Bd | SEP DPU | CIT | SEP Cen |  |  |
| 173 | 4.1.5.2 | **FM 1 & FM 2** | 37d | 2003-10-20 | 2003-12-12 |  |  |  | 2003-09-18 | 2003-11-11 | 37d | 36.55d |  |  | STEREO | IMPACT | SEP Package | Logic Bd | SEP DPU | CIT |  |  |  |
| 174 | 4.1.5.2.1 | Test flight SEP Central Logic boards (initial) | 15d | 2003-10-20 | 2003-11-11 | 165, 362 |  |  | 2003-09-18 | 2003-10-09 | 15d | 36.55d | 0d |  | STEREO | IMPACT | SEP Package | Logic Bd | SEP DPU | CIT | SEP Cen |  |  |
| 175 | 4.1.5.2.2 | Doc flight SEP Central Logic board test results | 3d | 2003-11-11 | 2003-11-14 | 174 |  |  | 2003-10-10 | 2003-10-14 | 3d | 161.55d |  |  | STEREO | IMPACT | SEP Package | Logic Bd | SEP DPU | CIT | SEP Cen |  |  |
| 176 | 4.1.5.2.3 | Stake/conformal coat flight SEP Central Logic boards | 1d | 2003-11-17 | 2003-11-18 | 139 |  |  | 2003-10-16 | 2003-10-16 | 1d | 36.55d | 0d |  | STEREO | IMPACT | SEP Package | Logic Bd | SEP DPU | CIT | SEP Cen |  |  |
| 177 | 4.1.5.2.4 | Bakeout flight SEP Central Logic boards | 1d | 2003-11-18 | 2003-11-19 | 176 |  |  | 2003-10-17 | 2003-10-17 | 1d | 36.55d | 0d |  | STEREO | IMPACT | SEP Package | Logic Bd | SEP DPU | CIT | SEP Cen |  |  |
| 178 | 4.1.5.2.5 | Post-conf. coat QA inspection of SEP Central Logic Boards | 1d | 2003-11-19 | 2003-11-20 | 177 |  |  | 2003-10-20 | 2003-10-20 | 1d | 36.55d | 0d |  | STEREO | IMPACT | SEP Package | Logic Bd | SEP DPU | CIT | SEP Cen |  |  |
| 179 | 4.1.5.2.6 | Test flight SEP Central Logic boards (final) | 5d | 2003-11-20 | 2003-11-28 | 178 |  |  | 2003-10-21 | 2003-10-27 | 5d | 36.55d | 0d |  | STEREO | IMPACT | SEP Package | Logic Bd | SEP DPU | CIT | SEP Cen |  |  |
| 180 | 4.1.5.2.7 | SEP Central Logic Board Mass properties/photo | 1d | 2003-11-28 | 2003-12-01 | 179 |  |  | 2003-10-28 | 2003-10-28 | 1d | 36.55d | 0d |  | STEREO | IMPACT | SEP Package | Logic Bd | SEP DPU | CIT | SEP Cen | Flight Logic Boards Tested |  |
| 181 | 4.1.5.2.8 | Maintain hard copy SEP Central Logic Boards docs | 9d | 2003-12-01 | 2003-12-12 | 180 |  |  | 2003-10-29 | 2003-11-11 | 9d | 142.55d |  |  | STEREO | IMPACT | SEP Package | Logic Bd | SEP DPU | CIT | SEP Cen |  |  |
| 182 | 5 | **SEP Low Voltage Power Supply** | 190d | 2003-05-01 A | 2004-02-03 |  | 15% | 161.97d | 2003-02-03 | 2004-01-02 | 231d | 108d |  |  | STEREO | IMPACT | SEP Package | LVPS Card | SEP DPU | CIT |  |  | LVPS |
| 183 | 5.1 | **Design, Manufacture, Assembly and Test** | 190d | 2003-05-01 A | 2004-02-03 |  | 15% | 161.97d | 2003-02-03 | 2004-01-02 | 231d | 108d |  |  | STEREO | IMPACT | SEP Package | LVPS Card | SEP DPU | CIT |  |  | LVPS |
| 184 | 5.1.1 | **Fabrication** | 33d | 2003-05-15 | 2003-07-01 |  |  |  | 2003-05-13 | 2003-05-22 | 8d | 71.5d |  |  | STEREO | IMPACT | SEP Package | LVPS Card | SEP DPU | CIT |  |  | LVPS |
| 185 | 5.1.1.1 | **ETU** | 5d | 2003-05-15 | 2003-05-21 |  |  |  | 2003-05-13 | 2003-05-19 | 5d | 71.5d |  |  | STEREO | IMPACT | SEP Package | LVPS Card | SEP DPU | CIT |  |  | LVPS |
| 186 | 5.1.1.1.1 | Fabricate dummy load box for EM board test | 5d | 2003-05-15 | 2003-05-21 | 191 |  |  | 2003-05-13 | 2003-05-19 | 5d | 71.5d |  | start no earlier than 2003-04-30 | STEREO | IMPACT | SEP Package | LVPS Card | SEP DPU | CIT | PS |  | LVPS |

| ID | WBS | Task | Duration | Start | Finish | Predecessors | Complete | Remaining | Baseline start | Baseline finish | Baseline duration | Total slack | Free slack | Constraint | Text11 | Text12 | Text13 | Text15 | Text16 | Text17 | Text28 | Text14 | Text23 |
| --- | --- | --- | --- | --- | --- | --- | --- | --- | --- | --- | --- | --- | --- | --- | --- | --- | --- | --- | --- | --- | --- | --- | --- |
| 187 | 5.1.1.2 | **FM 1 & FM 2** | 1d | 2003-07-01 | 2003-07-01 |  |  |  | 2003-05-22 | 2003-05-22 | 1d | 255d |  |  | STEREO | IMPACT | SEP Package | LVPS Card | SEP DPU | LVPS | CIT |  |  |
| 188 | 5.1.1.2.1 | Modify dummy load box for flight boards test | 1d | 2003-07-01 | 2003-07-01 | 199 |  |  | 2003-05-22 | 2003-05-22 | 1d | 255d |  | start no earlier than 2003-06-30 | STEREO | IMPACT | SEP Package | LVPS Card | SEP DPU | LVPS | CIT | PS |  |
| 189 | 5.1.2 | **Test** | 190d | 2003-05-01 A | 2004-02-03 |  | 16% | 158.91d | 2003-02-03 | 2004-01-02 | 231d | 106.2d |  |  | STEREO | IMPACT | SEP Package | LVPS Card | SEP DPU | LVPS | CIT |  |  |
| 190 | 5.1.2.1 | **ETU** | 97d | 2003-05-01 A | 2003-09-17 |  | 28% | 69.72d | 2003-02-03 | 2003-05-29 | 82d | 199.2d |  |  | STEREO | IMPACT | SEP Package | LVPS Card | SEP DPU | LVPS | CIT |  |  |
| 191 | 5.1.2.1.1 | Prepare test spec for EM board test | 10d | 2003-05-01 | 2003-05-14 |  |  |  | 2003-04-01 | 2003-04-14 | 10d | 71.5d | 0d | start no earlier than 2003-04-30 | STEREO | IMPACT | SEP Package | LVPS Card | SEP DPU | LVPS | CIT | SEP Cen |  |
| 192 | 5.1.2.1.2 | Inspect/document EM board | 0.5d | 2003-09-03 | 2003-09-03 | 17 |  |  | 2003-05-05 | 2003-05-07 | 3d | 0d |  |  | STEREO | IMPACT | SEP Package | LVPS Card | SEP DPU | LVPS | CIT | SEP Cen |  |
| 193 | 5.1.2.1.3 | Test EM board with dummy load box | 0.5d | 2003-09-03 | 2003-09-03 | 186, 191, 192 |  |  | 2003-05-08 | 2003-05-14 | 5d | 0d |  |  | STEREO | IMPACT | SEP Package | LVPS Card | SEP DPU | LVPS | CIT | SEP Cen | ETU LVPS Tested |
| 194 | 5.1.2.1.4 | (OBSOLETE) Integrate & test EM board with SEP EM | 9d | 2003-05-01 A | 2003-05-13 A |  | 100% |  | 2003-02-03 | 2003-02-13 | 9d |  |  | start no earlier than 2003-04-30 | STEREO | IMPACT | SEP Package | LVPS Card | SEP DPU | LVPS | CIT | SEP Cen |  |
| 195 | 5.1.2.1.5 | Document EM boards test results | 5d | 2003-09-04 | 2003-09-10 | 194, 193 |  |  | 2003-05-15 | 2003-05-21 | 5d | 0d |  |  | STEREO | IMPACT | SEP Package | LVPS Card | SEP DPU | LVPS | CIT | SEP Cen |  |
| 196 | 5.1.2.1.6 | Provide feedback to UCB designer | 2d | 2003-09-11 | 2003-09-12 | 195 |  |  | 2003-05-22 | 2003-05-23 | 2d | 0d |  |  | STEREO | IMPACT | SEP Package | LVPS Card | SEP DPU | LVPS | CIT | SEP Cen |  |
| 197 | 5.1.2.1.7 | Test EM board with SEP EM (final) | 5d | 2003-09-11 | 2003-09-17 | 195 |  |  | 2003-05-22 | 2003-05-29 | 5d | 199.2d | 0d |  | STEREO | IMPACT | SEP Package | LVPS Card | SEP DPU | LVPS | CIT | SEP Cen |  |
| 198 | 5.1.2.2 | **FM 1 & FM 2** | 176d | 2003-05-21 | 2004-02-03 |  |  |  | 2003-05-21 | 2004-01-02 | 155d | 46d |  |  | STEREO | IMPACT | SEP Package | LVPS Card | SEP DPU | LVPS | CIT |  |  |
| 199 | 5.1.2.2.1 | Prepare test spec for flight boards | 1d | 2003-05-21 | 2003-05-21 |  |  |  | 2003-05-21 | 2003-05-21 | 1d | 159d | 27d | start no earlier than 2003-05-21 | STEREO | IMPACT | SEP Package | LVPS Card | SEP DPU | LVPS | CIT | SEP Cen |  |
| 200 | 5.1.2.2.2 | **FM 1** | 11d | 2003-12-26 | 2004-01-13 |  |  |  | 2003-10-13 | 2003-12-11 | 42d | 8d |  |  | STEREO | IMPACT | SEP Package | LVPS Card | SEP DPU | LVPS | CIT |  |  |
| 201 | 5.1.2.2.2.1 | Receive/QA inspect/document FM 1 boards | 2d | 2003-12-26 | 2003-12-29 | 19 |  |  | 2003-10-13 | 2003-10-14 | 2d | 8d | 0d |  | STEREO | IMPACT | SEP Package | LVPS Card | SEP DPU | LVPS | CIT | SEP Cen |  |
| 202 | 5.1.2.2.2.2 | Test FM 1 board with dummy load box | 9d | 2003-12-30 | 2004-01-13 | 199, 201 |  |  | 2003-12-01 | 2003-12-11 | 9d | 8d | 0d | finish no earlier than 2003-12-11 | STEREO | IMPACT | SEP Package | LVPS Card | SEP DPU | LVPS | CIT | SEP Cen | FM 1 LVPS Tested |
| 203 | 5.1.2.2.3 | **FM 2** | 11d | 2004-01-20 | 2004-02-03 |  |  |  | 2003-12-17 | 2004-01-02 | 11d | 46d |  |  | STEREO | IMPACT | SEP Package | LVPS Card | SEP DPU | LVPS | CIT |  |  |
| 204 | 5.1.2.2.3.1 | Receive/QA inspect/document FM 2 boards | 2d | 2004-01-20 | 2004-01-21 | 21 |  |  | 2003-12-17 | 2003-12-18 | 2d | 46d | 0d |  | STEREO | IMPACT | SEP Package | LVPS Card | SEP DPU | LVPS | CIT | SEP Cen |  |
| 205 | 5.1.2.2.3.2 | Test FM 2 Board with dummy load box | 9d | 2004-01-22 | 2004-02-03 | 204 |  |  | 2003-12-19 | 2004-01-02 | 9d | 46d | 0d |  | STEREO | IMPACT | SEP Package | LVPS Card | SEP DPU | LVPS | CIT | SEP Cen | FM 2 LVPS Tested |
| 206 | 6 | **SEP Analog/Post-reg Board** | 632d | 2002-01-02 A | 2004-07-07 |  | 30% | 440.22d | 2002-01-02 | 2004-04-08 | 570d | 0d |  |  | STEREO | IMPACT | SEP Package | Alog/Post-Reg Bd | SEP DPU | LVPS | CIT |  |  |
| 207 | 6.1 | **Design, Manufacture, Assembly and Test** | 632d | 2002-01-02 A | 2004-07-07 |  | 30% | 440.22d | 2002-01-02 | 2004-04-08 | 570d | 0d |  |  | STEREO | IMPACT | SEP Package | Alog/Post-Reg Bd | SEP DPU | LVPS | CIT |  |  |
| 208 | 6.1.1 | **Procurements** | 391d | 2002-12-17 A | 2004-07-07 |  | 8% | 358.91d | 2002-12-17 | 2004-04-08 | 329d | 0d |  |  | STEREO | IMPACT | SEP Package | Alog/Post-Reg Bd | SEP DPU | LVPS | CIT |  |  |
| 209 | 6.1.1.1 | **ETU** | 391d | 2002-12-17 A | 2004-07-07 |  | 7% | 362.98d | 2002-12-17 | 2004-04-08 | 329d | 0d |  |  | STEREO | IMPACT | SEP Package | Alog/Post-Reg Bd | SEP DPU | LVPS | CIT |  |  |
| 210 | 6.1.1.1.1 | Procure Analog/Post-reg Board EM parts | 21d | 2002-12-17 A | 2003-01-17 A | 220 | 100% |  | 2002-12-17 | 2003-01-17 | 21d |  |  |  | STEREO | IMPACT | SEP Package | Alog/Post-Reg Bd | SEP DPU | LVPS | CIT | SEP Cen |  |
| 211 | 6.1.1.1.2 | Procure Analog/Post-reg from SI | 298d | 2003-05-01 | 2004-07-07 | 220 |  |  | 2003-02-03 | 2004-04-08 | 298d | 0d |  | start no earlier than 2003-04-30 | STEREO | IMPACT | SEP Package | Alog/Post-Reg Bd | SEP DPU | LVPS | CIT | SEP Cen |  |
| 212 | 6.1.1.1.3 | Procure Analog/Post-reg Board EM Printed Circuit Board | 2d | 2003-03-03 A | 2003-03-04 A | 228 | 100% |  | 2003-03-03 | 2003-03-04 | 2d |  |  |  | STEREO | IMPACT | SEP Package | Alog/Post-Reg Bd | SEP DPU | LVPS | CIT | SEP Cen |  |

Notes:
- 192: Changed duration from 3 days to 1 day to reflect actual plan.
- 194: Deleted Predessor of 192, since board goes to EM I & T / May 2003 Status (RSP) - Someone marked the test of the ETU LVPS with SEP Central as obsolete. Assume the compat test in the I & T schedule is this same activity.
- 199: Pred is 41
- 211: Change logic so that we can take 55% credit. Really money related.

| ID | WBS | Task | Duration | Start | Finish | Predecessors | Complete | Remaining | Baseline start | Baseline finish | Baseline duration | Total slack | Free slack | Constraint | Text11 | Text12 | Text13 | Text15 | Text16 | Text17 | Text28 | Text14 |
| --- | --- | --- | --- | --- | --- | --- | --- | --- | --- | --- | --- | --- | --- | --- | --- | --- | --- | --- | --- | --- | --- | --- |
| 213 | 6.1.1.2 | **FM 1 & FM 2** | 44.5d | 2003-06-10 A | 2003-08-12 |  | 50% | 22.25d | 2003-07-10 | 2003-08-28 | 36d | 80d |  |  | STEREO | IMPACT | SEP Package | Alog/Post-Reg Bd | SEP DPU | LVPS | CIT |  |
| 214 | 6.1.1.2.1 | Procure Analog/Post-reg Flight Boards parts | 5d | 2003-06-10 A | 2003-07-02 | 265FS-5d | 80% | 1d | 2003-07-10 | 2003-07-16 | 5d | 83.9d | 0d |  | STEREO | IMPACT | SEP Package | Alog/Post-Reg Bd | SEP DPU | LVPS | CIT | SEP Cen |
| 215 | 6.1.1.2.2 | Procure Analog/Post-reg Flight Boards Printed Circuit Boards | 3d | 2003-08-08 | 2003-08-12 | 239 |  |  | 2003-08-26 | 2003-08-28 | 3d | 80d | 0d |  | STEREO | IMPACT | SEP Package | Alog/Post-Reg Bd | SEP DPU | LVPS | CIT | SEP Cen |
| 216 | 6.1.2 | **Design** | 462d | 2002-01-02 A | 2003-10-31 |  | 80% | 91.22d | 2002-01-02 | 2003-11-19 | 474d | 170d |  |  | STEREO | IMPACT | SEP Package | Alog/Post-Reg Bd | SEP DPU | LVPS | CIT |  |
| 217 | 6.1.2.1 | **ETU** | 376.4d | 2002-01-02 A | 2003-07-01 |  | 99% | 2.48d | 2002-01-02 | 2003-07-09 | 382d | 80d |  |  | STEREO | IMPACT | SEP Package | Alog/Post-Reg Bd | SEP DPU | LVPS | CIT |  |
| 218 | 6.1.2.1.1 | Collect & verify SEP analog/post-reg requirements | 6.5d | 2002-01-02 A | 2002-12-03 A | 291FS+76d | 100% |  | 2002-01-02 | 2002-12-03 | 6.5d |  |  |  | STEREO | IMPACT | SEP Package | Alog/Post-Reg Bd | SEP DPU | LVPS | CIT | SEP Cen |
| 219 | 6.1.2.1.2 | Prepare Analog/Post-reg Board design spec & communicate to SI | 3d | 2002-04-26 A | 2002-04-30 A | 218 | 100% |  | 2002-04-26 | 2002-04-30 | 3d |  |  |  | STEREO | IMPACT | SEP Package | Alog/Post-Reg Bd | SEP DPU | LVPS | CIT | SEP Cen |
| 220 | 6.1.2.1.3 | Assess Analog/Post-reg Board EM & flight parts needs & availability | 2.4d | 2002-04-26 A | 2002-04-30 A | 219 | 100% |  | 2002-04-26 | 2002-04-30 | 2.4d |  |  |  | STEREO | IMPACT | SEP Package | Alog/Post-Reg Bd | SEP DPU | LVPS | CIT | SEP Cen |
| 221 | 6.1.2.1.4 | Obtain samples & footprint, provide to Printed Circuit Board designer | 2d | 2003-04-07 A | 2003-04-08 A | 244 | 100% |  | 2003-03-28 | 2003-03-31 | 2d |  |  | start no earlier than 2003-03-31 | STEREO | IMPACT | SEP Package | Alog/Post-Reg Bd | SEP DPU | LVPS | CIT | SEP Cen |
| 222 | 6.1.2.1.5 | Transfer Printed Circuit Board outline from GSFC to SI | 1d | 2002-05-01 A | 2002-05-01 A | 210FS-1d | 100% |  | 2002-05-01 | 2002-05-01 | 1d |  |  |  | STEREO | IMPACT | SEP Package | Alog/Post-Reg Bd | SEP DPU | LVPS | CIT | SEP Cen |
| 223 | 6.1.2.1.6 | Design Analog/Post-reg EM Board schematics | 14.8d | 2002-05-20 A | 2002-12-06 A | 222 | 100% |  | 2002-05-20 | 2002-12-06 | 14.8d |  |  |  | STEREO | IMPACT | SEP Package | Alog/Post-Reg Bd | SEP DPU | LVPS | CIT | SEP Cen |
| 224 | 6.1.2.1.7 | Verify design spec implementation - 1 | 3d | 2002-12-09 A | 2002-12-11 A | 223 | 100% |  | 2002-12-09 | 2002-12-11 | 3d |  |  | start no earlier than 2002-11-30 | STEREO | IMPACT | SEP Package | Alog/Post-Reg Bd | SEP DPU | LVPS | CIT | SEP Cen |
| 225 | 6.1.2.1.8 | FMA/design review/risk assessment | 5d | 2002-12-12 A | 2002-12-18 A | 224 | 100% |  | 2002-12-12 | 2002-12-18 | 5d |  |  |  | STEREO | IMPACT | SEP Package | Alog/Post-Reg Bd | SEP DPU | LVPS | CIT | SEP Cen |
| 226 | 6.1.2.1.9 | Provide feedback on design review to SI designer | 1d | 2002-12-19 A | 2002-12-19 A | 225 | 100% |  | 2002-12-19 | 2002-12-19 | 1d |  |  | start no earlier than 2002-11-30 | STEREO | IMPACT | SEP Package | Alog/Post-Reg Bd | SEP DPU | LVPS | CIT | SEP Cen |
| 227 | 6.1.2.1.10 | Design Analog/Post-reg EM Printed Circuit Board layout (final) | 17d | 2003-02-03 A | 2003-02-26 A | 226 | 100% |  | 2003-02-03 | 2003-02-26 | 17d |  |  | start no earlier than 2003-02-03 | STEREO | IMPACT | SEP Package | Alog/Post-Reg Bd | SEP DPU | LVPS | CIT | SEP Cen |
| 228 | 6.1.2.1.11 | Review & approve Analog/Post-reg EM Printed Circuit Board layout | 3d | 2003-02-27 A | 2003-03-03 A | 227 | 100% |  | 2003-02-27 | 2003-02-28 | 2d |  |  |  | STEREO | IMPACT | SEP Package | Alog/Post-Reg Bd | SEP DPU | LVPS | CIT | SEP Cen |
| 229 | 6.1.2.1.12 | Doc Analog/Post-reg EM board rework (traveler, ECR) | 2d | 2003-06-06 A | 2003-07-01 | 246 | 80% | 0.4d | 2003-07-08 | 2003-07-09 | 2d | 80d | 0d |  | STEREO | IMPACT | SEP Package | Alog/Post-Reg Bd | SEP DPU | LVPS | CIT | SEP Cen |
| 230 | 6.1.2.2 | **FM 1 & FM 2** | 104.5d | 2003-06-04 A | 2003-10-31 |  | 45% | 57.32d | 2003-07-03 | 2003-11-19 | 96d | 170d |  |  | STEREO | IMPACT | SEP Package | Alog/Post-Reg Bd | SEP DPU | LVPS | CIT |  |
| 231 | 6.1.2.2.1 | Revise/update Printed Circuit Board schematics for flight | 4d | 2003-06-04 A | 2003-07-02 | 264 | 90% | 0.4d | 2003-07-03 | 2003-07-09 | 4d | 254.6d |  |  | STEREO | IMPACT | SEP Package | Alog/Post-Reg Bd | SEP DPU | LVPS | CIT | SEP Cen |
| 232 | 6.1.2.2.2 | Obtain samples & footprints, provide to Printed Circuit Board designer | 5d | 2003-06-10 A | 2003-06-17 A | 214SS | 100% |  | 2003-07-10 | 2003-07-16 | 5d |  |  |  | STEREO | IMPACT | SEP Package | Alog/Post-Reg Bd | SEP DPU | LVPS | CIT | SEP Cen |
| 233 | 6.1.2.2.3 | Collect SEP analog/post-reg requirements update | 1d | 2003-06-17 A | 2003-07-02 | 214, 94 | 90% | 0.1d | 2003-07-17 | 2003-07-17 | 1d | 83.9d | 0d |  | STEREO | IMPACT | SEP Package | Alog/Post-Reg Bd | SEP DPU | LVPS | CIT | SEP Cen |
| 234 | 6.1.2.2.4 | Update design spec & communicate it to SI | 1d | 2003-06-18 A | 2003-07-09 | 265, 233 | 90% | 0.1d | 2003-07-18 | 2003-07-18 | 1d | 80d | 0d |  | STEREO | IMPACT | SEP Package | Alog/Post-Reg Bd | SEP DPU | LVPS | CIT | SEP Cen |
| 235 | 6.1.2.2.5 | Verify design spec implementation - 3 | 2d | 2003-07-09 | 2003-07-11 | 234 |  |  | 2003-07-21 | 2003-07-22 | 2d | 80d | 0d | start no earlier than 2003-06-30 | STEREO | IMPACT | SEP Package | Alog/Post-Reg Bd | SEP DPU | LVPS | CIT | SEP Cen |
| 236 | 6.1.2.2.6 | Design Analog/Post-reg Flight Boards schematics (final) | 5d | 2003-06-30 A | 2003-07-18 | 235FS+5d | 90% | 0.5d | 2003-07-30 | 2003-08-05 | 5d | 80d | 0d |  | STEREO | IMPACT | SEP Package | Alog/Post-Reg Bd | SEP DPU | LVPS | CIT | SEP Cen |
| 237 | 6.1.2.2.7 | Final design review | 2d | 2003-07-21 | 2003-07-22 | 236 |  |  | 2003-08-06 | 2003-08-07 | 2d | 80d | 0d |  | STEREO | IMPACT | SEP Package | Alog/Post-Reg Bd | SEP DPU | LVPS | CIT | SEP Cen |
| 238 | 6.1.2.2.8 | Layout analog/post-reg Printed Circuit Board (final) | 5d | 2003-07-30 | 2003-08-05 | 237FS+5d |  |  | 2003-08-15 | 2003-08-21 | 5d | 80d | 0d |  | STEREO | IMPACT | SEP Package | Alog/Post-Reg Bd | SEP DPU | LVPS | CIT | SEP Cen |
| 239 | 6.1.2.2.9 | Review & approve Analog/Post-reg Flight Boards Printed Circuit Board layout | 2d | 2003-08-06 | 2003-08-07 | 238 |  |  | 2003-08-22 | 2003-08-25 | 2d | 80d | 0d |  | STEREO | IMPACT | SEP Package | Alog/Post-Reg Bd | SEP DPU | LVPS | CIT | SEP Cen |
| 240 | 6.1.2.2.10 | Doc Analog/Post-reg Flight Boards rework (traveler, ECR) | 1d | 2003-10-20 | 2003-10-20 | 251 |  |  | 2003-11-05 | 2003-11-05 | 1d | 159d | 0d |  | STEREO | IMPACT | SEP Package | Alog/Post-Reg Bd | SEP DPU | LVPS | CIT | SEP Cen |
| 241 | 6.1.2.2.11 | Final update of Printed Circuit Board schematics & layout | 5d | 2003-10-27 | 2003-10-31 | 240FS+4d |  |  | 2003-11-13 | 2003-11-19 | 5d | 170d |  |  | STEREO | IMPACT | SEP Package | Alog/Post-Reg Bd | SEP DPU | LVPS | CIT | SEP Cen |

| ID | WBS | Task | Duration | Start | Finish | Predecessors | Complete | Remaining | Baseline start | Baseline finish | Baseline duration | Total slack | Free slack | Constraint | Text11 | Text12 | Text13 | Text15 | Text16 | Text17 | Text28 | Text14 | Text23 |
| --- | --- | --- | --- | --- | --- | --- | --- | --- | --- | --- | --- | --- | --- | --- | --- | --- | --- | --- | --- | --- | --- | --- | --- |
| 242 | 6.1.3 | **Fabrication** | 142d | 2003-03-28 A | 2003-10-17 |  | 61% | 55.22d | 2003-03-24 | 2003-11-04 | 158d | 180d |  |  | STEREO | IMPACT | SEP Package | Alog/Post-Reg Bd | SEP DPU | LVPS | CIT |  |  |
| 243 | 6.1.3.1 | **ETU** | 49.5d | 2003-03-28 A | 2003-06-06 A |  | 100% |  | 2003-03-24 | 2003-07-07 | 74d |  |  |  | STEREO | IMPACT | SEP Package | Alog/Post-Reg Bd | SEP DPU | LVPS | CIT |  |  |
| 244 | 6.1.3.1.1 | Receive/inspect/database Analog/Post-reg EM Board parts | 4d | 2003-04-01 A | 2003-04-04 A | 210FS+27d | 100% |  | 2003-03-24 | 2003-03-27 | 4d |  |  | start no earlier than 2003-03-31 | STEREO | IMPACT | SEP Package | Alog/Post-Reg Bd | SEP DPU | LVPS | CIT | SEP Cen |  |
| 245 | 6.1.3.1.2 | Inspect Analog/Post-reg EM Printed Circuit Board | 1d | 2003-03-28 A | 2003-03-28 A | 212FS+17d | 100% |  | 2003-03-28 | 2003-03-28 | 1d |  |  |  | STEREO | IMPACT | SEP Package | Alog/Post-Reg Bd | SEP DPU | LVPS | CIT | SEP Cen | EM Analog/Post-reg Board Fabricated |
| 246 | 6.1.3.1.3 | Rework/haywire/trim Analog/Post-reg EM board | 2d | 2003-06-04 A | 2003-06-06 A | 264 | 100% |  | 2003-07-03 | 2003-07-07 | 2d |  |  |  | STEREO | IMPACT | SEP Package | Alog/Post-Reg Bd | SEP DPU | LVPS | CIT | SEP Cen |  |
| 247 | 6.1.3.2 | **FM 1 & FM 2** | 75.5d | 2003-07-01 A | 2003-10-17 |  | 36% | 48.05d | 2003-07-31 | 2003-11-04 | 67d | 180d |  |  | STEREO | IMPACT | SEP Package | Alog/Post-Reg Bd | SEP DPU | LVPS | CIT |  |  |
| 248 | 6.1.3.2.1 | Receive/inspect/database Analog/Post-reg Flight Boards parts | 5d | 2003-07-01 A | 2003-07-18 | 214FS+10d | 80% | 1d | 2003-07-31 | 2003-08-06 | 5d | 243.6d |  |  | STEREO | IMPACT | SEP Package | Alog/Post-Reg Bd | SEP DPU | LVPS | CIT | SEP Cen |  |
| 249 | 6.1.3.2.2 | Inspect Analog/Post-reg Flight Boards Printed Circuit Boards (coupon & elec. cont.) | 3d | 2003-09-03 | 2003-09-05 | 215FS+14d |  |  | 2003-09-19 | 2003-09-23 | 3d | 80d | 0d |  | STEREO | IMPACT | SEP Package | Alog/Post-Reg Bd | SEP DPU | LVPS | CIT | SEP Cen | Flight Analog/Post-reg Boards Fabricated |
| 250 | 6.1.3.2.3 | Rework/haywire/trim Analog/Post-reg Flight Boards | 2d | 2003-10-15 | 2003-10-16 | 272 |  |  | 2003-10-31 | 2003-11-03 | 2d | 159d | 0d |  | STEREO | IMPACT | SEP Package | Alog/Post-Reg Bd | SEP DPU | LVPS | CIT | SEP Cen |  |
| 251 | 6.1.3.2.4 | Post rework QA inspection | 1d | 2003-10-17 | 2003-10-17 | 250 |  |  | 2003-11-04 | 2003-11-04 | 1d | 159d | 0d |  | STEREO | IMPACT | SEP Package | Alog/Post-Reg Bd | SEP DPU | LVPS | CIT | SEP Cen |  |
| 252 | 6.1.4 | **Assembly** | 118d | 2003-04-01 A | 2003-09-16 |  | 59% | 48.59d | 2003-03-31 | 2003-10-02 | 131d | 80d |  |  | STEREO | IMPACT | SEP Package | Alog/Post-Reg Bd | SEP DPU | LVPS | CIT |  |  |
| 253 | 6.1.4.1 | **ETU** | 10d | 2003-04-01 A | 2003-04-14 A |  | 100% |  | 2003-03-31 | 2003-04-11 | 10d |  |  |  | STEREO | IMPACT | SEP Package | Alog/Post-Reg Bd | SEP DPU | LVPS | CIT |  |  |
| 254 | 6.1.4.1.1 | Assemble Analog/Post-reg EM Printed Circuit Board | 10d | 2003-04-01 A | 2003-04-14 A | 245 | 100% |  | 2003-03-31 | 2003-04-11 | 10d |  |  | start no earlier than 2003-03-31 | STEREO | IMPACT | SEP Package | Alog/Post-Reg Bd | SEP DPU | LVPS | CIT | SEP Cen | EM Analog/Post-reg Board Assembled |
| 255 | 6.1.4.2 | **FM 1 & FM 2** | 7d | 2003-09-08 | 2003-09-16 |  |  |  | 2003-09-24 | 2003-10-02 | 7d | 80d |  |  | STEREO | IMPACT | SEP Package | Alog/Post-Reg Bd | SEP DPU | LVPS | CIT |  |  |
| 256 | 6.1.4.2.1 | Assemble Analog/Post-reg Flight Boards Printed Circuit Boards | 7d | 2003-09-08 | 2003-09-16 | 249 |  |  | 2003-09-24 | 2003-10-02 | 7d | 80d | 0d |  | STEREO | IMPACT | SEP Package | Alog/Post-Reg Bd | SEP DPU | LVPS | CIT | SEP Cen | Flight Analog/Post-reg Board Assembled |
| 257 | 6.1.5 | **Test** | 161d | 2003-04-01 A | 2003-11-18 |  | 48% | 84.08d | 2003-03-05 | 2003-12-05 | 192d | 159d |  |  | STEREO | IMPACT | SEP Package | Alog/Post-Reg Bd | SEP DPU | LVPS | CIT |  |  |
| 258 | 6.1.5.1 | **ETU** | 69.4d | 2003-04-01 A | 2003-07-09 |  | 84% | 10.89d | 2003-03-05 | 2003-07-16 | 94d | 250.6d |  |  | STEREO | IMPACT | SEP Package | Alog/Post-Reg Bd | SEP DPU | LVPS | CIT |  |  |
| 259 | 6.1.5.1.1 | Prepare test spec for Analog/Post-reg EM board | 2d | 2003-04-01 A | 2003-04-02 A | 212 | 100% |  | 2003-03-05 | 2003-03-06 | 2d |  |  | start no earlier than 2003-03-31 | STEREO | IMPACT | SEP Package | Alog/Post-Reg Bd | SEP DPU | LVPS | CIT | SEP Cen |  |
| 260 | 6.1.5.1.2 | Test Analog/Post-reg Board EM board | 30d | 2003-04-15 A | 2003-07-02 | 259, 254 | 95% | 1.5d | 2003-04-14 | 2003-05-23 | 30d | 254d | 0d |  | STEREO | IMPACT | SEP Package | Alog/Post-Reg Bd | SEP DPU | LVPS | CIT | SEP Cen |  |
| 261 | 6.1.5.1.3 | Receive/inspect/doc Analog/Post-reg EM board | 2d | 2003-05-28 A | 2003-07-02 | 260 | 75% | 0.5d | 2003-05-27 | 2003-05-28 | 2d | 254d |  |  | STEREO | IMPACT | SEP Package | Alog/Post-Reg Bd | SEP DPU | LVPS | CIT | SEP Cen | EM Analog/Post-reg Board Tested |
| 262 | 6.1.5.1.4 | Integrate & test Analog/Post-regxEM board with SEP EM | 5d | 2003-05-19 A | 2003-05-23 A | 261 | 100% |  | 2003-06-17 | 2003-06-23 | 5d |  |  | start no earlier than 2003-06-17 | STEREO | IMPACT | SEP Package | Alog/Post-Reg Bd | SEP DPU | LVPS | CIT | SEP Cen |  |
| 263 | 6.1.5.1.5 | Doc Analog/Post-reg EM board test results | 5d | 2003-05-23 A | 2003-07-01 | 262 | 90% | 0.5d | 2003-06-24 | 2003-06-30 | 5d | 254.6d | 0d |  | STEREO | IMPACT | SEP Package | Alog/Post-Reg Bd | SEP DPU | LVPS | CIT | SEP Cen |  |
| 264 | 6.1.5.1.6 | Provide feedback on Analog/Post-Reg EM Board test results to SI designer | 2d | 2003-06-02 A | 2003-07-01 | 263 | 75% | 0.5d | 2003-07-01 | 2003-07-02 | 2d | 254.6d | 0d |  | STEREO | IMPACT | SEP Package | Alog/Post-Reg Bd | SEP DPU | LVPS | CIT | SEP Cen |  |
| 265 | 6.1.5.1.7 | Test Analog/Post-reg Board EM board with SEP EM (final) | 5d | 2003-07-01 | 2003-07-09 | 229 |  |  | 2003-07-10 | 2003-07-16 | 5d | 80d | 0d | start no earlier than 2003-06-30 | STEREO | IMPACT | SEP Package | Alog/Post-Reg Bd | SEP DPU | LVPS | CIT | SEP Cen |  |

| ID | WBS | Task | Type | Duration | Start | Finish | Predecessors | Complete | Remaining | Baseline start | Baseline finish | Baseline duration | Total slack | Free slack | Constraint | Text11 | Text12 | Text13 | Text15 | Text16 | Text17 | Text28 | Text14 | Text23 |
| --- | --- | --- | --- | --- | --- | --- | --- | --- | --- | --- | --- | --- | --- | --- | --- | --- | --- | --- | --- | --- | --- | --- | --- | --- |
| 266 | 6.1.5.2 | **FM 1 & FM 2** |  | 43d | 2003-09-17 | 2003-11-18 |  |  |  | 2003-10-03 | 2003-12-05 | 43d | 80d |  |  | STEREO | IMPACT | SEP Package | Alog/Post-Reg Bd | SEP DPU | LVPS | CIT |  |  |
| 267 | 6.1.5.2.1 | Prepare test spec for Analog/Post-reg Flight Boards |  | 1d | 2003-09-17 | 2003-09-17 | 256 |  |  | 2003-10-03 | 2003-10-03 | 1d | 80d | 0d |  | STEREO | IMPACT | SEP Package | Alog/Post-Reg Bd | SEP DPU | LVPS | CIT | SEP Cen |  |
| 268 | 6.1.5.2.2 | Test Analog/Post-reg Flight Boards |  | 4d | 2003-09-18 | 2003-09-23 | 267 |  |  | 2003-10-07 | 2003-10-10 | 4d | 80d | 0d |  | STEREO | IMPACT | SEP Package | Alog/Post-Reg Bd | SEP DPU | LVPS | CIT | SEP Cen |  |
| 269 | 6.1.5.2.3 | Receive/QA inspect/document Analog/Post-reg Flight Boards |  | 2d | 2003-09-24 | 2003-09-25 | 268 |  |  | 2003-10-13 | 2003-10-14 | 2d | 80d | 0d |  | STEREO | IMPACT | SEP Package | Alog/Post-Reg Bd | SEP DPU | LVPS | CIT | SEP Cen |  |
| 270 | 6.1.5.2.4 | Integrate & test Analog/Post-reg Flight Boards with SEP |  | 5d | 2003-09-26 | 2003-10-02 | 269 |  |  | 2003-10-15 | 2003-10-21 | 5d | 159d | 0d |  | STEREO | IMPACT | SEP Package | Alog/Post-Reg Bd | SEP DPU | LVPS | CIT | SEP Cen |  |
| 271 | 6.1.5.2.5 | Doc Analog/Post-reg Flight Boards test results |  | 5d | 2003-10-03 | 2003-10-10 | 270 |  |  | 2003-10-22 | 2003-10-28 | 5d | 159d | 0d |  | STEREO | IMPACT | SEP Package | Alog/Post-Reg Bd | SEP DPU | LVPS | CIT | SEP Cen |  |
| 272 | 6.1.5.2.6 | Provide feedback on test results to SI designer |  | 2d | 2003-10-13 | 2003-10-14 | 271 |  |  | 2003-10-29 | 2003-10-30 | 2d | 159d | 0d |  | STEREO | IMPACT | SEP Package | Alog/Post-Reg Bd | SEP DPU | LVPS | CIT | SEP Cen |  |
| 273 | 6.1.5.2.7 | Stake/conformal coat Analog/Post-reg Flight Boards |  | 2d | 2003-10-21 | 2003-10-22 | 240 |  |  | 2003-11-06 | 2003-11-07 | 2d | 159d | 0d |  | STEREO | IMPACT | SEP Package | Alog/Post-Reg Bd | SEP DPU | LVPS | CIT | SEP Cen |  |
| 274 | 6.1.5.2.8 | Bakeout Analog/Post-reg Flight Boards |  | 1d | 2003-10-23 | 2003-10-23 | 273 |  |  | 2003-11-11 | 2003-11-11 | 1d | 159d | 0d |  | STEREO | IMPACT | SEP Package | Alog/Post-Reg Bd | SEP DPU | LVPS | CIT | SEP Cen |  |
| 275 | 6.1.5.2.9 | Post-conf coat QA inspection |  | 1d | 2003-10-24 | 2003-10-24 | 274 |  |  | 2003-11-12 | 2003-11-12 | 1d | 159d | 0d |  | STEREO | IMPACT | SEP Package | Alog/Post-Reg Bd | SEP DPU | LVPS | CIT | SEP Cen |  |
| 276 | 6.1.5.2.10 | Test Analog/Post-reg Flight Boards (final) |  | 9d | 2003-10-27 | 2003-11-06 | 275 |  |  | 2003-11-13 | 2003-11-25 | 9d | 159d | 0d |  | STEREO | IMPACT | SEP Package | Alog/Post-Reg Bd | SEP DPU | LVPS | CIT | SEP Cen | Flight Analog/Post-reg Boards Tested |
| 277 | 6.1.5.2.11 | Analog/Post-reg Board Mass properties/photo |  | 1d | 2003-11-07 | 2003-11-07 | 276 |  |  | 2003-11-26 | 2003-11-26 | 1d | 159d | 0d |  | STEREO | IMPACT | SEP Package | Alog/Post-Reg Bd | SEP DPU | LVPS | CIT | SEP Cen |  |
| 278 | 6.1.5.2.12 | Maintain Analog/Post-reg Board hard copy docs (sch, parts, material list) |  | 6d | 2003-11-11 | 2003-11-18 | 277 |  |  | 2003-11-28 | 2003-12-05 | 6d | 159d |  |  | STEREO | IMPACT | SEP Package | Alog/Post-Reg Bd | SEP DPU | LVPS | CIT | SEP Cen |  |
| 279 | 7 | **SEP Solid State Detector Bias Supply** |  | 590d | 2001-11-06 A | 2004-03-16 |  | 58% | 247.91d | 2001-11-06 | 2004-03-16 | 590d | 79d |  |  | STEREO | IMPACT | SEP Package | SSD Bias Card | SEP DPU | LVPS | CIT |  |  |
| 280 | 7.1 | **Design, Manufacture, Assembly and Test** |  | 590d | 2001-11-06 A | 2004-03-16 |  | 58% | 247.91d | 2001-11-06 | 2004-03-16 | 590d | 79d |  |  | STEREO | IMPACT | SEP Package | SSD Bias Card | SEP DPU | LVPS | CIT |  |  |
| 281 | 7.1.1 | **Procurements** |  | 342d | 2002-11-01 A | 2004-03-16 |  | 56% | 151.18d | 2002-11-01 | 2004-03-16 | 342d | 79d |  |  | STEREO | IMPACT | SEP Package | SSD Bias Card | SEP DPU | LVPS | CIT |  |  |
| 282 | 7.1.1.1 | **ETU** |  | 342d | 2002-11-01 A | 2004-03-16 |  | 57% | 147.43d | 2002-11-01 | 2004-03-16 | 342d | 79d |  |  | STEREO | IMPACT | SEP Package | SSD Bias Card | SEP DPU | LVPS | CIT |  |  |
| 283 | 7.1.1.1.1 | Procure Solid State Detector Bias Supply EM parts |  | 14d | 2003-04-01 A | 2003-04-18 A | 294 | 100% |  | 2003-02-03 | 2003-02-21 | 14d |  |  | start no earlier than 2003-03-31 | STEREO | IMPACT | SEP Package | SSD Bias Card | SEP DPU | LVPS | CIT | SEP Cen |  |
| 284 | 7.1.1.1.2 | Solid State Detector Bias Supply from SI |  | 342d | 2002-11-01 A | 2004-03-16 | 294FS-14d | 55% | 153.9d | 2002-11-01 | 2004-03-16 | 342d | 79d |  | start no earlier than 2002-10-31 | STEREO | IMPACT | SEP Package | SSD Bias Card | SEP DPU | LVPS | CIT | SEP Cen |  |
| 285 | 7.1.1.1.3 | Procure Solid State Detector EM Printed Circuit Board |  | 1d | 2003-03-18 A | 2003-03-18 A | 302 | 100% |  | 2003-03-18 | 2003-03-18 | 1d |  |  |  | STEREO | IMPACT | SEP Package | SSD Bias Card | SEP DPU | LVPS | CIT | SEP Cen |  |
| 286 | 7.1.1.2 | **FM 1 & FM 2** |  | 35d | 2003-07-31 | 2003-09-19 |  |  |  | 2003-07-17 | 2003-09-04 | 35d | 42.65d |  |  | STEREO | IMPACT | SEP Package | SSD Bias Card | SEP DPU | LVPS | CIT |  |  |
| 287 | 7.1.1.2.1 | Procure Solid State Detector flight parts |  | 5d | 2003-07-31 | 2003-08-07 | 340 |  |  | 2003-07-17 | 2003-07-23 | 5d | 42.65d | 0d |  | STEREO | IMPACT | SEP Package | SSD Bias Card | SEP DPU | LVPS | CIT | SEP Cen |  |
| 288 | 7.1.1.2.2 | Procure Solid State Detector flight Printed Circuit Boards |  | 2d | 2003-09-17 | 2003-09-19 | 313 |  |  | 2003-09-03 | 2003-09-04 | 2d | 42.65d | 0d |  | STEREO | IMPACT | SEP Package | SSD Bias Card | SEP DPU | LVPS | CIT | SEP Cen |  |
| 289 | 7.1.2 | **Design** |  | 530.35d | 2001-11-06 A | 2003-12-18 |  | 82% | 95.13d | 2001-11-06 | 2003-12-03 | 520d | 138.65d |  |  | STEREO | IMPACT | SEP Package | SSD Bias Card | SEP DPU | LVPS | CIT |  |  |
| 290 | 7.1.2.1 | **ETU** |  | 428.35d | 2001-11-06 A | 2003-07-23 |  | 99% | 1.56d | 2001-11-06 | 2003-07-08 | 418d | 42.65d |  |  | STEREO | IMPACT | SEP Package | SSD Bias Card | SEP DPU | LVPS | CIT |  |  |
| 291 | 1.1.5 | Instrument PDR | milestone | 1d | 2001-09-11 A | 2001-09-11 A |  | 100% |  |  |  |  |  |  | start no earlier than 2001-09-11 | STEREO | IMPACT | SEP Package |  |  |  |  |  |  |
| 292 | 7.1.2.1.2 | Collect & verify SEP Solid State Detector bias requirements |  | 2d | 2001-11-06 A | 2001-11-07 A | 291FS+39d | 100% |  | 2001-11-06 | 2001-11-07 | 2d |  |  |  | STEREO | IMPACT | SEP Package | SSD Bias Card | SEP DPU | LVPS | CIT | SEP Cen |  |
| 293 | 7.1.2.1.3 | Prepare design spec & communicateSolid State Detector Bias Supply to SI |  | 22.5d | 2002-04-24 A | 2002-06-28 A | 292FS+113d | 100% |  | 2002-04-24 | 2002-06-28 | 22.5d |  |  |  | STEREO | IMPACT | SEP Package | SSD Bias Card | SEP DPU | LVPS | CIT | SEP Cen |  |
| 294 | 7.1.2.1.4 | Assess Solid State Detector Bias Supply EM & flight parts needs & availability |  | 25d | 2002-04-26 A | 2002-12-13 A | 293 | 100% |  | 2002-04-26 | 2002-12-13 | 25d |  |  |  | STEREO | IMPACT | SEP Package | SSD Bias Card | SEP DPU | LVPS | CIT | SEP Cen |  |
| 295 | 7.1.2.1.5 | Obtain Solid State Detector Bias Supply samples & footprint, provide to Printed Circuit Board designer |  | 2d | 2002-06-11 A | 2002-06-12 A | 318 | 100% |  | 2002-06-11 | 2002-06-12 | 2d |  |  |  | STEREO | IMPACT | SEP Package | SSD Bias Card | SEP DPU | LVPS | CIT | SEP Cen |  |
| 296 | 7.1.2.1.6 | Transfer Solid State Detector Bias Supply Printed Circuit Board outline from GSGC to SI |  | 1d | 2002-06-11 A | 2002-06-11 A | 283FS-1d | 100% |  | 2002-06-11 | 2002-06-11 | 1d |  |  |  | STEREO | IMPACT | SEP Package | SSD Bias Card | SEP DPU | LVPS | CIT | SEP Cen |  |
| 297 | 7.1.2.1.7 | Design Solid State Detector Bias Supply EM schematics |  | 15d | 2002-05-10 A | 2002-05-31 A | 296 | 100% |  | 2002-05-10 | 2002-05-31 | 15d |  |  |  | STEREO | IMPACT | SEP Package | SSD Bias Card | SEP DPU | LVPS | CIT | SEP Cen |  |
| 298 | 7.1.2.1.8 | Verify Solid State Detector Bias Supply design spec implementation - 1 |  | 3.5d | 2002-08-01 A | 2002-12-03 A | 297 | 100% |  | 2002-08-01 | 2002-12-03 | 3.5d |  |  | start no earlier than 2002-07-31 | STEREO | IMPACT | SEP Package | SSD Bias Card | SEP DPU | LVPS | CIT | SEP Cen |  |
| 299 | 7.1.2.1.9 | Solid State Detector Bias Supply FMA/design review/risk assessment |  | 20d | 2002-12-04 A | 2003-01-02 A | 298 | 100% |  | 2002-12-04 | 2003-01-02 | 20d |  |  | start no earlier than 2002-11-30 | STEREO | IMPACT | SEP Package | SSD Bias Card | SEP DPU | LVPS | CIT | SEP Cen |  |
| 300 | 7.1.2.1.10 | Provide feedback on Solid State Detector Bias Supply design review to SI designer |  | 1d | 2003-01-03 A | 2003-01-03 A | 299 | 100% |  | 2003-01-03 | 2003-01-03 | 1d |  |  | start no earlier than 2002-11-30 | STEREO | IMPACT | SEP Package | SSD Bias Card | SEP DPU | LVPS | CIT | SEP Cen |  |
| 301 | 7.1.2.1.11 | Design Solid State Detector Bias Supply EM Printed Circuit Board layout (final) |  | 15d | 2003-01-21 A | 2003-03-13 A | 300 | 100% |  | 2003-01-21 | 2003-03-13 | 15d |  |  | finish no earlier than 2003-03-13 | STEREO | IMPACT | SEP Package | SSD Bias Card | SEP DPU | LVPS | CIT | SEP Cen |  |
| 302 | 7.1.2.1.12 | Review & approve Solid State Detector Bias Supply EM Printed Circuit Board layout |  | 2d | 2003-03-14 A | 2003-03-17 A | 301 | 100% |  | 2003-03-14 | 2003-03-17 | 2d |  |  | start no earlier than 2002-11-30 | STEREO | IMPACT | SEP Package | SSD Bias Card | SEP DPU | LVPS | CIT | SEP Cen |  |
| 303 | 7.1.2.1.13 | Doc Solid State Detector Bias Supply EM board rework (traveler, ECR) |  | 1d | 2003-07-17 A | 2003-07-23 | 327 | 60% | 0.4d | 2003-07-08 | 2003-07-08 | 1d | 42.65d | 0d |  | STEREO | IMPACT | SEP Package | SSD Bias Card | SEP DPU | LVPS | CIT | SEP Cen |  |

Notes:
- 284: Change logic so that we can take 55% credit. Really money related.
- 294: Assummed this completed on time for rebaselining purposes.

| ID | WBS | Task | Duration | Start | Finish | Predecessors | Complete | Remaining | Baseline start | Baseline finish | Baseline duration | Total slack | Free slack | Constraint | Text11 | Text12 | Text13 | Text15 | Text16 | Text17 | Text28 | Text14 | Text23 |
| --- | --- | --- | --- | --- | --- | --- | --- | --- | --- | --- | --- | --- | --- | --- | --- | --- | --- | --- | --- | --- | --- | --- | --- |
| 304 | 7.1.2.2 | **FM 1 & FM 2** | 109.35d | 2003-07-14 A | 2003-12-18 |  | 23% | 83.67d | 2003-07-02 | 2003-12-03 | 106d | 138.65d |  |  | STEREO | IMPACT | SEP Package | SSD Bias Card | SEP DPU | LVPS | CIT |  |  |
| 305 | 7.1.2.2.1 | Revise/update Solid State Detector Bias Supply Printed Circuit Board schematics for flight | 5d | 2003-07-14 A | 2003-07-23 | 339 | 75% | 1.25d | 2003-07-02 | 2003-07-09 | 5d | 240.4d |  |  | STEREO | IMPACT | SEP Package | SSD Bias Card | SEP DPU | LVPS | CIT | SEP Cen |  |
| 306 | 7.1.2.2.2 | Obtain Solid State Detector Bias Supply samples & footprints, provide to Printed Circuit Board designer | 4d | 2003-07-28 A | 2003-07-31 A | 287SS | 100% |  | 2003-07-17 | 2003-07-22 | 4d |  |  |  | STEREO | IMPACT | SEP Package | SSD Bias Card | SEP DPU | LVPS | CIT | SEP Cen |  |
| 307 | 7.1.2.2.3 | Collect SEP Solid State Detector Bias Supply requirements update | 1d | 2003-08-07 | 2003-08-08 | 287, 94 |  |  | 2003-07-24 | 2003-07-24 | 1d | 42.65d | 0d |  | STEREO | IMPACT | SEP Package | SSD Bias Card | SEP DPU | LVPS | CIT | SEP Cen |  |
| 308 | 7.1.2.2.4 | Update Solid State Detector Bias Supply design spec & communicate it to SI | 1d | 2003-08-08 | 2003-08-11 | 340, 307 |  |  | 2003-07-25 | 2003-07-25 | 1d | 42.65d | 0d |  | STEREO | IMPACT | SEP Package | SSD Bias Card | SEP DPU | LVPS | CIT | SEP Cen |  |
| 309 | 7.1.2.2.5 | Verify Solid State Detector Bias Supply design spec implementation - 3 | 2d | 2003-08-11 | 2003-08-13 | 308 |  |  | 2003-07-28 | 2003-07-29 | 2d | 42.65d | 0d |  | STEREO | IMPACT | SEP Package | SSD Bias Card | SEP DPU | LVPS | CIT | SEP Cen |  |
| 310 | 7.1.2.2.6 | Design flight Solid State Detector Bias Supply schematics (final) | 5d | 2003-08-20 | 2003-08-27 | 309FS+5d |  |  | 2003-08-06 | 2003-08-12 | 5d | 42.65d | 0d |  | STEREO | IMPACT | SEP Package | SSD Bias Card | SEP DPU | LVPS | CIT | SEP Cen |  |
| 311 | 7.1.2.2.7 | Final Solid State Detector Bias Supply design review | 2d | 2003-08-27 | 2003-08-29 | 310 |  |  | 2003-08-13 | 2003-08-14 | 2d | 42.65d | 0d |  | STEREO | IMPACT | SEP Package | SSD Bias Card | SEP DPU | LVPS | CIT | SEP Cen |  |
| 312 | 7.1.2.2.8 | Layout Solid State Detector Bias Supply Printed Circuit Board (final) | 5d | 2003-09-08 | 2003-09-15 | 311FS+5d, 306 |  |  | 2003-08-22 | 2003-08-28 | 5d | 42.65d | 0d |  | STEREO | IMPACT | SEP Package | SSD Bias Card | SEP DPU | LVPS | CIT | SEP Cen |  |
| 313 | 7.1.2.2.9 | Review & approve Solid State Detector Bias Supply flight Printed Circuit Board layout | 2d | 2003-09-15 | 2003-09-17 | 312 |  |  | 2003-08-29 | 2003-09-02 | 2d | 42.65d | 0d |  | STEREO | IMPACT | SEP Package | SSD Bias Card | SEP DPU | LVPS | CIT | SEP Cen |  |
| 314 | 7.1.2.2.10 | Doc Solid State Detector Bias Supply flight board rework (traveler, ECR) | 1d | 2003-12-04 | 2003-12-05 | 331 |  |  | 2003-11-19 | 2003-11-19 | 1d | 127.65d | 0d |  | STEREO | IMPACT | SEP Package | SSD Bias Card | SEP DPU | LVPS | CIT | SEP Cen |  |
| 315 | 7.1.2.2.11 | Final Solid State Detector Bias Supply update of Printed Circuit Board schematics & layout | 5d | 2003-12-11 | 2003-12-18 | 314FS+4d |  |  | 2003-11-26 | 2003-12-03 | 5d | 138.65d |  |  | STEREO | IMPACT | SEP Package | SSD Bias Card | SEP DPU | LVPS | CIT | SEP Cen |  |
| 316 | 7.1.3 | **Fabrication** | 136.35d | 2003-04-02 A | 2003-10-15 |  | 59% | 56.14d | 2003-03-21 | 2003-09-29 | 134d | 182.65d |  |  | STEREO | IMPACT | SEP Package | SSD Bias Card | SEP DPU | LVPS | CIT |  |  |
| 317 | 7.1.3.1 | **ETU** | 19d | 2003-04-02 A | 2003-04-28 A |  | 100% |  | 2003-03-21 | 2003-04-02 | 9d |  |  |  | STEREO | IMPACT | SEP Package | SSD Bias Card | SEP DPU | LVPS | CIT |  |  |
| 318 | 7.1.3.1.1 | Receive/inspect/database Solid State Detector Bias Supply EM parts | 4d | 2003-04-23 A | 2003-04-28 A | 283FS+2d | 100% |  | 2003-03-24 | 2003-03-27 | 4d |  |  | start no earlier than 2003-03-31 | STEREO | IMPACT | SEP Package | SSD Bias Card | SEP DPU | LVPS | CIT | SEP Cen |  |
| 319 | 7.1.3.1.2 | Inspect Solid State Detector Bias Supply EM Printed Circuit Board | 1d | 2003-04-02 A | 2003-04-02 A | 285FS+10d | 100% |  | 2003-04-02 | 2003-04-02 | 1d |  |  |  | STEREO | IMPACT | SEP Package | SSD Bias Card | SEP DPU | LVPS | CIT | SEP Cen | EM Solid State Detector Bias Supply Board Fabricated |
| 320 | 7.1.3.1.3 | Fabricate dummy load box for Solid State Detector Bias Supply EM board test | 5d | 2003-04-03 A | 2003-04-09 A | 334 | 100% |  | 2003-03-21 | 2003-03-27 | 5d |  |  | start no earlier than 2003-03-31 | STEREO | IMPACT | SEP Package | SSD Bias Card | SEP DPU | LVPS | CIT | SEP Cen |  |
| 321 | 7.1.3.2 | **FM 1 & FM 2** | 28d | 2003-09-04 | 2003-10-15 |  |  |  | 2003-08-20 | 2003-09-29 | 28d | 67.65d |  |  | STEREO | IMPACT | SEP Package | SSD Bias Card | SEP DPU | LVPS | CIT |  |  |
| 322 | 7.1.3.2.1 | Receive/inspect/database Solid State Detector Bias Supply flight parts | 4d | 2003-09-04 | 2003-09-10 | 287FS+19d |  |  | 2003-08-20 | 2003-08-25 | 4d | 206.65d |  |  | STEREO | IMPACT | SEP Package | SSD Bias Card | SEP DPU | LVPS | CIT | SEP Cen |  |
| 323 | 7.1.3.2.2 | Inspect Solid State Detector Bias Supply flight Printed Circuit Boards (coupon & elec. cont.) | 3d | 2003-10-10 | 2003-10-15 | 288FS+14d |  |  | 2003-09-25 | 2003-09-29 | 3d | 42.65d | 0d |  | STEREO | IMPACT | SEP Package | SSD Bias Card | SEP DPU | LVPS | CIT | SEP Cen | Flight Solid State Detector Bias Supply Boards Fabricated |
| 324 | 7.1.4 | **Assembly** | 169.35d | 2003-04-03 A | 2003-12-04 |  | 54% | 78.05d | 2003-04-03 | 2003-11-18 | 159d | 127.65d |  |  | STEREO | IMPACT | SEP Package | SSD Bias Card | SEP DPU | LVPS | CIT |  |  |
| 325 | 7.1.4.1 | **ETU** | 76.95d | 2003-04-03 A | 2003-07-22 |  | 95% | 3.55d | 2003-04-03 | 2003-07-07 | 66d | 42.65d |  |  | STEREO | IMPACT | SEP Package | SSD Bias Card | SEP DPU | LVPS | CIT |  |  |
| 326 | 7.1.4.1.1 | Assemble Solid State Detector Bias Supply EM Printed Circuit Board | 10d | 2003-04-03 A | 2003-06-04 A | 319 | 100% |  | 2003-04-03 | 2003-04-16 | 10d |  |  |  | STEREO | IMPACT | SEP Package | SSD Bias Card | SEP DPU | LVPS | CIT | SEP Cen |  |
| 327 | 7.1.4.1.2 | Rework/haywire/trim Solid State Detector Bias Supply EM board | 3d | 2003-07-14 A | 2003-07-22 | 339 | 80% | 0.6d | 2003-07-02 | 2003-07-07 | 3d | 42.65d | 0d |  | STEREO | IMPACT | SEP Package | SSD Bias Card | SEP DPU | LVPS | CIT | SEP Cen |  |

| ID | WBS | Task | Duration | Start | Finish | Predecessors | Complete | Remaining | Baseline start | Baseline finish | Baseline duration | Total slack | Free slack | Constraint | Text11 | Text12 | Text13 | Text15 | Text16 | Text17 | Text28 | Text14 | Text23 |
| --- | --- | --- | --- | --- | --- | --- | --- | --- | --- | --- | --- | --- | --- | --- | --- | --- | --- | --- | --- | --- | --- | --- | --- |
| 328 | 7.1.4.2 | **FM 1 & 2** | 34d | 2003-10-15 | 2003-12-04 |  |  |  | 2003-09-30 | 2003-11-18 | 34d | 42.65d |  |  | STEREO | IMPACT | SEP Package | SSD Bias Card | SEP DPU | LVPS | CIT |  |  |
| 329 | 7.1.4.2.1 | Assemble flight Solid State Detector Bias Supply Printed Circuit Boards | 7d | 2003-10-15 | 2003-10-24 | 323 |  |  | 2003-09-30 | 2003-10-09 | 7d | 42.65d | 0d |  | STEREO | IMPACT | SEP Package | SSD Bias Card | SEP DPU | LVPS | CIT | SEP Cen | Flight Solid State Detector Bias Supply Boards Tested |
| 330 | 7.1.4.2.2 | Rework/haywire/trim Solid State Detector Bias Supply flight board | 2d | 2003-12-01 | 2003-12-03 | 347 |  |  | 2003-11-14 | 2003-11-17 | 2d | 127.65d | 0d |  | STEREO | IMPACT | SEP Package | SSD Bias Card | SEP DPU | LVPS | CIT | SEP Cen |  |
| 331 | 7.1.4.2.3 | Post rework QA inspection of Solid State Detector Bias Supply board | 1d | 2003-12-03 | 2003-12-04 | 330 |  |  | 2003-11-18 | 2003-11-18 | 1d | 127.65d | 0d |  | STEREO | IMPACT | SEP Package | SSD Bias Card | SEP DPU | LVPS | CIT | SEP Cen |  |
| 332 | 7.1.5 | **Test** | 192.35d | 2003-04-01 A | 2004-01-06 |  | 30% | 134.54d | 2003-03-19 | 2003-12-18 | 191d | 127.65d |  |  | STEREO | IMPACT | SEP Package | SSD Bias Card | SEP DPU | LVPS | CIT |  |  |
| 333 | 7.1.5.1 | **ETU** | 85.35d | 2003-04-01 A | 2003-07-31 |  | 58% | 36.18d | 2003-03-19 | 2003-07-16 | 84d | 42.65d |  |  | STEREO | IMPACT | SEP Package | SSD Bias Card | SEP DPU | LVPS | CIT |  |  |
| 334 | 7.1.5.1.1 | Prepare test spec for Solid State Detector Bias Supply EM board | 2d | 2003-04-01 A | 2003-04-02 A | 285 | 100% |  | 2003-03-19 | 2003-03-20 | 2d |  |  | start no earlier than 2003-03-31 | STEREO | IMPACT | SEP Package | SSD Bias Card | SEP DPU | LVPS | CIT | SEP Cen |  |
| 335 | 7.1.5.1.2 | Test Solid State Detector Bias Supply EM board | 27d | 2003-04-17 A | 2003-07-02 | 320, 326 | 95% | 1.35d | 2003-04-17 | 2003-05-23 | 27d | 42.65d | 0d |  | STEREO | IMPACT | SEP Package | SSD Bias Card | SEP DPU | LVPS | CIT | SEP Cen |  |
| 336 | 7.1.5.1.3 | Receive/inspect/doc Solid State Detector Bias Supply EM board | 2d | 2003-07-02 | 2003-07-07 | 335 |  |  | 2003-05-27 | 2003-05-28 | 2d | 42.65d | 0d | start no earlier than 2003-06-30 | STEREO | IMPACT | SEP Package | SSD Bias Card | SEP DPU | LVPS | CIT | SEP Cen | EM Solid State Detector Bias Supply Board Tested |
| 337 | 7.1.5.1.4 | Integrate & test Solid State Detector Bias Supply EM board with SEP EM | 5d | 2003-07-07 | 2003-07-14 | 336 |  |  | 2003-06-17 | 2003-06-23 | 5d | 42.65d | 0d | start no earlier than 2003-06-17 | STEREO | IMPACT | SEP Package | SSD Bias Card | SEP DPU | LVPS | CIT | SEP Cen |  |
| 338 | 7.1.5.1.5 | Doc Solid State Detector Bias Supply EM board test results | 5d | 2003-07-14 | 2003-07-21 | 337 |  |  | 2003-06-24 | 2003-06-30 | 5d | 42.65d | 0d |  | STEREO | IMPACT | SEP Package | SSD Bias Card | SEP DPU | LVPS | CIT | SEP Cen |  |
| 339 | 7.1.5.1.6 | Provide feedback on Solid State Detector Bias Supply test results to SI designer | 1d | 2003-07-21 | 2003-07-22 | 338 |  |  | 2003-07-01 | 2003-07-01 | 1d | 42.65d | 0d |  | STEREO | IMPACT | SEP Package | SSD Bias Card | SEP DPU | LVPS | CIT | SEP Cen |  |
| 340 | 7.1.5.1.7 | Test Solid State Detector Bias Supply EM board with SEP EM (final) | 6d | 2003-07-23 | 2003-07-31 | 303 |  |  | 2003-07-09 | 2003-07-16 | 6d | 42.65d | 0d |  | STEREO | IMPACT | SEP Package | SSD Bias Card | SEP DPU | LVPS | CIT | SEP Cen |  |
| 341 | 7.1.5.2 | **FM 1 & FM 2** | 48d | 2003-10-24 | 2004-01-06 |  |  |  | 2003-10-10 | 2003-12-18 | 48d | 42.65d |  |  | STEREO | IMPACT | SEP Package | SSD Bias Card | SEP DPU | LVPS | CIT |  |  |
| 342 | 7.1.5.2.1 | Prepare test spec for Solid State Detector Bias Supply flight boards | 1d | 2003-10-24 | 2003-10-27 | 329 |  |  | 2003-10-10 | 2003-10-10 | 1d | 42.65d | 0d |  | STEREO | IMPACT | SEP Package | SSD Bias Card | SEP DPU | LVPS | CIT | SEP Cen |  |
| 343 | 7.1.5.2.2 | Test Solid State Detector Bias Supply flight boards | 5d | 2003-10-27 | 2003-11-03 | 342 |  |  | 2003-10-13 | 2003-10-17 | 5d | 42.65d | 0d |  | STEREO | IMPACT | SEP Package | SSD Bias Card | SEP DPU | LVPS | CIT | SEP Cen |  |
| 344 | 7.1.5.2.3 | Receive/QA inspect/document Solid State Detector Bias Supply flight boards | 2d | 2003-11-03 | 2003-11-05 | 343 |  |  | 2003-10-20 | 2003-10-21 | 2d | 42.65d | 0d |  | STEREO | IMPACT | SEP Package | SSD Bias Card | SEP DPU | LVPS | CIT | SEP Cen |  |
| 345 | 7.1.5.2.4 | Integrate & test Solid State Detector Bias Supply flight boards with SEP | 10d | 2003-11-05 | 2003-11-20 | 344 |  |  | 2003-10-22 | 2003-11-04 | 10d | 42.65d | 0d |  | STEREO | IMPACT | SEP Package | SSD Bias Card | SEP DPU | LVPS | CIT | SEP Cen |  |
| 346 | 7.1.5.2.5 | Doc Solid State Detector Bias Supply flight boards test results | 4d | 2003-11-20 | 2003-11-26 | 345 |  |  | 2003-11-05 | 2003-11-11 | 4d | 127.65d | 0d |  | STEREO | IMPACT | SEP Package | SSD Bias Card | SEP DPU | LVPS | CIT | SEP Cen |  |
| 347 | 7.1.5.2.6 | Provide feedback onSolid State Detector Bias Supply test results to SI designer | 2d | 2003-11-26 | 2003-12-01 | 346 |  |  | 2003-11-12 | 2003-11-13 | 2d | 127.65d | 0d |  | STEREO | IMPACT | SEP Package | SSD Bias Card | SEP DPU | LVPS | CIT | SEP Cen |  |
| 348 | 7.1.5.2.7 | Stake/conformal coat Solid State Detector Bias Supply flight boards | 3d | 2003-12-05 | 2003-12-10 | 314 |  |  | 2003-11-20 | 2003-11-24 | 3d | 127.65d | 0d |  | STEREO | IMPACT | SEP Package | SSD Bias Card | SEP DPU | LVPS | CIT | SEP Cen |  |
| 349 | 7.1.5.2.8 | Bakeout Solid State Detector Bias Supply flight boards | 1d | 2003-12-10 | 2003-12-11 | 348 |  |  | 2003-11-25 | 2003-11-25 | 1d | 127.65d | 0d |  | STEREO | IMPACT | SEP Package | SSD Bias Card | SEP DPU | LVPS | CIT | SEP Cen |  |
| 350 | 7.1.5.2.9 | Post-conf coat QA inspection of Solid State Detector Bias Supply boards | 1d | 2003-12-11 | 2003-12-12 | 349 |  |  | 2003-11-26 | 2003-11-26 | 1d | 127.65d | 0d |  | STEREO | IMPACT | SEP Package | SSD Bias Card | SEP DPU | LVPS | CIT | SEP Cen |  |
| 351 | 7.1.5.2.10 | Test Solid State Detector Bias Supply flight boards (final) | 8d | 2003-12-12 | 2003-12-24 | 350 |  |  | 2003-11-28 | 2003-12-09 | 8d | 127.65d | 0d |  | STEREO | IMPACT | SEP Package | SSD Bias Card | SEP DPU | LVPS | CIT | SEP Cen | Flight Solid State Detector Bias Supply Boards Tested |
| 352 | 7.1.5.2.11 | Solid State Detector Bias Supply Mass properties/photo | 1d | 2003-12-24 | 2003-12-26 | 351 |  |  | 2003-12-10 | 2003-12-10 | 1d | 127.65d | 0d |  | STEREO | IMPACT | SEP Package | SSD Bias Card | SEP DPU | LVPS | CIT | SEP Cen |  |
| 353 | 7.1.5.2.12 | Maintain Solid State Detector Bias Supply hard copy docs (sch, parts, material list) | 6d | 2003-12-26 | 2004-01-06 | 352 |  |  | 2003-12-11 | 2003-12-18 | 6d | 127.65d |  |  | STEREO | IMPACT | SEP Package | SSD Bias Card | SEP DPU | LVPS | CIT | SEP Cen |  |

| ID | WBS | Task | Type | Duration | Start | Finish | Predecessors | Complete | Remaining | Baseline start | Baseline finish | Baseline duration | Total slack | Free slack | Constraint | Text11 | Text12 | Text13 | Text28 | Text14 | Text15 | Text16 | Text23 |
| --- | --- | --- | --- | --- | --- | --- | --- | --- | --- | --- | --- | --- | --- | --- | --- | --- | --- | --- | --- | --- | --- | --- | --- |
| 354 | 8 | **Harness** |  | 64.5d | 2003-04-01 A | 2003-07-01 |  | 50% | 32.25d | 2003-02-03 | 2003-02-03 | 1d | 255.5d |  |  | STEREO | IMPACT | SEP Package | CIT |  |  |  |  |
| 355 | 8.1 | **Procurements** |  | 64.5d | 2003-04-01 A | 2003-07-01 |  | 50% | 32.25d | 2003-02-03 | 2003-02-03 | 1d | 255.5d |  |  | STEREO | IMPACT | SEP Package | CIT |  |  |  |  |
| 356 | 8.1.1 | **FM 1 & FM 2** |  | 64.5d | 2003-04-01 A | 2003-07-01 |  | 50% | 32.25d | 2003-02-03 | 2003-02-03 | 1d | 255.5d |  |  | STEREO | IMPACT | SEP Package | CIT |  |  |  |  |
| 357 | 8.1.1.1 | Procure Flight Harnesses |  | 1d | 2003-04-01 A | 2003-07-01 |  | 50% | 0.5d | 2003-02-03 | 2003-02-03 | 1d | 255.5d |  | start no earlier than 2003-03-31 | STEREO | IMPACT | SEP Package | CIT | SEP Cen |  |  |  |
| 358 | 9 | **Flight Software** |  | 459d? | 2002-09-03 A | 2004-06-30 |  | 61% | 181.3d? | 2002-09-03 | 2004-01-07 | 337d? | 4d |  |  | STEREO | IMPACT | SEP Package | CIT |  | Flt S/W | SEP DPU |  |
| 359 | 9.1 | **Design, Manufacture, Assembly and Test** |  | 459d? | 2002-09-03 A | 2004-06-30 |  | 55% | 204.36d? | 2002-09-03 | 2004-01-07 | 337d? | 4d |  |  | STEREO | IMPACT | SEP Package | CIT |  | Flt S/W | SEP DPU |  |
| 360 | 9.1.1 | **Assembly** |  | 370.6d | 2002-09-03 A | 2004-02-26 |  | 55% | 165d | 2002-09-03 | 2004-01-07 | 337d | 92.4d |  |  | STEREO | IMPACT | SEP Package | CIT |  | Flt S/W | SEP DPU |  |
| 361 | 9.1.1.1 | SEP Central Build 1 |  | 112d | 2002-09-03 A | 2003-04-08 A | 80SS | 100% |  | 2002-09-03 | 2003-04-08 | 112d |  |  |  | STEREO | IMPACT | SEP Package |  | SEP Cen |  |  | B1 Flight Software Available |
| 362 | 9.1.1.2 | SEP Central Build 2 |  | 45d | 2003-05-01 A | 2003-07-03 A | 361 | 100% |  | 2003-04-09 | 2003-07-07 | 62d |  |  | start no earlier than 2003-04-30 | STEREO | IMPACT | SEP Package | CIT | SEP Cen | Flt S/W | SEP DPU | B2 Flight Software Available |
| 363 | 9.1.1.3 | SEP Central Build 3 |  | 106d | 2003-07-07 | 2003-12-05 | 362 |  |  | 2003-07-08 | 2003-12-08 | 106d | 127d | 0d |  | STEREO | IMPACT | SEP Package | CIT | SEP Cen | Flt S/W | SEP DPU |  |
| 364 | 9.1.1.4 | Final Flight S/W Build |  | 20d | 2004-01-28 | 2004-02-26 | 363, 78, 26 |  |  | 2003-12-09 | 2004-01-07 | 20d | 92.4d |  |  | STEREO | IMPACT | SEP Package | CIT | SEP Cen | Flt S/W | SEP DPU | Final Flight Software Available |
| 365 | 9.1.2 | **Test** |  | 0d? | 2004-06-30 A | 2004-06-30 A |  | 100% |  | 2003-05-23 | 2003-05-23 | 1d? |  |  |  | STEREO | IMPACT | SEP Package | CIT |  | Flt S/W | SEP DPU |  |
| 366 | 9.1.2.1 | (OBSOLETE) SEP Central/HET & SIT I/F Test | milestone | 0d? | 2004-06-30 A | 2004-06-30 A | 11, 14 | 100% |  | 2003-05-23 | 2003-05-23 | 1d? |  |  | finish no later than 2003-07-31 | STEREO | IMPACT | SEP Package | CIT | SEP Cen | Flt S/W | SEP DPU |  |
| 367 | 9.2 | **GSE** |  | 92d | 2003-02-03 A | 2003-06-12 A |  | 100% |  | 2003-02-03 | 2003-04-30 | 62d |  |  |  | STEREO | IMPACT | SEP Package |  |  |  |  |  |
| 368 | 9.2.1 | **Simulator** |  | 92d | 2003-02-03 A | 2003-06-12 A |  | 100% |  | 2003-02-03 | 2003-04-30 | 62d |  |  |  | STEREO | IMPACT | SEP Package |  |  |  |  |  |
| 369 | 9.2.1.1 | Design & Fabricate SEP Instrument Simulator Unit |  | 36d | 2003-02-03 A | 2003-06-12 A |  | 100% |  | 2003-02-03 | 2003-04-30 | 62d |  |  | start no earlier than 2003-02-01 | STEREO | IMPACT | SEP Package |  |  |  |  |  |

Notes:
- 366: Ths activity occurs in conjunction with a SEP Meeting, But where is it. May need some deliver/receive points here. / 2/5/03-Sent e-mail to Alan Cummings, this may disappear may mod MISC test board to SEP Cen EM board so that this testing can occur anytime. For the time being moved date to 4/30. / 2/6/03-Got no response from Al but Kristin said she thought the test was moved to May so, I'll make that change for now / March 03 Status Upd: CIT to produce 2nd SepCen EM Logic Board for GSFC/UMD.
