# IMPACT SEP

Schedule from MS Project, 2000-09-05 to 2005-09-29, status date 2003-07-31, A marks actual dates.
SEP Package Development With I & T
NASA GSFC
Status Date: 07/31/2003 / Baseline Date: 01/31/2003 R1

## Calendars

- Standard w/ 10 Gov't Holidays: Mon-Fri 08:00-12:00, 13:00-17:00; Sat-Sun off. Exceptions (off unless hours are given): 2000-10-09, 2000-11-13, 2000-11-23, 2000-12-25, 2001-01-01, 2001-01-15, 2001-02-19, 2001-05-28, 2001-07-04, 2001-09-03, 2001-10-08, 2001-11-12, 2001-11-22, 2001-12-25, 2002-01-01, 2002-01-14, 2002-02-18, 2002-05-27, 2002-07-04, 2002-09-02, 2002-10-07, 2002-11-11, 2002-11-28, 2002-12-25, 2003-01-01, 2003-01-13, 2003-02-17, 2003-05-26, 2003-07-04, 2003-09-01, 2003-10-06, 2003-11-10, 2003-11-27, 2003-12-25, 2004-01-01, 2004-01-12, 2004-02-16, 2004-05-31, 2004-07-05, 2004-09-06, 2004-10-11, 2004-11-08, 2004-11-25, 2004-12-24, 2004-12-31, 2005-01-17, 2005-02-21, 2005-05-30, 2005-07-04, 2005-09-05.

## Schedule

| ID | WBS | Task | Type | Duration | Start | Finish | Predecessors | Complete | Remaining | Baseline start | Baseline finish | Baseline duration | Total slack | Free slack | Constraint | Work | Actual work | Text11 | Text12 | Text13 | Text28 | Text14 | Text16 | Text20 | Text22 | Text23 | Text21 |
| --- | --- | --- | --- | --- | --- | --- | --- | --- | --- | --- | --- | --- | --- | --- | --- | --- | --- | --- | --- | --- | --- | --- | --- | --- | --- | --- | --- |
| 1 | 1 | **Management** |  | 548d | 2002-05-21 A | 2004-07-27 |  |  | 548d | 2002-05-21 | 2004-09-15 | 584d | 297d |  |  |  |  | STEREO | IMPACT | SEP Package | CIT |  |  |  |  |  |  |
| 2 | 1.1 | **Milestones** |  | 548d | 2002-05-21 A | 2004-07-27 |  |  | 548d | 2002-05-21 | 2004-09-15 | 584d | 297d |  |  |  |  | STEREO | IMPACT | SEP Package | CIT |  |  |  |  |  |  |
| 3 | 1.1.1 | SEP Software Design Review | milestone | 0d | 2002-05-21 A | 2002-05-21 A |  | 100% |  | 2002-05-21 | 2002-05-21 | 0d |  |  | start no earlier than 2002-07-31 |  |  | STEREO | IMPACT | SEP Package | CIT | SEP Cen | MAG |  |  |  |  |
| 4 | 1.1.2 | **Contingency Blocks** |  | 14.75d | 2004-07-06 | 2004-07-27 |  |  |  | 2004-07-15 | 2004-09-15 | 44d | 1d |  |  |  |  | STEREO | IMPACT | SEP Package | CIT |  |  |  |  |  |  |
| 5 | 1.1.2.1 | SEP Package FM 1 Delivery to APL Contingency | milestone | 0d | 2004-07-06 | 2004-07-06 | 9 |  |  | 2004-07-28 | 2004-09-15 | 35d | 6.75d |  | finish no later than 2004-07-14 |  |  | STEREO | IMPACT | SEP Package | CIT | SEP Cen |  |  |  |  |  |
| 6 | 1.1.2.2 | SEP Package FM 2 Delivery to APL Contingency | milestone | 0d | 2004-07-27 | 2004-07-27 | 11 |  |  | 2004-07-15 | 2004-09-01 | 35d | 1d |  | finish no later than 2004-07-27 |  |  | STEREO | IMPACT | SEP Package | CIT | SEP Cen |  |  |  |  |  |
| 7 | 1.1.3 | **Receivables** |  | 14.75d | 2004-07-06 | 2004-07-27 |  |  |  | 2004-07-07 | 2004-07-28 | 14d | 1d |  |  |  |  | STEREO | IMPACT | SEP Package |  |  |  |  |  |  |  |
| 8 | 1.2.7.13 | SEP Package FM 1 Complete | milestone | 0d | 2004-07-06 | 2004-07-06 |  |  |  |  |  |  | 6.75d | 0d |  |  |  | STEREO | IMPACT | SEP Package |  |  |  |  |  |  |  |
| 9 | 1.1.3.2 | SEP Package FM 1 Ready For Delivery to APL | milestone | 0d | 2004-07-06 | 2004-07-06 | 8 |  |  | 2004-07-14 | 2004-07-14 | 0d | 6.75d | 0d |  |  |  | STEREO | IMPACT | SEP Package |  | SEP Package |  | FM 1 Rdy | SEP Package - FM 1 Ready For Delivery | FM 1 Ready For Delivery to APL |  |
| 10 | 1.2.7.15 | SEP Package FM 2 Complete | milestone | 0d | 2004-07-16 | 2004-07-16 |  |  |  |  |  |  | 7.75d | 6.75d |  |  |  | STEREO | IMPACT | SEP Package |  |  |  |  |  |  |  |
| 11 | 1.1.3.4 | SEP Package FM 2 Ready For Delivery to APL | milestone | 0d | 2004-07-27 | 2004-07-27 | 10 |  |  | 2004-07-27 | 2004-07-27 | 0d | 1d | 0d | start no earlier than 2004-07-27 |  |  | STEREO | IMPACT | SEP Package |  | SEP Package |  | FM 2 Rdy | SEP Package - FM 2 Ready For Delivery | FM 2 Ready for Delivery to APL |  |
| 12 | 1.1.4 | **Deliverables** |  | 311d | 2003-04-30 A | 2004-07-26 |  |  | 311d | 2003-02-01 | 2004-09-15 | 409d | 297d |  |  |  |  | STEREO | IMPACT | SEP Package | CIT |  |  |  |  |  |  |
| 13 | 1.1.4.1 | SEP Package FM 1 Project Contingency | milestone | 0d | 2004-07-14 | 2004-07-14 |  |  |  | 2004-09-01 | 2004-09-01 | 0d | 35d | 0d | start no earlier than 2004-07-14 |  |  | STEREO | IMPACT | SEP Package | CIT | SEP Package |  | Del FM 1 | SEP Package - FM 1 Delivery to APL | FM 1 Project Contingency | FM1 & 2 SEP to APL / Bar 2 IMPACT #1 DEL |
| 14 | 1.1.4.2 | SEP Package FM 2 Project Contingency | milestone | 0d | 2004-07-26 | 2004-07-26 |  |  |  | 2004-09-15 | 2004-09-15 | 0d | 35d | 0d | start no earlier than 2004-07-26 |  |  | STEREO | IMPACT | SEP Package | CIT | SEP Package |  | Del FM 2 | SEP Package - Delivery FM 2 to APL | FM 2 Project Contingency | FM1 & 2 SEP to APLL / Bar 2 IMPACT #2 DEL |
| 15 | 1.1.4.3 | SEP Package FM 1 Contractual Date |  | 1d | 2004-07-14 | 2004-07-14 | 13 |  |  |  |  |  | 35d |  | must finish on 2004-09-01 |  |  | STEREO | IMPACT | SEP Package |  |  |  |  |  |  |  |
| 16 | 1.1.4.4 | SEP Package FM 2 Contractual Date |  | 1d | 2004-07-26 | 2004-07-26 | 14 |  |  |  |  |  | 35d |  | must finish on 2004-09-14 |  |  | STEREO | IMPACT | SEP Package |  |  |  |  |  |  |  |
| 17 | 1.1.4.5 | Deliver SEP to UC-B for EMC Testing | milestone | 0d | 2003-04-30 | 2003-04-30 |  |  |  | 2003-02-01 | 2003-02-01 | 0d | 608d |  | start no earlier than 2003-04-30 |  |  | STEREO | IMPACT | SEP Package | CIT | SEP Cen |  |  |  |  | Ready for EMC Test |
| 18 | 1.1.4.6 | (OBSOLETE)Deliver IDPU ETU to UC-B W/ SEP ETU/IDPU ETU I/F Test Results | milestone | 0d | 2003-04-30 A | 2003-04-30 A |  | 100% |  | 2003-02-01 | 2003-02-01 | 0d |  |  | start no earlier than 2003-04-30 |  |  | STEREO | IMPACT | SEP Package | CIT | IDPU | IDPU |  |  |  |  |
| 19 | 1.1.4.7 | (OBSOLETE)Deliver IDPU FM 1 to UC-B From SEP FM 1/ IDPU FM 1 Testing | milestone | 0d | 2003-04-30 A | 2003-04-30 A |  | 100% |  | 2003-02-01 | 2003-02-01 | 0d |  |  | start no earlier than 2003-04-30 |  |  | STEREO | IMPACT | SEP Package | CIT | IDPU | IDPU |  |  |  |  |
| 20 | 1.2 | **Documentation** |  | 0d | 2003-04-30 A | 2003-04-30 A |  | 100% |  | 2003-02-01 | 2003-02-01 | 0d |  |  |  |  |  | STEREO | IMPACT | SEP Package | CIT |  |  |  |  |  |  |
| 21 | 1.2.1 | Data Transfer Protocol ICD Finished | milestone | 0d | 2003-04-30 A | 2003-04-30 A |  | 100% |  | 2003-02-01 | 2003-02-01 | 0d |  |  | start no earlier than 2003-04-30 |  |  | STEREO | IMPACT | SEP Package | CIT | SEP Cen |  |  |  |  |  |
| 22 | 2 | **Systems Engineering** |  | 1147.76d | 2000-12-01 A | 2005-06-28 |  | 48% | 594.95d | 2000-12-01 | 2005-01-31 | 1043.76d | 65.24d |  |  |  |  | STEREO | IMPACT | SEP Package | CIT |  |  |  |  |  |  |
| 23 | 2.1 | **Documentation** |  | 1147.76d | 2000-12-01 A | 2005-06-28 |  | 48% | 594.95d | 2000-12-01 | 2005-01-31 | 1043.76d | 65.24d |  |  |  |  | STEREO | IMPACT | SEP Package | CIT |  |  |  |  |  |  |
| 24 | 2.1.1 | SEP Development Oversight |  | 963d | 2000-12-01 A | 2005-06-28 |  | 48% | 500.76d | 2000-12-01 | 2005-01-31 | 963d | 65.24d |  | start no earlier than 2000-12-01 |  |  | STEREO | IMPACT | SEP Package | CIT | SEP Cen |  |  |  |  |  |
| 25 | 2.1.2 | Make ICDs |  | 86d | 2001-07-31 A | 2003-08-29 |  | 50% | 43d | 2001-07-31 | 2003-04-03 | 86d | 523d |  | start no earlier than 2001-07-31 |  |  | STEREO | IMPACT | SEP Package | CIT | SEP Cen |  |  |  |  |  |
| 26 | 3 | SEP CEN - Solar Energy Partical Package Central Processor |  | 726d? | 2001-08-15 A | 2004-07-07 |  | 56% | 317.3d? | 2001-08-15 | 2004-04-08 | 664d? | 310d |  |  |  |  | STEREO | IMPACT | SEP Package |  |  |  |  |  |  |  |
| 27 | 4 | LET - Low Energy Telescope |  | 1273d | 2000-09-05 A | 2005-09-29 |  | 47% | 678.44d | 2000-09-05 | 2005-07-01 | 1211d | 0d |  |  |  |  | STEREO | IMPACT | SEP Package | CIT | LET | LET |  |  |  |  |
| 28 | 5 | HET - High Energy Telescope |  | 877.25d | 2000-09-05 A | 2004-03-08 |  | 69% | 275.31d | 2000-09-05 | 2004-01-22 | 847d | 395.75d |  |  |  |  | STEREO | IMPACT | SEP Package |  | HET | HET |  |  |  |  |
| 29 | 6 | SIT - Suprathermal Ion Telescope |  | 872.5d | 2000-09-05 A | 2004-03-01 |  | 57% | 372.26d | 2000-09-05 | 2004-01-15 | 842d | 400.5d |  |  |  |  | STEREO | IMPACT | SEP Package |  | SIT | SIT |  |  |  |  |
| 30 | 7 | SEPT - Solar Electron and Proton Telescope |  | 746d | 2001-01-02 A | 2003-12-19 |  | 84% | 119.98d | 2001-01-02 | 2003-11-17 | 723d | 447d |  |  | 8233.6h | 8205.6h | STEREO | IMPACT | SEP Package |  | SEPT | SEPT |  |  |  |  |
| 31 | 8 | SEP I & T - Solar Energy Partical Package Integration and Test |  | 1144d | 2001-03-01 A | 2005-09-16 |  | 13% | 990.39d | 2001-03-01 | 2005-09-16 | 1144d | 9d |  |  |  |  | STEREO | IMPACT | SEP Package |  |  |  |  |  |  |  |

Notes:
- 5: Changed duration back to 50 per plan 1/9/03
- 6: Changed duration back to 50 per plan 1/9/03
- 17: FNL 5/17/04
- 18: May 2003 Status - Deliver IDPU ETU to UC-B W/ SEP ETU/IDPU ETU I/F Test Results is obsolete it was moved to the SEP I & T schedule and is left over from the 1/31/03 rebaseline.
- 19: May 2003 Status - Deliver IDPU FM 1 to UC-B W/ SEP ETU/IDPU FM 1 I/F Test Results is obsolete it was moved to the SEP I & T schedule and is left over from the 1/31/03 rebaseline.
