# SIT - Suprathermal Ion Telescope

Schedule from MS Project, 2000-09-05 to 2004-03-08, status date 2003-07-31, A marks actual dates.
SIT Instrument Development Schedule
NASA GSFC
Status Date: 07/31/2003 / Baseline Date: 01/31/2003 R1

## Calendars

- Standard w/ 10 Gov't Holidays: Mon-Fri 08:00-12:00, 13:00-17:00; Sat-Sun off. Exceptions (off unless hours are given): 2000-10-09, 2000-11-13, 2000-11-23, 2000-12-25, 2001-01-01, 2001-01-15, 2001-02-19, 2001-05-28, 2001-07-04, 2001-09-03, 2001-10-08, 2001-11-12, 2001-11-22, 2001-12-25, 2002-01-01, 2002-01-14, 2002-02-18, 2002-05-27, 2002-07-04, 2002-09-02, 2002-10-07, 2002-11-11, 2002-11-28, 2002-12-25, 2003-01-01, 2003-01-13, 2003-02-17, 2003-05-26, 2003-07-04, 2003-09-01, 2003-10-06, 2003-11-10, 2003-11-27, 2003-12-25, 2004-01-01, 2004-01-12, 2004-02-16.

## Schedule

| ID | WBS | Task | Type | Duration | Start | Finish | Predecessors | Complete | Remaining | Baseline start | Baseline finish | Baseline duration | Total slack | Free slack | Constraint | Text11 | Text12 | Text13 | Text14 | Text16 | Text28 | Text21 | Text23 | Text19 | Text22 |
| --- | --- | --- | --- | --- | --- | --- | --- | --- | --- | --- | --- | --- | --- | --- | --- | --- | --- | --- | --- | --- | --- | --- | --- | --- | --- |
| 1 | 1 | **Management** |  | 785.5d | 2001-01-11 A | 2004-03-01 |  | 99% | 0d | 2001-01-11 | 2004-01-15 | 755d | 0d |  |  | STEREO | IMPACT | SEP Package | SIT | SIT | UMD |  |  |  |  |
| 2 | 1.1 | **Milestones** |  | 785.5d | 2001-01-11 A | 2004-03-01 |  | 99% | 0d | 2001-01-11 | 2004-01-15 | 755d | 0d |  |  | STEREO | IMPACT | SEP Package | SIT | SIT | UMD |  |  |  |  |
| 3 | 1.1.1 | **Contingency** |  | 157.5d | 2003-07-11 A | 2004-03-01 |  |  | 157.5d | 2003-04-25 | 2004-01-15 | 180d | 0d |  |  | STEREO | IMPACT | SEP Package | SIT | SIT | UMD |  |  |  |  |
| 4 | 1.1.1.1 | SIT FM 1 Delivery to CIT for SEP I & T Contingency | milestone | 0d | 2004-02-18 | 2004-02-18 | 312 |  |  | 2004-01-05 | 2004-01-06 | 2d | 7.5d | 0d |  | STEREO | IMPACT | SEP Package | SIT | SIT | UMD |  |  |  |  |
| 5 | 1.1.1.2 | SIT FM 2 Delivery to CIT for SEP I & T Contingency | milestone | 0d | 2004-03-01 | 2004-03-01 | 317 |  |  | 2004-01-15 | 2004-01-15 | 0d | 0d |  |  | STEREO | IMPACT | SEP Package | SIT | SIT | UMD |  |  |  |  |
| 6 | 1.1.1.3 | SIT S/W Delivery to CIT for SEP Central I/F Testing Contingency | milestone | 0d | 2003-07-11 A | 2003-07-11 A | 303, 359 | 100% |  | 2003-04-25 | 2003-04-25 | 0d |  |  |  | STEREO | IMPACT | SEP Package | SIT | SIT | UMD |  |  |  |  |
| 7 | 1.1.2 | **Receivables** |  | 713.25d | 2001-01-11 A | 2003-11-13 |  | 99% | 0d | 2001-01-11 | 2003-08-12 | 649.6d | 55.25d |  |  | STEREO | IMPACT | SEP Package | SIT | SIT | UMD |  |  |  |  |
| 8 | 1.1.2.1 | Receive SIT On-Board Software SPEC From UMD |  | 1d | 2002-06-14 A | 2002-06-14 A | 44 | 100% |  | 2002-06-14 | 2002-06-14 | 1d |  |  |  | STEREO | IMPACT | SEP Package | SIT | SIT | GSFC |  |  |  |  |
| 9 | 1.1.2.2 | Receive SIT ETU Front-End Logic only ACTEL Pinout Definition From GSFC |  | 1d | 2002-10-25 A | 2002-10-25 A | 38 | 100% |  | 2002-10-25 | 2002-10-25 | 1d |  |  | start no earlier than 2002-09-30 | STEREO | IMPACT | SEP Package | SIT | SIT | UMD |  |  |  |  |
| 10 | 1.1.2.3 | Receive SIT Front-End Logic/MISC ACTEL Pinout Definition From GSFC |  | 1d | 2002-12-20 A | 2002-12-20 A | 39 | 100% |  | 2002-12-20 | 2002-12-20 | 1d |  |  | start no earlier than 2002-11-30 | STEREO | IMPACT | SEP Package | SIT | SIT | GSFC |  |  |  |  |
| 11 | 1.1.2.4 | Receive SIT ETU Front-End Logic only on ACTEL Chip fromm GSFC |  | 1d | 2002-10-22 A | 2002-10-22 A | 40 | 100% |  | 2002-10-22 | 2002-10-22 | 1d |  |  |  | STEREO | IMPACT | SEP Package | SIT | SIT | UMD |  |  |  |  |
| 12 | 1.1.2.5 | Receive SIT Prototype Front-End Logic/MISC ACTEL Chip from GSFC |  | 1d | 2003-01-15 A | 2003-01-15 A | 41 | 100% |  | 2003-01-15 | 2003-01-15 | 1d |  |  | start no earlier than 2002-07-01 | STEREO | IMPACT | SEP Package | SIT | SIT | UMD |  |  |  |  |
| 13 | 1.1.2.6 | Receive SIT Final ACTEL Chip from GSFC | milestone | 0d | 2003-08-01 | 2003-08-01 | 42 |  |  | 2003-03-26 | 2003-03-26 | 0d | 125.9d | 20.4d | start no earlier than 2002-07-01 | STEREO | IMPACT | SEP Package | SIT | SIT | UMD | Flt. VLSI Chip to SIT |  |  |  |
| 14 | 1.1.2.7 | Receive SIT S/W for Functional Testing From GSFC | milestone | 0d | 2003-07-11 A | 2003-07-11 A | 47 | 100% |  | 2003-04-25 | 2003-04-25 | 0d |  |  |  | STEREO | IMPACT | SEP Package | SIT | SIT | UMD |  |  |  |  |
| 15 | 1.1.3.3.9 | Deliver SIT ETU HVPS | milestone | 0d | 2002-10-01 A | 2002-10-01 A |  | 100% |  | 2002-10-01 | 2002-10-01 | 0d |  |  | start no earlier than 2002-09-30 | STEREO | IMPACT | SEP Package | SIT | SIT | UMD |  |  |  |  |
| 16 | 1.1.2.9 | Receive ETU HVPS From UC-B |  | 1d | 2002-10-01 A | 2002-10-01 A | 15 | 100% |  | 2002-10-01 | 2002-10-01 | 1d |  |  | start no earlier than 2002-09-30 | STEREO | IMPACT | SEP Package | SIT | SIT | UMD |  |  |  |  |
| 17 | 1.1.3.4.9 | Deliver SIT FM 1 HVPS | milestone | 0d | 2003-09-09 | 2003-09-09 |  |  |  | 2003-03-31 | 2003-03-31 | 0d | 1.25d | 0d | start no earlier than 2003-06-30 | STEREO | IMPACT | SEP Package | SIT | SIT | UMD |  |  |  |  |
| 18 | 1.1.2.11 | Receive FM 1 HVPS From UC-B | milestone | 0d | 2003-09-09 | 2003-09-09 | 17 |  |  | 2003-03-31 | 2003-03-31 | 0d | 1.25d | 0d | start no earlier than 2003-06-30 | STEREO | IMPACT | SEP Package | SIT | SIT | UMD |  | FM 1 HVPS Available |  |  |
| 19 | 1.1.3.5.9 | Deliver SIT FM 2 HVPS | milestone | 0d | 2003-11-13 | 2003-11-13 |  |  |  | 2003-08-05 | 2003-08-05 | 0d | 1.25d | 0d |  | STEREO | IMPACT | SEP Package | SIT | SIT | UMD |  |  |  |  |
| 20 | 1.1.2.13 | Receive FM 2 HVPS From UC-B | milestone | 0d | 2003-11-13 | 2003-11-13 | 19 |  |  | 2003-08-05 | 2003-08-05 | 0d | 1.25d | 0d |  | STEREO | IMPACT | SEP Package | SIT | SIT | UMD |  | FM 2 HVPS Available |  |  |
| 21 | 1.1.2.14 | Receive SIT FM 1 Telescope From GSFC | milestone | 0d | 2003-09-09 | 2003-09-09 | 48 |  |  | 2003-04-11 | 2003-04-11 | 0d | 9d | 0d |  | STEREO | IMPACT | SEP Package | SIT | SIT | UMD |  | FM 1 Telescope Available | Sandy Shuman |  |
| 22 | 1.1.2.15 | Receive SIT FM 2 Telescope From GSFC | milestone | 0d | 2003-09-09 | 2003-09-09 | 49 |  |  | 2003-04-11 | 2003-04-11 | 0d | 54d | 0d |  | STEREO | IMPACT | SEP Package | SIT | SIT | UMD |  | FM 2 Telescope Available | Sandy Shuman |  |
| 23 | 1.1.2.16 | Receive Proto Digital TOF brd From MPAe | milestone | 0d | 2001-01-11 A | 2001-01-11 A |  | 100% |  | 2001-01-11 | 2001-01-11 | 0d |  |  | start no earlier than 2001-11-01 | STEREO | IMPACT | SEP Package | SIT | SIT | UMD |  |  |  |  |
| 24 | 1.1.2.17 | Receive Proto Analog TOF brd from MPAe | milestone | 0d | 2001-12-17 A | 2001-12-17 A |  | 100% |  | 2001-12-17 | 2001-12-17 | 0d |  |  | start no earlier than 2001-12-17 | STEREO | IMPACT | SEP Package | SIT | SIT | UMD |  |  |  |  |
| 25 | 1.1.2.18 | Receive FM 1 Digital TOF Boards from MPAe | milestone | 0d | 2002-07-31 A | 2002-07-31 A | 50 | 100% |  | 2002-07-31 | 2002-07-31 | 0d |  |  |  | STEREO | IMPACT | SEP Package | SIT | SIT | UMD |  |  |  |  |
| 26 | 1.1.2.19 | Receive FM 1 Analog TOF Boards from MPAe | milestone | 0d | 2002-08-30 A | 2002-08-30 A | 51 | 100% |  | 2002-08-30 | 2002-08-30 | 0d |  |  | start no earlier than 2002-08-01 | STEREO | IMPACT | SEP Package | SIT | SIT | UMD |  |  |  |  |
| 27 | 1.1.2.20 | Receive Remade FM 1 Digital TOF Boards from MPAe | milestone | 0d | 2003-08-18 | 2003-08-18 |  |  |  | 2003-07-21 | 2003-07-21 | 0d | 30.5d | 0d | finish no earlier than 2003-08-18 | STEREO | IMPACT | SEP Package | SIT | SIT | UMD |  | FM 1 Digital TOF Boards Available |  | SIT - FM 1 Digital TOF Boards Available |
| 28 | 1.1.2.21 | Receive Remade FM 1 Analog TOF Boards from MPAe | milestone | 0d | 2003-08-18 | 2003-08-18 |  |  |  | 2003-07-28 | 2003-07-28 | 0d | 30.5d | 0d | finish no earlier than 2003-08-18 | STEREO | IMPACT | SEP Package | SIT | SIT | UMD |  | FM 1 Analog TOF Boards Available |  | SIT - FM 1 Analog TOF Boards Available |
| 29 | 1.1.2.22 | Receive FM 2 Digital TOF Boards from MPAe | milestone | 0d | 2003-08-29 | 2003-08-29 | 52 |  |  | 2003-07-28 | 2003-07-28 | 0d | 52.5d | 0d | start no earlier than 2003-08-18 | STEREO | IMPACT | SEP Package | SIT | SIT | UMD |  | FM 2 Digital TOF Boards Available |  | SIT - FM 2 Digital TOF Boards Available |
| 30 | 1.1.2.23 | Receive FM 2 Analog TOF Boards from MPAe | milestone | 0d | 2003-08-29 | 2003-08-29 | 53 |  |  | 2003-07-28 | 2003-07-28 | 0d | 52.5d | 0d | start no earlier than 2003-08-18 | STEREO | IMPACT | SEP Package | SIT | SIT | UMD |  | FM 2 Analog TOF Boards Available |  | SIT - FM 2 Analog TOF Boards Available |
| 31 | 1.2.7.1 | Deliver SIT EM Back to UMD | milestone | 0d | 2003-08-01 A | 2003-08-01 A |  | 100% |  | 2003-08-05 | 2003-08-05 | 0d |  |  | start no earlier than 2003-06-30 | STEREO | IMPACT | SEP Package | SIT | SIT | UMD |  |  |  |  |
| 32 | 1.1.2.25 | Receive SIT EM Back from CIT | milestone | 0d | 2003-08-04 A | 2003-08-04 A | 31FS+5d | 100% |  | 2003-08-12 | 2003-08-12 | 0d |  |  |  | STEREO | IMPACT | SEP Package | SIT | SIT | UMD |  |  |  |  |

Notes:
- 4: March 03 Status - Dropped contingency from 2 days to 0 days.
- 6: Removed 33 days of duration 1/9/03
- 20: Successor is 259 flat
- 27: The original plan was for 7/21/03. Now expected by mid August. Set new constraint date to mid August 8/18.
- 28: The original plan was for 7/21/03. Now expected by mid August. Set new constraint date to mid August, 8/18.
- 29: The original plan was for 7/21/03. Now expected by mid August. Set new constraint date to mid August.
- 30: The original plan was for 7/21/03. Now expected by mid August. Set new constraint date to mid August.

| ID | WBS | Task | Type | Duration | Start | Finish | Predecessors | Complete | Remaining | Baseline start | Baseline finish | Baseline duration | Total slack | Free slack | Constraint | Text11 | Text12 | Text13 | Text14 | Text16 | Text28 | Text19 | Text20 | Text22 | Text23 | Text21 |
| --- | --- | --- | --- | --- | --- | --- | --- | --- | --- | --- | --- | --- | --- | --- | --- | --- | --- | --- | --- | --- | --- | --- | --- | --- | --- | --- |
| 33 | 1.1.3 | **Deliverables** |  | 593.5d | 2001-10-16 A | 2004-03-01 |  | 99% | 0d | 2001-10-16 | 2004-01-15 | 563d | 0d |  |  | STEREO | IMPACT | SEP Package | SIT | SIT | UMD |  |  |  |  |  |
| 34 | 1.1.3.1 | Deliver SIT ETU/SIT HVPS ETU I/F Test Results to UC-B |  | 1d | 2002-10-16 A | 2002-10-16 A | 307 | 100% |  | 2002-10-16 | 2002-10-16 | 1d |  |  |  | STEREO | IMPACT | SEP Package | SIT | SIT | UMD |  |  |  |  |  |
| 35 | 1.1.3.2 | Deliver SIT ETU / SIT HVPS FM 1 I/F Test Results to UC-B | milestone | 0d | 2003-09-16 | 2003-09-16 | 283 |  |  | 2003-06-09 | 2003-06-09 | 0d | 1.25d | 0d |  | STEREO | IMPACT | SEP Package | SIT | SIT | UMD |  |  |  |  |  |
| 36 | 1.1.2.11 | Receive SIT HVPS FM 1/SIT ETU I/F Test Results from UMD | milestone | 0d | 2003-09-16 | 2003-09-16 | 35 |  |  | 2003-06-09 | 2003-06-09 | 0d | 1.25d | 0d |  | STEREO | IMPACT | SEP Package | SIT | SIT | UMD |  |  |  |  |  |
| 37 | 1.1.2.2 | Receive SIT HVPS ETU/SIT ETU I/F Test Results from UMD | milestone | 0d | 2002-10-17 A | 2002-10-17 A | 34 | 100% |  | 2002-10-17 | 2002-10-17 | 0d |  |  |  | STEREO | IMPACT | SEP Package | SIT | SIT | UMD |  |  |  |  |  |
| 38 | 1.1.3.5 | Deliver SIT ETU Front-End Logic only ACTEL Pinout Defintion to UMD | milestone | 0d | 2002-10-25 A | 2002-10-25 A | 126SS+5d | 100% |  | 2002-10-25 | 2002-10-25 | 0d |  |  | start no earlier than 2002-09-30 | STEREO | IMPACT | SEP Package | SIT | SIT | UMD |  |  |  |  |  |
| 39 | 1.1.3.6 | Deliver SIT Front-End Logic/MISC ACTEL Pinout Defintion to UMD |  | 1d | 2002-12-20 A | 2002-12-20 A | 128SS+5d | 100% |  | 2002-12-20 | 2002-12-20 | 1d |  |  | start no earlier than 2002-11-30 | STEREO | IMPACT | SEP Package | SIT | SIT | UMD |  |  |  |  |  |
| 40 | 1.1.3.7 | Deliver SIT ETU Front-End Logic only ACTEL Chip to UMD | milestone | 0d | 2002-10-22 A | 2002-10-22 A | 127 | 100% |  | 2002-10-22 | 2002-10-22 | 0d |  |  |  | STEREO | IMPACT | SEP Package | SIT | SIT | UMD |  |  |  |  |  |
| 41 | 1.1.3.8 | Deliver SIT Prototype Front-End Logic/MISC ACTEL Chip to UMD |  | 1d | 2003-01-15 A | 2003-01-15 A | 129 | 100% |  | 2003-01-15 | 2003-01-15 | 1d |  |  | start no earlier than 2002-07-01 | STEREO | IMPACT | SEP Package | SIT | SIT | GSFC |  |  |  |  |  |
| 42 | 1.1.3.9 | Deliver SIT Final ACTEL Chip to UMD | milestone | 0d | 2003-08-01 | 2003-08-01 | 132 |  |  | 2003-03-26 | 2003-03-26 | 0d | 125.9d | 0d | start no earlier than 2002-07-01 | STEREO | IMPACT | SEP Package | SIT | SIT | GSFC |  |  |  |  |  |
| 43 | 1.1.3.10 | Deliver SIT Front-End Logic Design to GSFC |  | 1d | 2001-10-16 A | 2001-10-16 A |  | 100% |  | 2001-10-16 | 2001-10-16 | 1d |  |  | start no earlier than 2001-12-20 | STEREO | IMPACT | SEP Package | SIT | SIT | UMD |  |  |  |  |  |
| 44 | 1.1.3.11 | Deliver SIT On-Board Software SPEC to GSFC |  | 1d | 2002-06-14 A | 2002-06-14 A |  | 100% |  | 2002-06-14 | 2002-06-14 | 1d |  |  | start no earlier than 2002-03-01 | STEREO | IMPACT | SEP Package | SIT | SIT | UMD |  |  |  |  |  |
| 45 | 1.1.3.12 | Delivery SIT S/W to CIT for SEP Central I/F Testing | milestone | 0d | 2003-07-23 A | 2003-07-23 A | 6 | 100% |  | 2003-04-25 | 2003-04-25 | 0d |  |  |  | STEREO | IMPACT | SEP Package | SIT | SIT | UMD |  |  |  |  |  |
| 46 | 1.1.5.3.2 | (OBSOLETE) Receive SIT S/W for SEP Central I/F Testing |  | 21d | 2003-05-30 A | 2003-06-30 A | 45 | 100% |  | 2003-04-25 | 2003-04-25 | 0d |  |  |  | STEREO | IMPACT | SEP Package | SIT | SIT | UMD |  |  |  |  |  |
| 47 | 1.1.3.14 | Delivery SIT S/W to UMD for Functional Testing | milestone | 0d | 2003-07-18 A | 2003-07-18 A | 303 | 100% |  | 2003-04-25 | 2003-04-25 | 0d |  |  |  | STEREO | IMPACT | SEP Package | SIT | SIT | UMD |  |  |  |  |  |
| 48 | 1.1.3.15 | Deliver SIT FM 1 Telescope Assembly to UMD | milestone | 0d | 2003-09-09 | 2003-09-09 | 88 |  |  | 2003-04-11 | 2003-04-11 | 0d | 9d | 0d |  | STEREO | IMPACT | SEP Package | SIT | SIT | GSFC | Sandy Shuman |  |  |  |  |
| 49 | 1.1.3.16 | Delivery SIT FM 2 Telescope Assembly to UMD | milestone | 0d | 2003-09-09 | 2003-09-09 | 90 |  |  | 2003-04-11 | 2003-04-11 | 0d | 54d | 0d |  | STEREO | IMPACT | SEP Package | SIT | SIT | GSFC | Sandy Shuman |  |  |  |  |
| 50 | 1.1.3.17 | Delivery FM 1 Digital TOF Boards to UMD | milestone | 0d | 2002-07-31 A | 2002-07-31 A | 169 | 100% |  | 2002-07-31 | 2002-07-31 | 0d |  |  |  | STEREO | IMPACT | SEP Package | SIT | SIT | MP |  |  |  |  |  |
| 51 | 1.1.3.18 | Delivery FM 1 Analog TOF Boards to UMD |  | 1d | 2002-08-30 A | 2002-08-30 A | 170 | 100% |  | 2002-08-30 | 2002-08-30 | 1d |  |  |  | STEREO | IMPACT | SEP Package | SIT | SIT | MP |  |  |  |  |  |
| 52 | 1.1.3.19 | Delivery FM 2 Digital TOF Boards to UMD | milestone | 0d | 2003-08-29 | 2003-08-29 | 169FS+20d |  |  | 2003-02-01 | 2003-02-01 | 0d | 52.5d | 0d | start no earlier than 2003-08-29 | STEREO | IMPACT | SEP Package | SIT | SIT | MP |  |  |  |  |  |
| 53 | 1.1.3.20 | Delivery FM 2 Analog TOF Boards to UMD | milestone | 0d | 2003-08-29 | 2003-08-29 | 170FS+20d |  |  | 2003-02-01 | 2003-02-01 | 0d | 52.5d | 0d | start no earlier than 2003-08-29 | STEREO | IMPACT | SEP Package | SIT | SIT | MP |  |  |  |  |  |
| 54 | 1.1.3.21 | Deliver SIT EM to CIT | milestone | 0d | 2003-07-21 A | 2003-07-21 A |  | 100% |  | 2003-06-13 | 2003-06-13 | 0d |  |  | must start on 2003-06-13 | STEREO | IMPACT | SEP Package | SIT | SIT | UMD |  | SIT EM | SIT - Deliver EM to CIT | Deliver EM for SEP EM I & T |  |
| 55 | 1.2.6.8.2 | Receive SIT EM From UMD For SEP EM I & T | milestone | 0d | 2003-07-23 A | 2003-07-23 A | 54FS+5d | 100% |  | 2003-06-19 | 2003-06-19 | 0d |  |  | start no earlier than 2003-06-30 | STEREO | IMPACT | SEP Package | SIT | SIT | UMD |  |  |  |  |  |
| 56 | 1.1.3.23 | Deliver SIT FM 1 to CIT For SEP I & T | milestone | 0d | 2004-02-18 | 2004-02-18 | 4 |  |  | 2004-01-06 | 2004-01-06 | 0d | 7.5d | 0d |  | STEREO | IMPACT | SEP Package | SIT | SIT | UMD |  | SIT FM 1 | SIT - FM 1 Delivery to CIT For SEP I & T | Deliver FM 1 for SEP I & T | SIT FM 1 & FM 2 to CIT |
| 57 | 1.2.6.8.4 | Receive SIT FM 1 From UMD For SEP FM 1 I & T | milestone | 0d | 2004-02-25 | 2004-02-25 | 56FS+5d |  |  | 2004-01-14 | 2004-01-14 | 0d | 7.5d | 0d |  | STEREO | IMPACT | SEP Package | SIT | SIT | UMD |  |  |  |  |  |
| 58 | 1.1.3.25 | Deliver SIT FM 2 to CIT For SEP I & T | milestone | 0d | 2004-03-01 | 2004-03-01 | 5 |  |  | 2004-01-15 | 2004-01-15 | 0d | 0d |  |  | STEREO | IMPACT | SEP Package | SIT | SIT | UMD |  | SIT FM 2 | SIT - FM 2 Delivery to CIT For SEP I & T | Deliver FM 2 for SEP I & T | SIT FM 1 & FM 2 to CIT |
| 59 | 1.2.6.8.6 | Receive SIT FM 2 From UMD For SEP FM 2 I & T | milestone | 0d | 2004-03-08 | 2004-03-08 | 58FS+5d |  |  | 2004-01-22 | 2004-01-22 | 0d | 17.5d | 0d |  | STEREO | IMPACT | SEP Package | SIT | SIT | UMD |  |  |  |  |  |

Notes:
- 54: Need to setup a return for this and all other ETU/EMs
- 56: FNL of 1/6/04 removed 1/9/03
- 58: FNL of 1/6/04 removed 1/9/03

| ID | WBS | Task | Type | Duration | Start | Finish | Predecessors | Complete | Remaining | Baseline start | Baseline finish | Baseline duration | Total slack | Free slack | Constraint | Text11 | Text12 | Text13 | Text14 | Text16 | Text28 | Text19 | Text23 | Text17 |
| --- | --- | --- | --- | --- | --- | --- | --- | --- | --- | --- | --- | --- | --- | --- | --- | --- | --- | --- | --- | --- | --- | --- | --- | --- |
| 60 | 1.2 | **Documentation** |  | 3d | 2002-02-26 A | 2002-02-28 A |  | 100% |  | 2002-02-26 | 2002-02-28 | 3d |  |  |  | STEREO | IMPACT | SEP Package | SIT | SIT | UMD |  |  |  |
| 61 | 1.2.1 | Update Front-End Logic Requirements |  | 3d | 2002-02-26 A | 2002-02-28 A | 184 | 100% |  | 2002-02-26 | 2002-02-28 | 3d |  |  |  | STEREO | IMPACT | SEP Package | SIT | SIT | UMD |  |  |  |
| 62 | 2 | **Systems Engineering** |  | 622.2d | 2000-09-05 A | 2003-03-03 A |  | 100% |  | 2000-09-05 | 2003-02-03 | 603.2d |  |  |  | STEREO | IMPACT | SEP Package | SIT | SIT | UMD |  |  |  |
| 63 | 2.1 | **Documentation** |  | 387.2d | 2001-08-13 A | 2003-03-03 A |  | 100% |  | 2001-08-13 | 2003-02-03 | 368.2d |  |  |  | STEREO | IMPACT | SEP Package | SIT | SIT | UMD |  |  |  |
| 64 | 2.1.1 | SIT ICD Drawings |  | 60d | 2001-08-13 A | 2001-11-06 A | 67 | 100% |  | 2001-08-13 | 2001-11-06 | 60d |  |  |  | STEREO | IMPACT | SEP Package | SIT | SIT | UMD |  |  |  |
| 65 | 2.1.2 | Generate Energy Board Parts List |  | 2d | 2002-10-01 A | 2003-03-03 A | 188 | 100% |  | 2002-10-01 | 2003-02-03 | 2d |  |  | start no earlier than 2002-09-30 | STEREO | IMPACT | SEP Package | SIT | SIT | UMD |  |  |  |
| 66 | 2.2 | **Studies** |  | 528d | 2000-09-05 A | 2002-10-11 A |  | 100% |  | 2000-09-05 | 2002-10-11 | 528d |  |  |  | STEREO | IMPACT | SEP Package | SIT | SIT | UMD |  |  |  |
| 67 | 2.2.1 | Fields of View Analysis |  | 235d | 2000-09-05 A | 2001-08-10 A |  | 100% |  | 2000-09-05 | 2001-08-10 | 235d |  |  | start no earlier than 2000-09-05 | STEREO | IMPACT | SEP Package | SIT | SIT | UMD |  |  |  |
| 68 | 2.2.2 | Study SIT Front-End Logic Design |  | 8d | 2002-10-01 A | 2002-10-11 A | 43 | 100% |  | 2002-10-01 | 2002-10-11 | 8d |  |  | start no earlier than 2002-09-30 | STEREO | IMPACT | SEP Package | SIT | SIT | UMD |  |  |  |
| 69 | 3 | **Structure** |  | 310.25d | 2002-09-03 A | 2003-11-28 |  | 19% | 250.75d | 2002-09-03 | 2003-08-19 | 241.2d | 62.25d |  |  | STEREO | IMPACT | SEP Package | SIT | SIT | GSFC |  |  |  |
| 70 | 3.1 | **Design, Manufacture, Assembly and Test** |  | 310.25d | 2002-09-03 A | 2003-11-28 |  | 19% | 250.75d | 2002-09-03 | 2003-08-19 | 241.2d | 62.25d |  |  | STEREO | IMPACT | SEP Package | SIT | SIT | GSFC |  |  |  |
| 71 | 3.1.1 | **Design** |  | 217.5d | 2002-09-03 A | 2003-07-16 |  | 67% | 72.5d | 2002-09-03 | 2003-02-18 | 113.5d | 9d |  |  | STEREO | IMPACT | SEP Package | SIT | SIT | GSFC |  |  |  |
| 72 | 3.1.1.1 | Modify SIT Housing Design |  | 21d | 2002-09-03 A | 2003-07-16 | 74SS+11d | 50% | 10.5d | 2002-09-03 | 2003-02-18 | 21d | 9d | 0d | start no earlier than 2002-08-31 | STEREO | IMPACT | SEP Package | SIT | SIT | GSFC | Sandy Shuman |  |  |
| 73 | 3.1.1.2 | Design SIT Electronics Enclosure |  | 21d | 2002-09-03 A | 2003-07-16 | 74 | 75% | 5.25d | 2002-09-03 | 2003-02-18 | 21d | 9d | 0d |  | STEREO | IMPACT | SEP Package | SIT | SIT | GSFC | Sandy Shuman |  |  |
| 74 | 3.1.1.3 | Design SIT Doors |  | 21d | 2002-09-03 A | 2003-07-09 | 64FS+193d | 75% | 5.25d | 2002-09-03 | 2003-02-10 | 21d | 9d | 0d | start no earlier than 2002-08-31 | STEREO | IMPACT | SEP Package | SIT | SIT | GSFC | Sandy Shuman |  |  |
| 75 | 3.1.2 | **Fabrication** |  | 57d | 2003-07-16 | 2003-10-07 |  |  |  | 2003-02-10 | 2003-03-17 | 24.25d | 9d |  |  | STEREO | IMPACT | SEP Package | SIT | SIT | GSFC |  |  |  |
| 76 | 3.1.2.1 | **FM 1 & FM 2** |  | 57d | 2003-07-16 | 2003-10-07 |  |  |  | 2003-02-10 | 2003-03-17 | 24.25d | 9d |  |  | STEREO | IMPACT | SEP Package | SIT | SIT | GSFC |  |  |  |
| 77 | 3.1.2.1.1 | **FM 1** |  | 57d | 2003-07-16 | 2003-10-07 |  |  |  | 2003-02-10 | 2003-03-17 | 24.25d | 9d |  |  | STEREO | IMPACT | SEP Package | SIT | SIT | GSFC |  |  |  |
| 78 | 3.1.2.1.1.1 | Fabricate SIT FM 1 Electronics Enclosure |  | 19d | 2003-07-16 | 2003-08-12 | 79, 73 |  |  | 2003-02-18 | 2003-03-17 | 19d | 9d | 0d | start no earlier than 2003-05-31 | STEREO | IMPACT | SEP Package | SIT | SIT | GSFC | Sandy Shuman | FM 1 Housing Fabricated |  |
| 79 | 1.1.13 | Instrument CDR | milestone | 3d | 2002-11-20 A | 2002-11-22 A |  | 100% |  | 2002-11-20 | 2002-11-22 | 3d |  |  | finish no earlier than 2002-11-22 | STEREO | IMPACT | SEP Package | SIT | SIT | UMD |  |  | SIT |
| 80 | 3.1.2.1.1.3 | Fabricate SIT FM 1 Housing |  | 19d | 2003-07-16 | 2003-08-12 | 79, 72 |  |  | 2003-02-10 | 2003-03-10 | 19d | 9d | 0d | start no earlier than 2003-05-31 | STEREO | IMPACT | SEP Package | SIT | SIT | GSFC | Sandy Shuman | FM 1 Door Fabricated |  |
| 81 | 3.1.2.1.1.4 | Fabricate SIT FM 1 Doors |  | 19d | 2003-09-09 | 2003-10-07 | 79, 88, 74 |  |  | 2003-02-18 | 2003-03-17 | 19d | 98d |  | start no earlier than 2003-05-31 | STEREO | IMPACT | SEP Package | SIT | SIT | GSFC | Sandy Shuman | FM 1 Electronics Enclosure Fabricated |  |
| 82 | 3.1.2.1.2 | **FM 2** |  | 57d | 2003-07-16 | 2003-10-07 |  |  |  | 2003-02-10 | 2003-03-17 | 24.25d | 54d |  |  | STEREO | IMPACT | SEP Package | SIT | SIT | GSFC |  |  |  |
| 83 | 3.1.2.1.2.1 | Fabricate SIT FM 2 Electronics Enclosure |  | 19d | 2003-07-16 | 2003-08-12 | 79, 73 |  |  | 2003-02-18 | 2003-03-17 | 19d | 54d | 0d | start no earlier than 2003-05-31 | STEREO | IMPACT | SEP Package | SIT | SIT | GSFC | Sandy Shuman | FM 2 Housing Fabricated |  |
| 84 | 3.1.2.1.2.2 | Fabricate SIT FM 2 Housing |  | 19d | 2003-07-16 | 2003-08-12 | 79, 72, 83 |  |  | 2003-02-10 | 2003-03-10 | 19d | 54d | 0d | start no earlier than 2003-05-31 | STEREO | IMPACT | SEP Package | SIT | SIT | GSFC | Sandy Shuman | FM 2 Door Fabricated |  |
| 85 | 3.1.2.1.2.3 | Fabricate SIT FM 2 Doors |  | 19d | 2003-09-09 | 2003-10-07 | 79, 90, 74 |  |  | 2003-02-18 | 2003-03-17 | 19d | 98d |  | start no earlier than 2003-05-31 | STEREO | IMPACT | SEP Package | SIT | SIT | GSFC | Sandy Shuman | FM 2 Electronics Enclosure Fabricated |  |

| ID | WBS | Task | Type | Duration | Start | Finish | Predecessors | Complete | Remaining | Baseline start | Baseline finish | Baseline duration | Total slack | Free slack | Constraint | Text11 | Text12 | Text13 | Text14 | Text16 | Text28 | Text19 | Text23 |
| --- | --- | --- | --- | --- | --- | --- | --- | --- | --- | --- | --- | --- | --- | --- | --- | --- | --- | --- | --- | --- | --- | --- | --- |
| 86 | 3.1.3 | **Assembly** |  | 19d | 2003-08-12 | 2003-09-09 |  |  |  | 2003-03-17 | 2003-04-11 | 19d | 9d |  |  | STEREO | IMPACT | SEP Package | SIT | SIT | GSFC |  |  |
| 87 | 3.1.3.1 | **FM 1** |  | 19d | 2003-08-12 | 2003-09-09 |  |  |  | 2003-03-17 | 2003-04-11 | 19d | 9d |  |  | STEREO | IMPACT | SEP Package | SIT | SIT | GSFC |  |  |
| 88 | 3.1.3.1.1 | Assemble SIT FM 1 Telescope |  | 19d | 2003-08-12 | 2003-09-09 | 78, 80 |  |  | 2003-03-17 | 2003-04-11 | 19d | 9d | 0d | start no earlier than 2003-04-30 | STEREO | IMPACT | SEP Package | SIT | SIT | GSFC | Sandy Shuman | FM 1 Telescope Assembled |
| 89 | 3.1.3.2 | **FM 2** |  | 19d | 2003-08-12 | 2003-09-09 |  |  |  | 2003-03-17 | 2003-04-11 | 19d | 54d |  |  | STEREO | IMPACT | SEP Package | SIT | SIT | GSFC |  |  |
| 90 | 3.1.3.2.1 | Assemble SIT FM 2 Telescope |  | 19d | 2003-08-12 | 2003-09-09 | 83, 84 |  |  | 2003-03-17 | 2003-04-11 | 19d | 54d | 0d | start no earlier than 2003-04-30 | STEREO | IMPACT | SEP Package | SIT | SIT | GSFC | Sandy Shuman | FM 2 Telescope Assembled |
| 91 | 3.1.4 | **Test** |  | 47d | 2003-09-19 | 2003-11-28 |  |  |  | 2003-06-12 | 2003-08-19 | 47d | 1.25d |  |  | STEREO | IMPACT | SEP Package | SIT | SIT | GSFC |  |  |
| 92 | 3.1.4.1 | **FM 1** |  | 2d | 2003-09-19 | 2003-09-23 |  |  |  | 2003-06-12 | 2003-06-16 | 2d | 1.25d |  |  | STEREO | IMPACT | SEP Package | SIT | SIT | GSFC |  |  |
| 93 | 3.1.4.1.1 | Inspect/Test Fit SIT FM 1 Housing |  | 2d | 2003-09-19 | 2003-09-23 | 21, 319 |  |  | 2003-06-12 | 2003-06-16 | 2d | 1.25d | 0d |  | STEREO | IMPACT | SEP Package | SIT | SIT | GSFC | Sandy Shuman | FM 1 Telescope Fit Tested |
| 94 | 3.1.4.2 | **FM 2** |  | 2d | 2003-11-25 | 2003-11-28 |  |  |  | 2003-08-15 | 2003-08-19 | 2d | 1.25d |  |  | STEREO | IMPACT | SEP Package | SIT | SIT | GSFC |  |  |
| 95 | 3.1.4.2.1 | Inspect/Test Fit SIT FM 2 Housing |  | 2d | 2003-11-25 | 2003-11-28 | 22, 328 |  |  | 2003-08-15 | 2003-08-19 | 2d | 1.25d | 0d |  | STEREO | IMPACT | SEP Package | SIT | SIT | GSFC | Sandy Shuman | FM 2 Telescope Fit Tested |
| 96 | 4 | **Detectors** |  | 342.25d | 2002-08-01 A | 2003-12-12 |  | 19% | 277.5d | 2002-08-01 | 2003-09-03 | 273.2d | 52.25d |  |  | STEREO | IMPACT | SEP Package | SIT | SIT | UMD |  |  |
| 97 | 4.1 | **Design, Manufacture, Assembly and Test** |  | 342.25d | 2002-08-01 A | 2003-12-12 |  | 19% | 277.5d | 2002-08-01 | 2003-09-03 | 273.2d | 52.25d |  |  | STEREO | IMPACT | SEP Package | SIT | SIT | UMD |  |  |
| 98 | 4.1.1 | **Procurements** |  | 126d | 2002-08-01 A | 2003-02-03 A |  | 100% |  | 2002-08-01 | 2003-02-03 | 126d |  |  |  | STEREO | IMPACT | SEP Package | SIT | SIT | UMD |  |  |
| 99 | 4.1.1.1 | **FM 1 & FM 2** |  | 126d | 2002-08-01 A | 2003-02-03 A |  | 100% |  | 2002-08-01 | 2003-02-03 | 126d |  |  |  | STEREO | IMPACT | SEP Package | SIT | SIT | UMD |  |  |
| 100 | 4.1.1.1.1 | Order Flight Micro Channel Plates |  | 1d | 2002-08-01 A | 2002-08-01 A | 105SF | 100% |  | 2002-08-01 | 2002-08-01 | 1d |  |  | start no earlier than 2002-07-31 | STEREO | IMPACT | SEP Package | SIT | SIT | UMD |  |  |
| 101 | 4.1.1.1.2 | Order Flight Solid State Detectors |  | 1d | 2002-08-01 A | 2002-08-01 A | 106SF | 100% |  | 2002-08-01 | 2002-08-01 | 1d |  |  | start no earlier than 2002-07-31 | STEREO | IMPACT | SEP Package | SIT | SIT | UMD |  |  |
| 102 | 4.1.1.1.3 | Order Flight Foils | milestone | 0d | 2003-02-03 A | 2003-02-03 A | 107SF | 100% |  | 2003-02-03 | 2003-02-03 | 1d |  |  | start no earlier than 2003-03-01 | STEREO | IMPACT | SEP Package | SIT | SIT | UMD |  |  |
| 103 | 4.1.2 | **Fabrication** |  | 12d | 2003-03-14 A | 2003-03-31 A |  | 100% |  | 2003-02-03 | 2003-07-18 | 117d |  |  |  | STEREO | IMPACT | SEP Package | SIT | SIT | UMD |  |  |
| 104 | 4.1.2.1 | **FM 1 & FM 2** |  | 12d | 2003-03-14 A | 2003-03-31 A |  | 100% |  | 2003-02-03 | 2003-07-18 | 117d |  |  |  | STEREO | IMPACT | SEP Package | SIT | SIT | UMD |  |  |
| 105 | 4.1.2.1.1 | Receive & Inspect FM 1 & FM 2 Micro Channel Plates |  | 2d | 2003-03-14 A | 2003-03-17 A | 115SF, 110SF | 100% |  | 2003-02-03 | 2003-07-18 | 117d |  |  | start no earlier than 2003-02-01 | STEREO | IMPACT | SEP Package | SIT | SIT | UMD |  |  |
| 106 | 4.1.2.1.2 | Receive & Inspect FM 1 & FM 2 Solid State Detectors |  | 2d | 2003-03-28 A | 2003-03-31 A | 116SF, 111SF | 100% |  | 2003-02-03 | 2003-07-18 | 117d |  |  | start no earlier than 2003-03-01 | STEREO | IMPACT | SEP Package | SIT | SIT | UMD |  |  |
| 107 | 4.1.2.1.3 | Receive & Inspect FM 1 & FM 2 Foils |  | 2d | 2003-03-28 A | 2003-03-31 A | 117SF, 112SF | 100% |  | 2003-02-03 | 2003-07-18 | 117d |  |  | start no earlier than 2003-03-01 | STEREO | IMPACT | SEP Package | SIT | SIT | UMD |  |  |
| 108 | 4.1.3 | **Test** |  | 187.25d | 2003-03-18 A | 2003-12-12 |  | 14% | 160.5d | 2003-02-28 | 2003-09-03 | 129.7d | 52.25d |  |  | STEREO | IMPACT | SEP Package | SIT | SIT | UMD |  |  |
| 109 | 4.1.3.1 | **FM 1** |  | 142.25d | 2003-03-18 A | 2003-10-08 |  | 14% | 121.93d | 2003-02-28 | 2003-06-30 | 84.7d | 97.25d |  |  | STEREO | IMPACT | SEP Package | SIT | SIT | UMD |  |  |
| 110 | 4.1.3.1.1 | Test FM 1 Micro Channel Plates |  | 20d | 2003-03-18 A | 2003-09-22 | 21SF-10d | 50% | 10d | 2003-02-28 | 2003-03-28 | 20d | 108d |  | start no earlier than 2003-03-01 | STEREO | IMPACT | SEP Package | SIT | SIT | UMD |  |  |
| 111 | 4.1.3.1.2 | Test FM 1 Solid States Detectors |  | 20d | 2003-07-28 | 2003-08-25 | 21SF-10d |  |  | 2003-02-28 | 2003-03-28 | 20d | 127d |  | start no earlier than 2003-05-31 | STEREO | IMPACT | SEP Package | SIT | SIT | UMD |  |  |
| 112 | 4.1.3.1.3 | Test FM 1 Foils |  | 20d | 2003-07-28 | 2003-08-25 | 21SF-10d |  |  | 2003-02-28 | 2003-03-28 | 20d | 127d |  | start no earlier than 2003-05-31 | STEREO | IMPACT | SEP Package | SIT | SIT | UMD |  |  |
| 113 | 4.1.3.1.4 | Alpha Tests FM 1 w/Proto Elect |  | 10d | 2003-09-23 | 2003-10-08 | 93 |  |  | 2003-06-16 | 2003-06-30 | 10d | 97.25d |  |  | STEREO | IMPACT | SEP Package | SIT | SIT | UMD |  |  |

| ID | WBS | Task | Duration | Start | Finish | Predecessors | Complete | Remaining | Baseline start | Baseline finish | Baseline duration | Total slack | Free slack | Constraint | Text11 | Text12 | Text13 | Text14 | Text16 | Text28 |
| --- | --- | --- | --- | --- | --- | --- | --- | --- | --- | --- | --- | --- | --- | --- | --- | --- | --- | --- | --- | --- |
| 114 | 4.1.3.2 | **FM 2** | 187.25d | 2003-03-18 A | 2003-12-12 |  | 14% | 160.5d | 2003-02-28 | 2003-09-03 | 129.7d | 52.25d |  |  | STEREO | IMPACT | SEP Package | SIT | SIT | UMD |
| 115 | 4.1.3.2.1 | Test FM 2 Micro Channel Plates | 20d | 2003-03-18 A | 2003-09-22 | 22SF-10d | 50% | 10d | 2003-02-28 | 2003-03-28 | 20d | 108d |  | start no earlier than 2003-03-01 | STEREO | IMPACT | SEP Package | SIT | SIT | UMD |
| 116 | 4.1.3.2.2 | Test FM 2 Solid States Detectors | 20d | 2003-07-28 | 2003-08-25 | 22SF-10d |  |  | 2003-02-28 | 2003-03-28 | 20d | 127d |  | start no earlier than 2003-05-31 | STEREO | IMPACT | SEP Package | SIT | SIT | UMD |
| 117 | 4.1.3.2.3 | Test FM 2 Foils | 20d | 2003-07-28 | 2003-08-25 | 22SF-10d |  |  | 2003-02-28 | 2003-03-28 | 20d | 127d |  | start no earlier than 2003-05-31 | STEREO | IMPACT | SEP Package | SIT | SIT | UMD |
| 118 | 4.1.3.2.4 | Alpha Tests FM 2 w/Proto Elect | 10d | 2003-11-28 | 2003-12-12 | 95 |  |  | 2003-08-19 | 2003-09-03 | 10d | 52.25d |  |  | STEREO | IMPACT | SEP Package | SIT | SIT | UMD |
| 119 | 5 | **ACTEL** | 231d | 2002-10-15 A | 2003-09-15 |  | 83% | 39.87d | 2002-10-15 | 2003-09-09 | 227d | 112.5d |  |  | STEREO | IMPACT | SEP Package | SIT | SIT | UMD |
| 120 | 5.1 | **Design, Manufacture, Assembly and Test** | 231d | 2002-10-15 A | 2003-09-15 |  | 83% | 39.87d | 2002-10-15 | 2003-09-09 | 227d | 112.5d |  |  | STEREO | IMPACT | SEP Package | SIT | SIT | UMD |
| 121 | 5.1.1 | **Design** | 15d | 2003-07-02 A | 2003-07-24 A |  | 100% |  | 2003-02-26 | 2003-03-18 | 15d |  |  |  | STEREO | IMPACT | SEP Package | SIT | SIT | UMD |
| 122 | 5.1.1.1 | **FM 1 & FM 2** | 15d | 2003-07-02 A | 2003-07-24 A |  | 100% |  | 2003-02-26 | 2003-03-18 | 15d |  |  |  | STEREO | IMPACT | SEP Package | SIT | SIT | UMD |
| 123 | 5.1.1.1.1 | Finalize Design of SIT ACTEL Chip | 15d | 2003-07-02 A | 2003-07-24 A | 135 | 100% |  | 2003-02-26 | 2003-03-18 | 15d |  |  | start no earlier than 2003-05-31 | STEREO | IMPACT | SEP Package | SIT | SIT | GSFC |
| 124 | 5.1.2 | **Fabrication** | 200.6d | 2002-10-15 A | 2003-08-01 |  | 97% | 6.27d | 2002-10-15 | 2003-03-26 | 111d | 125.9d |  |  | STEREO | IMPACT | SEP Package | SIT | SIT | UMD |
| 125 | 5.1.2.1 | **ETU** | 62d | 2002-10-15 A | 2003-01-15 A |  | 100% |  | 2002-10-15 | 2003-01-15 | 62d |  |  |  | STEREO | IMPACT | SEP Package | SIT | SIT | GSFC |
| 126 | 5.1.2.1.1 | Implement SIT Front-End Logic only on ACTEL Chip | 5d | 2002-10-15 A | 2002-10-21 A | 68 | 100% |  | 2002-10-15 | 2002-10-21 | 5d |  |  | start no earlier than 2002-09-30 | STEREO | IMPACT | SEP Package | SIT | SIT | UMD |
| 127 | 5.1.2.1.2 | Burn SIT ETU Front-End Logic only on ACTEL Chip | 1d | 2002-10-22 A | 2002-10-22 A | 126 | 100% |  | 2002-10-22 | 2002-10-22 | 1d |  |  |  | STEREO | IMPACT | SEP Package | SIT | SIT | UMD |
| 128 | 5.1.2.1.3 | Implement SIT Front-End Logic/MISC on ACTEL Chip | 19d | 2002-12-16 A | 2003-01-14 A | 245SS+5d | 100% |  | 2002-12-16 | 2003-01-14 | 19d |  |  | start no earlier than 2002-11-30 | STEREO | IMPACT | SEP Package | SIT | SIT | GSFC |
| 129 | 5.1.2.1.4 | Burn SIT Prototype Front-End Logic/MISC on ACTEL Chip | 1d | 2003-01-15 A | 2003-01-15 A | 128 | 100% |  | 2003-01-15 | 2003-01-15 | 1d |  |  |  | STEREO | IMPACT | SEP Package | SIT | SIT | GSFC |
| 130 | 5.1.2.2 | **FM 1 & FM 2** | 6d | 2003-07-24 A | 2003-08-01 |  | 83% | 1d | 2003-03-19 | 2003-03-26 | 6d | 125.9d |  |  | STEREO | IMPACT | SEP Package | SIT | SIT | UMD |
| 131 | 5.1.2.2.1 | Implement Final SIT ACTEL Chip Design | 5d | 2003-07-24 A | 2003-07-31 A | 123 | 100% |  | 2003-03-19 | 2003-03-25 | 5d |  |  | start no earlier than 2003-05-31 | STEREO | IMPACT | SEP Package | SIT | SIT | GSFC |
| 132 | 5.1.2.2.2 | Burn Final SIT ACTEL Chip | 1d | 2003-07-31 | 2003-08-01 | 131 |  |  | 2003-03-26 | 2003-03-26 | 1d | 125.9d | 0d |  | STEREO | IMPACT | SEP Package | SIT | SIT | GSFC |
| 133 | 5.1.3 | **Test** | 157d | 2003-02-03 A | 2003-09-15 |  | 55% | 70.05d | 2003-02-03 | 2003-09-09 | 153d | 112.5d |  |  | STEREO | IMPACT | SEP Package | SIT | SIT | UMD |
| 134 | 5.1.3.1 | **ETU** | 105.6d | 2003-02-03 A | 2003-07-02 |  | 90% | 10.56d | 2003-02-03 | 2003-02-25 | 16d | 163.9d |  |  | STEREO | IMPACT | SEP Package | SIT | SIT | UMD |
| 135 | 5.1.3.1.1 | Evaluate SIT Prototype ACTEL Chip | 16d | 2003-02-03 A | 2003-07-02 | 12 | 90% | 1.6d | 2003-02-03 | 2003-02-25 | 16d | 163.9d |  | finish no earlier than 2003-05-01 | STEREO | IMPACT | SEP Package | SIT | SIT | UMD |
| 136 | 5.1.3.2 | **FM 1 & FM 2** | 10d | 2003-09-02 | 2003-09-15 |  |  |  | 2003-03-27 | 2003-09-09 | 116d | 112.5d |  |  | STEREO | IMPACT | SEP Package | SIT | SIT | UMD |
| 137 | 5.1.3.2.1 | Evaluate SIT Final ACTEL Chip | 10d | 2003-09-02 | 2003-09-15 | 13 |  |  | 2003-03-27 | 2003-09-09 | 116d | 112.5d |  | start no earlier than 2003-09-02 | STEREO | IMPACT | SEP Package | SIT | SIT | UMD |

| ID | WBS | Task | Type | Duration | Start | Finish | Predecessors | Complete | Remaining | Baseline start | Baseline finish | Baseline duration | Total slack | Constraint | Text11 | Text12 | Text13 | Text14 | Text16 | Text28 |
| --- | --- | --- | --- | --- | --- | --- | --- | --- | --- | --- | --- | --- | --- | --- | --- | --- | --- | --- | --- | --- |
| 138 | 6 | **TOF Board** |  | 426d | 2002-01-04 A | 2003-09-12 |  | 72% | 120.67d | 2002-01-04 | 2003-08-26 | 414d | 113.5d |  | STEREO | IMPACT | SEP Package | SIT | SIT | UMD |
| 139 | 6.1 | **Design, Manufacture, Assembly and Test** |  | 426d | 2002-01-04 A | 2003-09-12 |  | 72% | 120.67d | 2002-01-04 | 2003-08-26 | 414d | 113.5d |  | STEREO | IMPACT | SEP Package | SIT | SIT | UMD |
| 140 | 6.1.1 | **Procurements** |  | 110d | 2003-03-03 A | 2003-08-05 |  | 54% | 50.6d | 2003-02-01 | 2003-04-18 | 54d | 140.5d |  | STEREO | IMPACT | SEP Package | SIT | SIT | UMD |
| 141 | 6.1.1.1 | **FM 1 & FM 2** |  | 110d | 2003-03-03 A | 2003-08-05 |  | 54% | 50.6d | 2003-02-01 | 2003-04-18 | 54d | 140.5d |  | STEREO | IMPACT | SEP Package | SIT | SIT | UMD |
| 142 | 6.1.1.1.1 | PIND Test AD96687 |  | 46d | 2003-06-02 | 2003-08-05 |  |  |  | 2003-02-03 | 2003-04-08 | 46d | 140.5d | start no earlier than 2003-05-31 | STEREO | IMPACT | SEP Package | SIT | SIT | MP |
| 143 | 6.1.1.1.2 | Screening of transistors AT41435 |  | 33d | 2003-03-03 A | 2003-04-16 A |  | 100% |  | 2003-02-03 | 2003-03-20 | 33d |  | start no earlier than 2003-03-01 | STEREO | IMPACT | SEP Package | SIT | SIT | MP |
| 144 | 6.1.1.1.3 | Receive transistors | milestone | 0d | 2003-04-16 A | 2003-04-16 A | 143 | 100% |  | 2003-03-20 | 2003-03-20 | 0d |  | start no earlier than 2003-02-01 | STEREO | IMPACT | SEP Package | SIT | SIT | MP |
| 145 | 6.1.1.1.4 | Qualification test of AT41435 |  | 21d | 2003-04-17 A | 2003-05-15 A | 143 | 100% |  | 2003-03-21 | 2003-04-18 | 21d |  | start no earlier than 2003-02-01 | STEREO | IMPACT | SEP Package | SIT | SIT | MP |
| 146 | 6.1.1.1.5 | Receive coax connectors | milestone | 0d | 2003-04-30 A | 2003-04-30 A |  | 100% |  | 2003-02-01 | 2003-02-01 | 0d |  | start no earlier than 2003-04-30 | STEREO | IMPACT | SEP Package | SIT | SIT | UMD |
| 147 | 6.1.2 | **Design** |  | 125d | 2002-02-19 A | 2002-08-14 A |  | 100% |  | 2002-02-19 | 2002-08-14 | 125d |  |  | STEREO | IMPACT | SEP Package | SIT | SIT | UMD |
| 148 | 6.1.2.1 | **FM 1 & FM 2** |  | 125d | 2002-02-19 A | 2002-08-14 A |  | 100% |  | 2002-02-19 | 2002-08-14 | 125d |  |  | STEREO | IMPACT | SEP Package | SIT | SIT | UMD |
| 149 | 6.1.2.1.1 | Freeze TOF System Design |  | 1d | 2002-02-19 A | 2002-02-19 A |  | 100% |  | 2002-02-19 | 2002-02-19 | 1d |  | start no earlier than 2002-02-19 | STEREO | IMPACT | SEP Package | SIT | SIT | MP |
| 150 | 6.1.2.1.2 | PCB Design Place and Route |  | 10d | 2002-04-17 A | 2002-04-30 A |  | 100% |  | 2002-04-17 | 2002-04-30 | 10d |  | start no earlier than 2002-04-17 | STEREO | IMPACT | SEP Package | SIT | SIT | MP |
| 151 | 6.1.2.1.3 | Finish Analog TOF Printed Circuit Board Layout |  | 10d | 2002-08-01 A | 2002-08-14 A |  | 100% |  | 2002-08-01 | 2002-08-14 | 10d |  | start no earlier than 2002-07-31 | STEREO | IMPACT | SEP Package | SIT | SIT | MP |
| 152 | 6.1.3 | **Fabrication** |  | 83d | 2002-05-01 A | 2002-08-27 A |  | 100% |  | 2002-05-01 | 2002-08-27 | 83d |  |  | STEREO | IMPACT | SEP Package | SIT | SIT | UMD |
| 153 | 6.1.3.1 | **FM 1 & FM 2** |  | 83d | 2002-05-01 A | 2002-08-27 A |  | 100% |  | 2002-05-01 | 2002-08-27 | 83d |  |  | STEREO | IMPACT | SEP Package | SIT | SIT | UMD |
| 154 | 6.1.3.1.1 | Digital TOF Printed Circuit Board manufacturing (brockstedt) |  | 19d | 2002-05-01 A | 2002-05-28 A | 150 | 100% |  | 2002-05-01 | 2002-05-28 | 19d |  |  | STEREO | IMPACT | SEP Package | SIT | SIT | MP |
| 155 | 6.1.3.1.2 | Inspection of Digital TOF Printed Circuit Board from US side |  | 10d | 2002-05-29 A | 2002-06-11 A | 154 | 100% |  | 2002-05-29 | 2002-06-11 | 10d |  |  | STEREO | IMPACT | SEP Package | SIT | SIT | UMD |
| 156 | 6.1.3.1.3 | Analog TOF FM 1 board fabrication |  | 8d | 2002-08-15 A | 2002-08-26 A | 151FS+1d | 100% |  | 2002-08-15 | 2002-08-26 | 8d |  | start no earlier than 2002-07-31 | STEREO | IMPACT | SEP Package | SIT | SIT | MP |
| 157 | 6.1.3.1.4 | Inspection of Printed Circuit Board from US side |  | 1d | 2002-08-27 A | 2002-08-27 A | 156 | 100% |  | 2002-08-27 | 2002-08-27 | 1d |  | start no earlier than 2002-07-01 | STEREO | IMPACT | SEP Package | SIT | SIT | UMD |
| 158 | 6.1.4 | **Assembly** |  | 55d | 2002-06-12 A | 2002-08-28 A |  | 100% |  | 2002-06-12 | 2002-08-28 | 55d |  |  | STEREO | IMPACT | SEP Package | SIT | SIT | UMD |
| 159 | 6.1.4.1 | **FM 1 & FM 2** |  | 55d | 2002-06-12 A | 2002-08-28 A |  | 100% |  | 2002-06-12 | 2002-08-28 | 55d |  |  | STEREO | IMPACT | SEP Package | SIT | SIT | UMD |
| 160 | 6.1.4.1.1 | Digital TOF Board population |  | 10d | 2002-06-12 A | 2002-07-09 A | 155 | 100% |  | 2002-06-12 | 2002-07-09 | 10d |  |  | STEREO | IMPACT | SEP Package | SIT | SIT | MP |
| 161 | 6.1.4.1.2 | FM #1 board passive parts population |  | 1d | 2002-08-28 A | 2002-08-28 A | 157 | 100% |  | 2002-08-28 | 2002-08-28 | 1d |  | start no earlier than 2002-07-01 | STEREO | IMPACT | SEP Package | SIT | SIT | MP |
| 162 | 6.1.4.1.3 | FM #1 board active parts population |  | 1d | 2002-08-28 A | 2002-08-28 A | 161 | 100% |  | 2002-08-28 | 2002-08-28 | 1d |  | start no earlier than 2002-07-01 | STEREO | IMPACT | SEP Package | SIT | SIT | MP |

| ID | WBS | Task | Type | Duration | Start | Finish | Predecessors | Complete | Remaining | Baseline start | Baseline finish | Baseline duration | Total slack | Free slack | Constraint | Text11 | Text12 | Text13 | Text14 | Text16 | Text28 | Text23 |
| --- | --- | --- | --- | --- | --- | --- | --- | --- | --- | --- | --- | --- | --- | --- | --- | --- | --- | --- | --- | --- | --- | --- |
| 163 | 6.1.5 | **Test** |  | 426d | 2002-01-04 A | 2003-09-12 |  | 68% | 137.42d | 2002-01-04 | 2003-08-26 | 414d | 52.5d |  |  | STEREO | IMPACT | SEP Package | SIT | SIT | UMD |  |
| 164 | 6.1.5.1 | **ETU** |  | 13d | 2002-01-04 A | 2002-01-23 A |  | 100% |  | 2002-01-04 | 2002-01-23 | 13d |  |  |  | STEREO | IMPACT | SEP Package | SIT | SIT | UMD |  |
| 165 | 6.1.5.1.1 | Test Proto Digital TOF Board |  | 6d | 2002-01-04 A | 2002-01-11 A | 343, 23 | 100% |  | 2002-01-04 | 2002-01-11 | 6d |  |  |  | STEREO | IMPACT | SEP Package | SIT | SIT | UMD |  |
| 166 | 6.1.5.1.2 | Bench Test Proto TOF System |  | 5d | 2002-01-04 A | 2002-01-10 A | 165, 24 | 100% |  | 2002-01-04 | 2002-01-10 | 5d |  |  |  | STEREO | IMPACT | SEP Package | SIT | SIT | UMD |  |
| 167 | 6.1.5.1.3 | Alpha Test with Proto TOF |  | 9d | 2002-01-10 A | 2002-01-23 A | 166, 344 | 100% |  | 2002-01-10 | 2002-01-23 | 9d |  |  |  | STEREO | IMPACT | SEP Package | SIT | SIT | UMD |  |
| 168 | 6.1.5.2 | **FM 1 & FM 2** |  | 300d | 2002-07-05 A | 2003-09-12 |  | 52% | 142.86d | 2002-07-05 | 2003-08-26 | 288d | 52.5d |  |  | STEREO | IMPACT | SEP Package | SIT | SIT | UMD |  |
| 169 | 6.1.5.2.1 | Digital TOF Functional / Environmental Tests |  | 19d | 2002-07-05 A | 2002-07-31 A | 160 | 100% |  | 2002-07-05 | 2002-07-31 | 19d |  |  | start no earlier than 2002-07-01 | STEREO | IMPACT | SEP Package | SIT | SIT | UMD |  |
| 170 | 6.1.5.2.2 | Analog TOF Electronics Test |  | 3d | 2002-08-28 A | 2002-08-30 A | 162 | 100% |  | 2002-08-28 | 2002-08-30 | 3d |  |  | start no earlier than 2002-07-01 | STEREO | IMPACT | SEP Package | SIT | SIT | UMD |  |
| 171 | 6.1.5.2.3 | **FM 1** |  | 10d | 2003-07-29 | 2003-08-11 |  |  |  | 2003-07-29 | 2003-08-11 | 10d | 30.5d |  |  | STEREO | IMPACT | SEP Package | SIT | SIT | UMD |  |
| 172 | 6.1.5.2.3.1 | FM 1 TOF Boards Functional Test |  | 10d | 2003-07-29 | 2003-08-11 | 25FS+1d, 26FS+1d, 27FS-15d, 28FS-15d |  |  | 2003-07-29 | 2003-08-11 | 10d | 30.5d | 0d | start no earlier than 2002-11-30 | STEREO | IMPACT | SEP Package | SIT | SIT | UMD | FM 1 TOF Boards Functional Test Complete |
| 173 | 6.1.5.2.4 | **FM 2** |  | 10d | 2003-08-29 | 2003-09-12 |  |  |  | 2003-08-13 | 2003-08-26 | 10d | 52.5d |  |  | STEREO | IMPACT | SEP Package | SIT | SIT | UMD |  |
| 174 | 6.1.5.2.4.1 | FM 2 TOF Boards Functional Test |  | 10d | 2003-08-29 | 2003-09-12 | 345, 29, 30 |  |  | 2003-08-13 | 2003-08-26 | 10d | 52.5d | 51.25d | start no earlier than 2002-11-30 | STEREO | IMPACT | SEP Package | SIT | SIT | UMD | FM 2 TOF Boards Functional Test Complete |
| 175 | 7 | **Energy Board** |  | 391d | 2002-01-24 A | 2003-08-12 |  | 76% | 93.93d | 2002-01-24 | 2003-06-03 | 341.2d | 62.5d |  |  | STEREO | IMPACT | SEP Package | SIT | SIT | UMD |  |
| 176 | 7.1 | **Design, Manufacture, Assembly and Test** |  | 391d | 2002-01-24 A | 2003-08-12 |  | 76% | 93.93d | 2002-01-24 | 2003-06-03 | 341.2d | 62.5d |  |  | STEREO | IMPACT | SEP Package | SIT | SIT | UMD |  |
| 177 | 7.1.1 | **Procurements** |  | 10d | 2002-03-14 A | 2002-03-28 A |  | 100% |  | 2002-03-14 | 2002-03-28 | 10d |  |  |  | STEREO | IMPACT | SEP Package | SIT | SIT | UMD |  |
| 178 | 7.1.1.1 | **ETU** |  | 10d | 2002-03-14 A | 2002-03-28 A |  | 100% |  | 2002-03-14 | 2002-03-28 | 10d |  |  |  | STEREO | IMPACT | SEP Package | SIT | SIT | UMD |  |
| 179 | 7.1.1.1.1 | Energy Board Preliminary Parts Order | milestone | 0d | 2002-03-14 A | 2002-03-14 A | 61 | 100% |  | 2002-03-14 | 2002-03-14 | 0d |  |  |  | STEREO | IMPACT | SEP Package | SIT | SIT | UMD |  |
| 180 | 7.1.1.1.2 | Procure Proto Printed Curcuit Board |  | 10d | 2002-03-15 A | 2002-03-28 A | 185 | 100% |  | 2002-03-15 | 2002-03-28 | 10d |  |  |  | STEREO | IMPACT | SEP Package | SIT | SIT | UMD |  |
| 181 | 7.1.2 | **Design** |  | 278d | 2002-01-24 A | 2003-03-04 A |  | 100% |  | 2002-01-24 | 2003-02-04 | 258.2d |  |  |  | STEREO | IMPACT | SEP Package | SIT | SIT | UMD |  |
| 182 | 7.1.2.1 | **ETU** |  | 132d | 2002-01-24 A | 2002-07-31 A |  | 100% |  | 2002-01-24 | 2002-07-31 | 132d |  |  |  | STEREO | IMPACT | SEP Package | SIT | SIT | UMD |  |
| 183 | 7.1.2.1.1 | Decision to Proceed |  | 1d | 2002-01-24 A | 2002-01-24 A |  | 100% |  | 2002-01-24 | 2002-01-24 | 1d |  |  | start no earlier than 2002-01-24 | STEREO | IMPACT | SEP Package | SIT | SIT | UMD |  |
| 184 | 7.1.2.1.2 | Design Energy Board |  | 4d | 2002-02-20 A | 2002-02-25 A | 149, 183 | 100% |  | 2002-02-20 | 2002-02-25 | 4d |  |  |  | STEREO | IMPACT | SEP Package | SIT | SIT | UMD |  |
| 185 | 7.1.2.1.3 | Energy Board Preliminary Layout |  | 10d | 2002-03-01 A | 2002-03-14 A | 61 | 100% |  | 2002-03-01 | 2002-03-14 | 10d |  |  |  | STEREO | IMPACT | SEP Package | SIT | SIT | UMD |  |
| 186 | 7.1.2.1.4 | Energy Board ETU Layout |  | 10d | 2002-07-18 A | 2002-07-31 A | 306 | 100% |  | 2002-07-18 | 2002-07-31 | 10d |  |  |  | STEREO | IMPACT | SEP Package | SIT | SIT | UMD |  |

| ID | WBS | Task | Duration | Start | Finish | Predecessors | Complete | Remaining | Baseline start | Baseline finish | Baseline duration | Total slack | Free slack | Constraint | Text11 | Text12 | Text13 | Text14 | Text16 | Text28 | Text23 |
| --- | --- | --- | --- | --- | --- | --- | --- | --- | --- | --- | --- | --- | --- | --- | --- | --- | --- | --- | --- | --- | --- |
| 187 | 7.1.2.2 | **FM 1 & FM 2** | 128d | 2002-08-27 A | 2003-03-04 A |  | 100% |  | 2002-08-27 | 2003-02-04 | 108.2d |  |  |  | STEREO | IMPACT | SEP Package | SIT | SIT | UMD |  |
| 188 | 7.1.2.2.1 | Freeze Energy Board Design | 1d | 2002-08-27 A | 2002-08-27 A | 209 | 100% |  | 2002-08-27 | 2002-08-27 | 1d |  |  |  | STEREO | IMPACT | SEP Package | SIT | SIT | UMD |  |
| 189 | 7.1.2.2.2 | Energy Board Final Layout | 5.8d | 2002-08-28 A | 2003-03-04 A | 65 | 100% |  | 2002-08-28 | 2003-02-04 | 5d |  |  |  | STEREO | IMPACT | SEP Package | SIT | SIT | UMD |  |
| 190 | 7.1.3 | **Fabrication** | 280.8d | 2002-03-28 A | 2003-05-08 A |  | 100% |  | 2002-03-28 | 2003-03-18 | 243.2d |  |  |  | STEREO | IMPACT | SEP Package | SIT | SIT | UMD |  |
| 191 | 7.1.3.1 | **ETU** | 2d | 2002-03-28 A | 2002-03-29 A |  | 100% |  | 2002-03-28 | 2002-03-29 | 2d |  |  |  | STEREO | IMPACT | SEP Package | SIT | SIT | UMD |  |
| 192 | 7.1.3.1.1 | Receive & Inspect Printed Curcuit Board | 2d | 2002-03-28 A | 2002-03-29 A | 180FS-2d | 100% |  | 2002-03-28 | 2002-03-29 | 2d |  |  | start no earlier than 2002-07-01 | STEREO | IMPACT | SEP Package | SIT | SIT | UMD |  |
| 193 | 7.1.3.2 | **FM 1 & FM 2** | 41.8d | 2003-03-12 A | 2003-05-08 A |  | 100% |  | 2003-02-04 | 2003-03-18 | 29d |  |  |  | STEREO | IMPACT | SEP Package | SIT | SIT | UMD |  |
| 194 | 7.1.3.2.1 | **FM 1** | 40.8d | 2003-03-12 A | 2003-05-08 A |  | 100% |  | 2003-02-04 | 2003-03-18 | 29d |  |  |  | STEREO | IMPACT | SEP Package | SIT | SIT | UMD |  |
| 195 | 7.1.3.2.1.1 | Fabricate FM 1 Energy Board | 29d | 2003-03-12 A | 2003-05-08 A | 189 | 100% |  | 2003-02-04 | 2003-03-18 | 29d |  |  | start no earlier than 2003-03-01 | STEREO | IMPACT | SEP Package | SIT | SIT | UMD | FM 1 Energy Board Fabricated |
| 196 | 7.1.3.2.2 | **FM 2** | 41.8d | 2003-03-12 A | 2003-05-08 A |  | 100% |  | 2003-02-04 | 2003-03-18 | 29d |  |  |  | STEREO | IMPACT | SEP Package | SIT | SIT | UMD |  |
| 197 | 7.1.3.2.2.1 | Fabricate FM 2 Energy Board | 29d | 2003-03-12 A | 2003-05-08 A | 189 | 100% |  | 2003-02-04 | 2003-03-18 | 29d |  |  | start no earlier than 2003-03-01 | STEREO | IMPACT | SEP Package | SIT | SIT | UMD | FM 2 Energy Board Fabricated |
| 198 | 7.1.4 | **Assembly** | 304d | 2002-03-29 A | 2003-06-12 |  | 45% | 165.82d | 2002-03-29 | 2003-04-21 | 266.2d | 89.5d |  |  | STEREO | IMPACT | SEP Package | SIT | SIT | UMD |  |
| 199 | 7.1.4.1 | **ETU** | 119d | 2002-03-29 A | 2002-09-16 A |  | 100% |  | 2002-03-29 | 2002-09-16 | 119d |  |  |  | STEREO | IMPACT | SEP Package | SIT | SIT | UMD |  |
| 200 | 7.1.4.1.1 | Assemble Proto Energy Breadboard | 5d | 2002-03-29 A | 2002-04-04 A | 192, 179 | 100% |  | 2002-03-29 | 2002-04-04 | 5d |  |  |  | STEREO | IMPACT | SEP Package | SIT | SIT | UMD |  |
| 201 | 7.1.4.1.2 | Assemble ETU Energy Board | 10d | 2002-09-03 A | 2002-09-16 A | 186 | 100% |  | 2002-09-03 | 2002-09-16 | 10d |  |  | start no earlier than 2002-08-31 | STEREO | IMPACT | SEP Package | SIT | SIT | UMD |  |
| 202 | 7.1.4.2 | **FM 1** | 9d | 2003-06-02 | 2003-06-12 |  |  |  | 2003-04-08 | 2003-04-21 | 9d | 41.5d |  |  | STEREO | IMPACT | SEP Package | SIT | SIT | UMD |  |
| 203 | 7.1.4.2.1 | Assemble FM 1 Energy Board | 9d | 2003-06-02 | 2003-06-12 | 211 |  |  | 2003-04-08 | 2003-04-21 | 9d | 41.5d | 12d | start no earlier than 2003-05-31 | STEREO | IMPACT | SEP Package | SIT | SIT | UMD | FM 1 Energy Board Assembled |
| 204 | 7.1.4.3 | **FM 2** | 9d | 2003-06-02 | 2003-06-12 |  |  |  | 2003-04-08 | 2003-04-21 | 9d | 89.5d |  |  | STEREO | IMPACT | SEP Package | SIT | SIT | UMD |  |
| 205 | 7.1.4.3.1 | Assemble FM 2 Energy Board | 9d | 2003-06-02 | 2003-06-12 | 211 |  |  | 2003-04-08 | 2003-04-21 | 9d | 89.5d | 27d | start no earlier than 2003-05-31 | STEREO | IMPACT | SEP Package | SIT | SIT | UMD | FM 2 Energy Board Assembled |
| 206 | 7.1.5 | **Test** | 341d | 2002-04-05 A | 2003-08-12 |  | 54% | 157.38d | 2002-04-05 | 2003-06-03 | 291.2d | 62.5d |  |  | STEREO | IMPACT | SEP Package | SIT | SIT | UMD |  |
| 207 | 7.1.5.1 | **ETU** | 124d | 2002-04-05 A | 2002-09-30 A |  | 100% |  | 2002-04-05 | 2002-09-30 | 124d |  |  |  | STEREO | IMPACT | SEP Package | SIT | SIT | UMD |  |
| 208 | 7.1.5.1.1 | Test Energy Breadboard | 10d | 2002-04-05 A | 2002-04-18 A | 200 | 100% |  | 2002-04-05 | 2002-04-18 | 10d |  |  |  | STEREO | IMPACT | SEP Package | SIT | SIT | UMD |  |
| 209 | 7.1.5.1.2 | Test ETU Energy Board | 10d | 2002-09-17 A | 2002-09-30 A | 201 | 100% |  | 2002-09-17 | 2002-09-30 | 10d |  |  |  | STEREO | IMPACT | SEP Package | SIT | SIT | UMD |  |
| 210 | 7.1.5.2 | **FM 1 & FM 2** | 15d | 2003-05-08 A | 2003-05-30 A |  | 100% |  | 2003-03-18 | 2003-04-08 | 15d |  |  |  | STEREO | IMPACT | SEP Package | SIT | SIT | UMD |  |
| 211 | 7.1.5.2.1 | Coupon Testing | 15d | 2003-05-08 A | 2003-05-30 A | 195, 197 | 100% |  | 2003-03-18 | 2003-04-08 | 15d |  |  | start no earlier than 2003-04-30 | STEREO | IMPACT | SEP Package | SIT | SIT | UMD |  |

Notes:
- 201: Check with Peter in regard to 9/30 status, marked this as complete since status report indicates the EngergyBoard/TOF thermal testing was completed
- 209: Check with Peter in regard to 9/30 status, marked this as complete since status report indicates the EngergyBoard/TOF thermal testing was completed

| ID | WBS | Task | Duration | Start | Finish | Predecessors | Complete | Remaining | Baseline start | Baseline finish | Baseline duration | Total slack | Free slack | Constraint | Text11 | Text12 | Text13 | Text14 | Text16 | Text28 | Text23 |
| --- | --- | --- | --- | --- | --- | --- | --- | --- | --- | --- | --- | --- | --- | --- | --- | --- | --- | --- | --- | --- | --- |
| 212 | 7.1.5.3 | **FM 1** | 15d | 2003-07-01 | 2003-07-22 |  |  |  | 2003-04-21 | 2003-05-12 | 15d | 29.5d |  |  | STEREO | IMPACT | SEP Package | SIT | SIT | UMD |  |
| 213 | 7.1.5.3.1 | Bench Test/Calibration | 10d | 2003-07-01 | 2003-07-15 | 203 |  |  | 2003-04-21 | 2003-05-05 | 10d | 29.5d | 0d | start no earlier than 2003-06-30 | STEREO | IMPACT | SEP Package | SIT | SIT | UMD |  |
| 214 | 7.1.5.3.2 | Thermal | 3d | 2003-07-16 | 2003-07-18 | 213 |  |  | 2003-05-05 | 2003-05-08 | 3d | 29.5d | 0d | start no earlier than 2003-06-30 | STEREO | IMPACT | SEP Package | SIT | SIT | UMD |  |
| 215 | 7.1.5.3.3 | Voltage Margin | 2d | 2003-07-21 | 2003-07-22 | 214 |  |  | 2003-05-08 | 2003-05-12 | 2d | 29.5d | 0d |  | STEREO | IMPACT | SEP Package | SIT | SIT | UMD | FM 1 Energy Board Tested |
| 216 | 7.1.5.4 | **FM 2** | 15d | 2003-07-23 | 2003-08-12 |  |  |  | 2003-05-12 | 2003-06-03 | 15d | 62.5d |  |  | STEREO | IMPACT | SEP Package | SIT | SIT | UMD |  |
| 217 | 7.1.5.4.1 | FM 2 Energy Board Functional Test | 15d | 2003-07-23 | 2003-08-12 | 215, 205 |  |  | 2003-05-12 | 2003-06-03 | 15d | 62.5d | 44.5d |  | STEREO | IMPACT | SEP Package | SIT | SIT | UMD | FM 2 Energy Board Tested |
| 218 | 8 | **Logic Board** | 363.5d | 2002-08-28 A | 2004-02-11 |  | 28% | 262.34d | 2002-08-28 | 2003-12-26 | 333d | 12d |  |  | STEREO | IMPACT | SEP Package | SIT | SIT | UMD |  |
| 219 | 8.1 | **Design, Manufacture, Assembly and Test** | 363.5d | 2002-08-28 A | 2004-02-11 |  | 28% | 262.34d | 2002-08-28 | 2003-12-26 | 333d | 12d |  |  | STEREO | IMPACT | SEP Package | SIT | SIT | UMD |  |
| 220 | 8.1.1 | **Design** | 214.5d | 2002-08-28 A | 2003-07-08 |  | 73% | 58.75d | 2002-08-28 | 2003-02-25 | 121.2d | 161d |  |  | STEREO | IMPACT | SEP Package | SIT | SIT | UMD |  |
| 221 | 8.1.1.1 | **ETU** | 45d | 2002-08-28 A | 2002-10-31 A |  | 100% |  | 2002-08-28 | 2002-10-31 | 45d |  |  |  | STEREO | IMPACT | SEP Package | SIT | SIT | UMD |  |
| 222 | 8.1.1.1.1 | ETU Logic Board Layout | 8d | 2002-08-28 A | 2002-10-31 A | 9SS-2d | 100% |  | 2002-08-28 | 2002-10-31 | 8d |  |  | start no earlier than 2002-07-31 | STEREO | IMPACT | SEP Package | SIT | SIT | UMD |  |
| 223 | 8.1.1.2 | **FM 1 & FM 2** | 89.5d | 2003-03-03 A | 2003-07-08 |  | 58% | 37.59d | 2003-02-03 | 2003-02-25 | 15.2d | 161d |  |  | STEREO | IMPACT | SEP Package | SIT | SIT | UMD |  |
| 224 | 8.1.1.2.1 | Design Logic Board | 1d | 2003-03-03 A | 2003-07-01 | 10 | 70% | 0.3d | 2003-02-03 | 2003-02-03 | 1d | 165.2d | 0.5d | start no earlier than 2003-03-01 | STEREO | IMPACT | SEP Package | SIT | SIT | UMD |  |
| 225 | 8.1.1.2.2 | Logic Board Schematic | 5d | 2003-03-05 A | 2003-07-02 | 189, 224SS+1.5d | 70% | 1.5d | 2003-02-04 | 2003-02-11 | 5d | 164d | 0d |  | STEREO | IMPACT | SEP Package | SIT | SIT | UMD |  |
| 226 | 8.1.1.2.3 | Logic Board Layout | 9d | 2003-03-12 A | 2003-07-08 | 225SS+5d | 50% | 4.5d | 2003-02-11 | 2003-02-25 | 9d | 0d |  |  | STEREO | IMPACT | SEP Package | SIT | SIT | UMD |  |
| 227 | 8.1.2 | **Fabrication** | 165.5d | 2002-12-02 A | 2003-07-29 |  | 25% | 124.12d | 2002-12-02 | 2003-04-08 | 87.2d | 0d |  |  | STEREO | IMPACT | SEP Package | SIT | SIT | UMD |  |
| 228 | 8.1.2.1 | **ETU** | 5d | 2002-12-02 A | 2002-12-06 A |  | 100% |  | 2002-12-02 | 2002-12-06 | 5d |  |  |  | STEREO | IMPACT | SEP Package | SIT | SIT | UMD |  |
| 229 | 8.1.2.1.1 | Fabricate ETU Logic Board | 5d | 2002-12-02 A | 2002-12-06 A | 222 | 100% |  | 2002-12-02 | 2002-12-06 | 5d |  |  | start no earlier than 2002-11-30 | STEREO | IMPACT | SEP Package | SIT | SIT | UMD |  |
| 230 | 8.1.2.2 | **FM 1 & FM 2** | 15d | 2003-07-08 | 2003-07-29 |  |  |  | 2003-02-25 | 2003-04-08 | 30d | 0d |  |  | STEREO | IMPACT | SEP Package | SIT | SIT | UMD |  |
| 231 | 8.1.2.2.1 | FM 1 & FM 2 Logic Board Fabrication | 15d | 2003-07-08 | 2003-07-29 | 226 |  |  | 2003-02-25 | 2003-04-08 | 30d | 0d |  | start no earlier than 2003-06-30 | STEREO | IMPACT | SEP Package | SIT | SIT | UMD | Flight Logic Boards Fabricated |
| 232 | 8.1.3 | **Assembly** | 118d | 2003-08-18 | 2004-02-09 |  |  |  | 2003-04-28 | 2003-12-23 | 165.8d | 0d |  |  | STEREO | IMPACT | SEP Package | SIT | SIT | UMD |  |
| 233 | 8.1.3.1 | **FM 1** | 118d | 2003-08-18 | 2004-02-09 |  |  |  | 2003-04-28 | 2003-12-23 | 165.8d | 0d |  |  | STEREO | IMPACT | SEP Package | SIT | SIT | UMD |  |
| 234 | 8.1.3.1.1 | Assemble FM 1 Logic Board with ETU ACTELs | 11d | 2003-08-18 | 2003-09-03 | 247, 12 |  |  | 2003-04-28 | 2003-05-13 | 11d | 0d |  |  | STEREO | IMPACT | SEP Package | SIT | SIT | UMD | FM 1 Logic Board Assembled w/ETU ACTEL |
| 235 | 8.1.3.1.2 | Disassembel FM 1 Logic Board with ETU ACTELs | 1d | 2004-02-03 | 2004-02-04 | 326 |  |  | 2003-12-18 | 2003-12-18 | 1d | 0d |  |  | STEREO | IMPACT | SEP Package | SIT | SIT | UMD |  |
| 236 | 8.1.3.1.3 | Retrofit/Inspect FM 1 Flight ACTELs | 2d | 2004-02-04 | 2004-02-06 | 235, 13 |  |  | 2003-12-19 | 2003-12-22 | 2d | 7.5d | 0d |  | STEREO | IMPACT | SEP Package | SIT | SIT | UMD |  |
| 237 | 8.1.3.1.4 | Reassemble FM 1 Logic Board with Flight ACTELs | 1d | 2004-02-06 | 2004-02-09 | 236 |  |  | 2003-12-23 | 2003-12-23 | 1d | 7.5d | 0d |  | STEREO | IMPACT | SEP Package | SIT | SIT | UMD | FM 1 Logic Board Assembled w/Flight ACTEL |

Notes:
- 222: Changed % complete to 30 from 20, check with Peter
- 231: 2003 May Status - Reduced the Fabrication time from 6 wks to 3 wks.

| ID | WBS | Task | Duration | Start | Finish | Predecessors | Complete | Remaining | Baseline start | Baseline finish | Baseline duration | Total slack | Free slack | Constraint | Text11 | Text12 | Text13 | Text14 | Text16 | Text28 | Text23 |
| --- | --- | --- | --- | --- | --- | --- | --- | --- | --- | --- | --- | --- | --- | --- | --- | --- | --- | --- | --- | --- | --- |
| 238 | 8.1.3.2 | **FM 2** | 118d | 2003-08-18 | 2004-02-09 |  |  |  | 2003-04-28 | 2003-12-23 | 165.8d | 0d |  |  | STEREO | IMPACT | SEP Package | SIT | SIT | UMD |  |
| 239 | 8.1.3.2.1 | Assemble FM 2 Logic Board with ETU ACTELS | 11d | 2003-08-18 | 2003-09-03 | 247, 12 |  |  | 2003-04-28 | 2003-05-13 | 11d | 0d |  |  | STEREO | IMPACT | SEP Package | SIT | SIT | UMD | FM 2 Logic Board Assembled w/ETU ACTEL |
| 240 | 8.1.3.2.2 | Disassemble FM 2 Logic Boards | 1d | 2004-02-03 | 2004-02-04 | 334, 235SS |  |  | 2003-12-18 | 2003-12-18 | 1d | 0d |  |  | STEREO | IMPACT | SEP Package | SIT | SIT | UMD |  |
| 241 | 8.1.3.2.3 | Retrofit/Inspect Flight ACTELS | 2d | 2004-02-04 | 2004-02-06 | 240, 13 |  |  | 2003-12-19 | 2003-12-22 | 2d | 0d |  |  | STEREO | IMPACT | SEP Package | SIT | SIT | UMD |  |
| 242 | 8.1.3.2.4 | Reassemble FM 2 Logic Boards | 1d | 2004-02-06 | 2004-02-09 | 241 |  |  | 2003-12-23 | 2003-12-23 | 1d | 0d |  |  | STEREO | IMPACT | SEP Package | SIT | SIT | UMD | FM 2 Logic Board Assembled w/Flight ACTEL |
| 243 | 8.1.4 | **Test** | 294.5d | 2002-12-09 A | 2004-02-11 |  | 26% | 216.54d | 2002-12-09 | 2003-12-26 | 264d | 12d |  |  | STEREO | IMPACT | SEP Package | SIT | SIT | UMD |  |
| 244 | 8.1.4.1 | **ETU** | 185d | 2002-12-09 A | 2003-09-02 |  | 50% | 92.5d | 2002-12-09 | 2003-03-03 | 57d | 121.5d |  |  | STEREO | IMPACT | SEP Package | SIT | SIT | UMD |  |
| 245 | 8.1.4.1.1 | Test ETU Logic Board | 54d | 2002-12-09 A | 2003-09-02 | 229 | 50% | 27d | 2002-12-09 | 2003-03-03 | 20d | 121.5d |  | start no earlier than 2002-11-30 | STEREO | IMPACT | SEP Package | SIT | SIT | UMD |  |
| 246 | 8.1.4.2 | **FM1 & FM 2** | 134d | 2003-07-29 | 2004-02-11 |  |  |  | 2003-04-08 | 2003-12-26 | 181.8d | 0d |  |  | STEREO | IMPACT | SEP Package | SIT | SIT | UMD |  |
| 247 | 8.1.4.2.1 | Coupon Testing | 14d | 2003-07-29 | 2003-08-18 | 231 |  |  | 2003-04-08 | 2003-04-28 | 14d | 0d |  | start no earlier than 2003-06-30 | STEREO | IMPACT | SEP Package | SIT | SIT | UMD |  |
| 248 | 8.1.4.2.2 | **FM 1** | 109d | 2003-09-03 | 2004-02-11 |  |  |  | 2003-05-13 | 2003-12-26 | 156.8d | 0d |  |  | STEREO | IMPACT | SEP Package | SIT | SIT | UMD |  |
| 249 | 8.1.4.2.2.1 | Functional Test of FM 1 Logic Board w/ETU ACTELS | 15d | 2003-09-03 | 2003-09-24 | 14, 349, 234, 239, 215 |  |  | 2003-05-13 | 2003-06-04 | 15d | 0d |  |  | STEREO | IMPACT | SEP Package | SIT | SIT | UMD | FM 1 Logic Board w/ETU ACTEL Functionally Tested |
| 250 | 8.1.4.2.2.2 | Funtional Test of FM 1 Logic Board w/Flight ACTELS | 2d | 2004-02-09 | 2004-02-11 | 237 |  |  | 2003-12-24 | 2003-12-26 | 2d | 7.5d | 0d |  | STEREO | IMPACT | SEP Package | SIT | SIT | UMD | FM 1 Logic Board w/Flight ACTEL Functionally Tested |
| 251 | 8.1.4.2.3 | **FM 2** | 94d | 2003-09-24 | 2004-02-11 |  |  |  | 2003-06-04 | 2003-12-26 | 141.8d | 0d |  |  | STEREO | IMPACT | SEP Package | SIT | SIT | UMD |  |
| 252 | 8.1.4.2.3.1 | Functional Test of FM 2 Logic Board w/ETU ACTELS | 15d | 2003-09-24 | 2003-10-16 | 249, 217SS |  |  | 2003-06-04 | 2003-06-25 | 15d | 18d | 0d |  | STEREO | IMPACT | SEP Package | SIT | SIT | UMD | FM 2 Logic Board w/ETU ACTEL Functionally Tested |
| 253 | 8.1.4.2.3.2 | Functional Test of FM 2 Logic Board w/Flight ACTELS | 2d | 2004-02-09 | 2004-02-11 | 242 |  |  | 2003-12-24 | 2003-12-26 | 2d | 0d |  |  | STEREO | IMPACT | SEP Package | SIT | SIT | UMD | FM 2 Logic Board w/Flight ACTEL Functionally Tested |
| 254 | 9 | **Mother Board** | 83d | 2003-05-01 A | 2003-08-27 |  | 50% | 41.5d | 2003-02-25 | 2003-06-27 | 87d | 109.5d |  |  | STEREO | IMPACT | SEP Package | SIT | SIT | UMD |  |
| 255 | 9.1 | **Design, Manufacture, Assembly and Test** | 83d | 2003-05-01 A | 2003-08-27 |  | 50% | 41.5d | 2003-02-25 | 2003-06-27 | 87d | 109.5d |  |  | STEREO | IMPACT | SEP Package | SIT | SIT | UMD |  |
| 256 | 9.1.1 | **Design** | 69d | 2003-05-01 A | 2003-08-07 |  | 80% | 13.8d | 2003-02-25 | 2003-03-11 | 10d | 109.5d |  |  | STEREO | IMPACT | SEP Package | SIT | SIT | UMD |  |
| 257 | 9.1.1.1 | **FM 1 & FM 2** | 69d | 2003-05-01 A | 2003-08-07 |  | 80% | 13.8d | 2003-02-25 | 2003-03-11 | 10d | 109.5d |  |  | STEREO | IMPACT | SEP Package | SIT | SIT | UMD |  |
| 258 | 9.1.1.1.1 | Mother Board Layout | 8d | 2003-05-01 A | 2003-05-12 A | 226SS+5d | 100% |  | 2003-02-25 | 2003-03-11 | 10d |  |  | start no earlier than 2003-04-30 | STEREO | IMPACT | SEP Package | SIT | SIT | UMD |  |
| 259 | 9.1.1.1.2 | Finalize Mother Board Layout (if necessary) | 2d | 2003-08-06 | 2003-08-07 | 273 |  |  | 2003-08-06 | 2003-08-07 | 2d | 109.5d | 0d |  | STEREO | IMPACT | SEP Package | SIT | SIT | UMD |  |
| 260 | 9.1.2 | **Fabrication** | 70d | 2003-05-20 A | 2003-08-27 |  | 36% | 44.55d | 2003-03-11 | 2003-04-21 | 29d | 109.5d |  |  | STEREO | IMPACT | SEP Package | SIT | SIT | UMD |  |
| 261 | 9.1.2.1 | **FM 1 & FM 2** | 70d | 2003-05-20 A | 2003-08-27 |  | 36% | 44.55d | 2003-03-11 | 2003-04-21 | 29d | 109.5d |  |  | STEREO | IMPACT | SEP Package | SIT | SIT | UMD |  |
| 262 | 9.1.2.1.1 | Fabricate FM 1 & FM 2 Mother Boards | 8d | 2003-05-20 A | 2003-05-30 A | 258 | 100% |  | 2003-03-11 | 2003-04-21 | 29d |  |  |  | STEREO | IMPACT | SEP Package | SIT | SIT | UMD | Flight Mother Boards Fabricated |
| 263 | 9.1.2.1.2 | Fabricate FM 1 & FM 2 Mother Boards (if necessary) | 14d | 2003-08-08 | 2003-08-27 | 259 |  |  | 2003-08-08 | 2003-08-27 | 14d | 109.5d | 0d |  | STEREO | IMPACT | SEP Package | SIT | SIT | UMD |  |

| ID | WBS | Task | Duration | Start | Finish | Predecessors | Complete | Remaining | Baseline start | Baseline finish | Baseline duration | Total slack | Free slack | Constraint | Text11 | Text12 | Text13 | Text14 | Text16 | Text28 | Text23 |
| --- | --- | --- | --- | --- | --- | --- | --- | --- | --- | --- | --- | --- | --- | --- | --- | --- | --- | --- | --- | --- | --- |
| 264 | 10 | **Assembly** | 76.5d | 2003-07-01 | 2003-10-20 |  |  |  | 2003-05-12 | 2003-05-23 | 9d | 24.5d |  |  | STEREO | IMPACT | SEP Package | SIT | SIT | UMD |  |
| 265 | 10.1 | **FM 1 & FM 2** | 76.5d | 2003-07-01 | 2003-10-20 |  |  |  | 2003-05-12 | 2003-05-23 | 9d | 24.5d |  |  | STEREO | IMPACT | SEP Package | SIT | SIT | UMD |  |
| 266 | 10.1.1 | Assemble FM 1 & FM 2 Mother Boards (FM 1 only) | 5d | 2003-07-23 | 2003-07-29 | 270 |  |  | 2003-05-12 | 2003-05-23 | 9d | 24.5d | 0d | start no earlier than 2003-06-30 | STEREO | IMPACT | SEP Package | SIT | SIT | UMD | Flight Mother Boards Assembled |
| 267 | 10.1.2 | Assemble FM 2 Mother Board and (if necessary) new FM 1 | 10d | 2003-08-28 | 2003-09-11 | 263 |  |  | 2003-08-28 | 2003-09-11 | 10d | 109.5d | 0d |  | STEREO | IMPACT | SEP Package | SIT | SIT | UMD |  |
| 268 | 10.1.3 | **Test** | 76.5d | 2003-07-01 | 2003-10-20 |  |  |  | 2003-04-21 | 2003-06-27 | 48d | 24.5d |  |  | STEREO | IMPACT | SEP Package | SIT | SIT | UMD |  |
| 269 | 10.1.3.1 | **FM 1 & FM 2** | 76.5d | 2003-07-01 | 2003-10-20 |  |  |  | 2003-04-21 | 2003-06-27 | 48d | 24.5d |  |  | STEREO | IMPACT | SEP Package | SIT | SIT | UMD |  |
| 270 | 10.1.3.1.1 | Coupon Testing of Mother Boards | 15d | 2003-07-01 | 2003-07-22 | 262 |  |  | 2003-04-21 | 2003-05-12 | 15d | 24.5d | 0d | start no earlier than 2003-06-30 | STEREO | IMPACT | SEP Package | SIT | SIT | UMD |  |
| 271 | 10.1.3.1.2 | Coupon Testing of Mother Boards (if necessary) | 15d | 2003-08-28 | 2003-09-18 | 263 |  |  | 2003-08-28 | 2003-09-18 | 15d | 109.5d |  |  | STEREO | IMPACT | SEP Package | SIT | SIT | UMD |  |
| 272 | 10.1.3.1.3 | **FM 1** | 36d | 2003-07-30 | 2003-09-18 |  |  |  | 2003-05-23 | 2003-06-02 | 5d | 24.5d |  |  | STEREO | IMPACT | SEP Package | SIT | SIT | UMD |  |
| 273 | 10.1.3.1.3.1 | Functional Test FM 1 Mother Board | 5d | 2003-07-30 | 2003-08-05 | 266 |  |  | 2003-05-23 | 2003-06-02 | 5d | 24.5d | 0d | start no earlier than 2003-06-30 | STEREO | IMPACT | SEP Package | SIT | SIT | UMD | FM 1 Mother Board Functionally Tested |
| 274 | 10.1.3.1.3.2 | Functional Test remade FM 1 Mother Board (if necessary) | 5d | 2003-09-12 | 2003-09-18 | 267 |  |  | 2003-09-12 | 2003-09-18 | 5d | 109.5d |  |  | STEREO | IMPACT | SEP Package | SIT | SIT | UMD |  |
| 275 | 10.1.3.1.4 | **FM 2** | 2d | 2003-10-16 | 2003-10-20 |  |  |  | 2003-06-25 | 2003-06-27 | 2d | 18d |  |  | STEREO | IMPACT | SEP Package | SIT | SIT | UMD |  |
| 276 | 10.1.3.1.4.1 | Functional Test FM 2 Mother Board | 2d | 2003-10-16 | 2003-10-20 | 252, 217 |  |  | 2003-06-25 | 2003-06-27 | 2d | 18d | 16.75d |  | STEREO | IMPACT | SEP Package | SIT | SIT | UMD | FM 2 Mother Board Functionally Tested |
| 277 | 11 | **Power** | 284.25d | 2002-10-02 A | 2003-11-20 |  | 33% | 189.5d | 2002-10-02 | 2003-08-12 | 215.2d | 1.25d |  |  | STEREO | IMPACT | SEP Package | SIT | SIT | UMD |  |
| 278 | 11.1 | **Design, Manufacture, Assembly and Test** | 284.25d | 2002-10-02 A | 2003-11-20 |  | 33% | 189.5d | 2002-10-02 | 2003-08-12 | 215.2d | 1.25d |  |  | STEREO | IMPACT | SEP Package | SIT | SIT | UMD |  |
| 279 | 11.1.1 | **Test** | 284.25d | 2002-10-02 A | 2003-11-20 |  | 33% | 189.5d | 2002-10-02 | 2003-08-12 | 215.2d | 1.25d |  |  | STEREO | IMPACT | SEP Package | SIT | SIT | UMD |  |
| 280 | 11.1.1.1 | **ETU** | 5d | 2002-10-02 A | 2002-10-09 A |  | 100% |  | 2002-10-02 | 2002-10-09 | 5d |  |  |  | STEREO | IMPACT | SEP Package | SIT | SIT | UMD |  |
| 281 | 11.1.1.1.1 | Bench Test SIT ETU HVPS | 5d | 2002-10-02 A | 2002-10-09 A | 16, 351 | 100% |  | 2002-10-02 | 2002-10-09 | 5d |  |  | start no earlier than 2002-09-30 | STEREO | IMPACT | SEP Package | SIT | SIT | UMD |  |
| 282 | 11.1.1.2 | **FM 1** | 5d | 2003-09-09 | 2003-09-16 |  |  |  | 2003-06-02 | 2003-06-09 | 5d | 1.25d |  |  | STEREO | IMPACT | SEP Package | SIT | SIT | UMD |  |
| 283 | 11.1.1.2.1 | Functional Test SIT FM 1 HVPS | 5d | 2003-09-09 | 2003-09-16 | 273, 18 |  |  | 2003-06-02 | 2003-06-09 | 5d | 1.25d | 0d |  | STEREO | IMPACT | SEP Package | SIT | SIT | UMD | FM 1 HVPS Funtionally Tested |
| 284 | 11.1.1.3 | **FM 2** | 5d | 2003-11-13 | 2003-11-20 |  |  |  | 2003-08-05 | 2003-08-12 | 5d | 1.25d |  |  | STEREO | IMPACT | SEP Package | SIT | SIT | UMD |  |
| 285 | 11.1.1.3.1 | Functional Test SIT FM 2 HVPS | 5d | 2003-11-13 | 2003-11-20 | 276, 20 |  |  | 2003-08-05 | 2003-08-12 | 5d | 1.25d | 0d |  | STEREO | IMPACT | SEP Package | SIT | SIT | UMD | FM 2 HVPS Functionally Tested |
| 286 | 12 | **Flight Software** | 309d | 2002-07-02 A | 2003-09-23 |  | 95% | 14.66d | 2002-07-02 | 2003-04-25 | 205d | 106.5d |  |  | STEREO | IMPACT | SEP Package | SIT | SIT | UMD |  |
| 287 | 12.1 | **Design, Manufacture, Assembly and Test** | 309d | 2002-07-02 A | 2003-09-23 |  | 95% | 14.66d | 2002-07-02 | 2003-04-25 | 205d | 106.5d |  |  | STEREO | IMPACT | SEP Package | SIT | SIT | UMD |  |
| 288 | 12.1.1 | **Assembly** | 195d | 2002-07-02 A | 2003-04-11 A |  | 100% |  | 2002-07-02 | 2003-03-17 | 176d |  |  |  | STEREO | IMPACT | SEP Package | SIT | SIT | GSFC |  |
| 289 | 12.1.1.1 | **ETU** | 85d | 2002-07-02 A | 2002-10-31 A |  | 100% |  | 2002-07-02 | 2002-10-31 | 85d |  |  |  | STEREO | IMPACT | SEP Package | SIT | SIT | GSFC |  |
| 290 | 12.1.1.1.1 | Code SIT Partical Event Processing With Simulated Data | 30d | 2002-07-02 A | 2002-08-29 A | 8 | 100% |  | 2002-07-02 | 2002-08-29 | 30d |  |  | start no earlier than 2002-07-01 | STEREO | IMPACT | SEP Package | SIT | SIT | GSFC |  |
| 291 | 12.1.1.1.2 | Code SIT Beacon Data Processing With Simulated Data | 22d | 2002-10-01 A | 2002-10-31 A | 8 | 100% |  | 2002-10-01 | 2002-10-31 | 22d |  |  | start no earlier than 2002-09-30 | STEREO | IMPACT | SEP Package | SIT | SIT | GSFC |  |
| 292 | 12.1.1.1.3 | Code SIT Telemetry Formatting With Simulated Data | 22d | 2002-10-01 A | 2002-10-31 A | 8 | 100% |  | 2002-10-01 | 2002-10-31 | 22d |  |  | start no earlier than 2002-09-30 | STEREO | IMPACT | SEP Package | SIT | SIT | GSFC |  |

Notes:
- 291: 100%
- 292: 100%

| ID | WBS | Task | Duration | Start | Finish | Predecessors | Complete | Remaining | Baseline start | Baseline finish | Baseline duration | Total slack | Free slack | Constraint | Text11 | Text12 | Text13 | Text14 | Text16 | Text28 | Text23 |
| --- | --- | --- | --- | --- | --- | --- | --- | --- | --- | --- | --- | --- | --- | --- | --- | --- | --- | --- | --- | --- | --- |
| 293 | 12.1.1.2 | **FM 1 & FM 2** | 30d | 2003-03-03 A | 2003-04-11 A |  | 100% |  | 2003-02-03 | 2003-03-17 | 30d |  |  |  | STEREO | IMPACT | SEP Package | SIT | SIT | UMD |  |
| 294 | 12.1.1.2.1 | Code SIT Data Acquisition | 19d | 2003-03-03 A | 2003-03-27 A |  | 100% |  | 2003-02-03 | 2003-02-28 | 19d |  |  | start no earlier than 2003-03-01 | STEREO | IMPACT | SEP Package | SIT | SIT | GSFC |  |
| 295 | 12.1.1.2.2 | Code SIT Command Processing | 30d | 2003-03-03 A | 2003-04-11 A | 8 | 100% |  | 2003-02-03 | 2003-03-17 | 30d |  |  | start no earlier than 2003-03-01 | STEREO | IMPACT | SEP Package | SIT | SIT | GSFC |  |
| 296 | 12.1.1.2.3 | Code Update For SIT Partical Event Processing | 10d | 2003-03-17 A | 2003-03-28 A | 290, 294SS, 301SS+10d | 100% |  | 2003-02-18 | 2003-03-03 | 10d |  |  | start no earlier than 2003-03-01 | STEREO | IMPACT | SEP Package | SIT | SIT | GSFC |  |
| 297 | 12.1.1.2.4 | Code Update for SIT Beacon Data Processing | 10d | 2003-03-17 A | 2003-03-28 A | 291, 301SS+10d | 100% |  | 2003-02-18 | 2003-03-03 | 10d |  |  | start no earlier than 2003-03-01 | STEREO | IMPACT | SEP Package | SIT | SIT | GSFC |  |
| 298 | 12.1.1.2.5 | Code Update for SIT Telemetry Formatting | 10d | 2003-03-31 A | 2003-04-11 A | 292, 296 | 100% |  | 2003-03-04 | 2003-03-17 | 10d |  |  | start no earlier than 2003-02-01 | STEREO | IMPACT | SEP Package | SIT | SIT | GSFC |  |
| 299 | 12.1.2 | **Test** | 144d | 2003-03-03 A | 2003-09-23 |  | 88% | 17.28d | 2003-02-03 | 2003-04-25 | 59d | 106.5d |  |  | STEREO | IMPACT | SEP Package | SIT | SIT | GSFC |  |
| 300 | 12.1.2.1 | **ETU** | 20d | 2003-03-03 A | 2003-03-28 A |  | 100% |  | 2003-02-03 | 2003-03-03 | 20d |  |  |  | STEREO | IMPACT | SEP Package | SIT | SIT | UMD |  |
| 301 | 12.1.2.1.1 | SIT Integrated S/W Testing Using Simulated Data | 20d | 2003-03-03 A | 2003-03-28 A | 290, 291, 292 | 100% |  | 2003-02-03 | 2003-03-03 | 20d |  |  | start no earlier than 2003-03-01 | STEREO | IMPACT | SEP Package | SIT | SIT | GSFC |  |
| 302 | 12.1.2.2 | **FM 1 & FM 2** | 80d | 2003-06-02 A | 2003-09-23 |  | 85% | 12d | 2003-03-18 | 2003-04-25 | 29d | 106.5d |  |  | STEREO | IMPACT | SEP Package | SIT | SIT | GSFC |  |
| 303 | 12.1.2.2.1 | Validate SIT On-Board Code | 80d | 2003-06-02 A | 2003-09-23 | 295, 294, 297, 298, 301 | 85% | 12d | 2003-03-18 | 2003-04-25 | 29d | 106.5d |  | start no earlier than 2003-05-31 | STEREO | IMPACT | SEP Package | SIT | SIT | GSFC | On-board Flight S/W Validated |
| 304 | 13 | **Integration & Test** | 466.5d | 2002-04-19 A | 2004-03-01 |  | 9% | 424.85d | 2002-04-19 | 2004-01-15 | 436d | 0d |  |  | STEREO | IMPACT | SEP Package | SIT | SIT | UMD |  |
| 305 | 13.1 | **ETU** | 125d | 2002-04-19 A | 2002-10-16 A |  | 100% |  | 2002-04-19 | 2002-10-16 | 125d |  |  |  | STEREO | IMPACT | SEP Package | SIT | SIT | UMD |  |
| 306 | 13.1.1 | Test Energy Breadboard with TOF System | 10d | 2002-04-19 A | 2002-05-02 A | 208, 166 | 100% |  | 2002-04-19 | 2002-05-02 | 10d |  |  |  | STEREO | IMPACT | SEP Package | SIT | SIT | UMD |  |
| 307 | 13.1.2 | Test SIT ETU HVPS with TOF ETU Board and Energy ETU Board | 5d | 2002-10-10 A | 2002-10-16 A | 281, 306 | 100% |  | 2002-10-10 | 2002-10-16 | 5d |  |  | start no earlier than 2002-09-30 | STEREO | IMPACT | SEP Package | SIT | SIT | UMD |  |
| 308 | 13.2 | **FM 1** | 4d | 2004-02-11 | 2004-02-18 |  |  |  | 2003-12-29 | 2004-01-02 | 4d | 7.5d |  |  | STEREO | IMPACT | SEP Package | SIT | SIT | UMD |  |
| 309 | 13.2.1 | Disassemble SIT FM 1 | 1d | 2004-02-11 | 2004-02-12 | 250 |  |  | 2003-12-29 | 2003-12-29 | 1d | 7.5d | 0d |  | STEREO | IMPACT | SEP Package | SIT | SIT | UMD |  |
| 310 | 13.2.2 | Conformal Coat SIT FM 1 Boards | 1d | 2004-02-12 | 2004-02-13 | 309 |  |  | 2003-12-30 | 2003-12-30 | 1d | 7.5d | 0d |  | STEREO | IMPACT | SEP Package | SIT | SIT | UMD |  |
| 311 | 13.2.3 | Reassemble SIT FM 1 | 1d | 2004-02-13 | 2004-02-17 | 310 |  |  | 2003-12-31 | 2003-12-31 | 1d | 7.5d | 0d |  | STEREO | IMPACT | SEP Package | SIT | SIT | UMD |  |
| 312 | 13.2.4 | Post-Coat Retest SIT FM 1 | 1d | 2004-02-17 | 2004-02-18 | 311 |  |  | 2004-01-02 | 2004-01-02 | 1d | 7.5d | 0d |  | STEREO | IMPACT | SEP Package | SIT | SIT | UMD | FM 1 Ready for Delivery |
| 313 | 13.3 | **FM 2** | 112.25d | 2003-09-16 | 2004-03-01 |  |  |  | 2003-06-09 | 2004-01-15 | 150.8d | 0d |  |  | STEREO | IMPACT | SEP Package | SIT | SIT | UMD |  |
| 314 | 13.3.1 | Disassemble SIT FM 2 | 1d | 2004-02-11 | 2004-02-12 | 253 |  |  | 2003-12-29 | 2003-12-29 | 1d | 0d |  |  | STEREO | IMPACT | SEP Package | SIT | SIT | UMD |  |
| 315 | 13.3.2 | Conformal Coat SIT FM 2 Boards | 1d | 2004-02-12 | 2004-02-13 | 314 |  |  | 2003-12-30 | 2003-12-30 | 1d | 0d |  |  | STEREO | IMPACT | SEP Package | SIT | SIT | UMD |  |
| 316 | 13.3.3 | Reassemble SIT FM 2 | 1d | 2004-02-13 | 2004-02-17 | 315 |  |  | 2003-12-31 | 2003-12-31 | 1d | 0d |  |  | STEREO | IMPACT | SEP Package | SIT | SIT | UMD |  |
| 317 | 13.3.4 | Post-Coat Retest SIT FM 2 | 9d | 2004-02-17 | 2004-03-01 | 316 |  |  | 2004-01-02 | 2004-01-15 | 9d | 0d |  |  | STEREO | IMPACT | SEP Package | SIT | SIT | UMD | FM 2 Ready for Delivery |

| ID | WBS | Task | Duration | Start | Finish | Predecessors | Complete | Remaining | Baseline start | Baseline finish | Baseline duration | Total slack | Free slack | Text11 | Text12 | Text13 | Text14 | Text16 | Text28 | Text23 |
| --- | --- | --- | --- | --- | --- | --- | --- | --- | --- | --- | --- | --- | --- | --- | --- | --- | --- | --- | --- | --- |
| 318 | 13.3.5 | **FM 1** | 94.25d | 2003-09-16 | 2004-02-03 |  |  |  | 2003-06-09 | 2003-12-17 | 132.8d | 0d |  | STEREO | IMPACT | SEP Package | SIT | SIT | UMD |  |
| 319 | 13.3.5.1 | Integrate SIT FM 1 HVPS and SIT FM 1 Telescope Without Electronics | 3d | 2003-09-16 | 2003-09-19 | 283, 352, 18 |  |  | 2003-06-09 | 2003-06-12 | 3d | 1.25d | 0d | STEREO | IMPACT | SEP Package | SIT | SIT | UMD |  |
| 320 | 13.3.5.2 | Integrate SIT FM 1Telescope | 2d | 2003-09-24 | 2003-09-26 | 249, 273, 172, 93 |  |  | 2003-08-12 | 2003-08-13 | 2d | 0d |  | STEREO | IMPACT | SEP Package | SIT | SIT | UMD | FM 1 Integrated |
| 321 | 13.3.5.3 | SIT FM 1 Debug | 27d | 2003-09-26 | 2003-11-05 | 14, 320 |  |  | 2003-08-14 | 2003-09-22 | 27d | 0d |  | STEREO | IMPACT | SEP Package | SIT | SIT | UMD |  |
| 322 | 13.3.5.4 | SIT FM 1 Bench Test | 9d | 2003-11-05 | 2003-11-19 | 321 |  |  | 2003-09-23 | 2003-10-03 | 9d | 0d |  | STEREO | IMPACT | SEP Package | SIT | SIT | UMD | FM 1 Tested |
| 323 | 13.3.5.5 | SIT FM 1 Alpha TEST | 10d | 2003-11-19 | 2003-12-04 | 322 |  |  | 2003-10-07 | 2003-10-20 | 10d | 0d |  | STEREO | IMPACT | SEP Package | SIT | SIT | UMD |  |
| 324 | 13.3.5.6 | SIT FM 1 Noise Removal | 29d | 2003-12-04 | 2004-01-19 | 323 |  |  | 2003-10-21 | 2003-12-02 | 29d | 0d |  | STEREO | IMPACT | SEP Package | SIT | SIT | UMD |  |
| 325 | 13.3.5.7 | SIT FM 1 Thermal Test | 10d | 2004-01-19 | 2004-02-02 | 324 |  |  | 2003-12-03 | 2003-12-16 | 10d | 0d |  | STEREO | IMPACT | SEP Package | SIT | SIT | UMD | FM 1 Environmentallyl Tested |
| 326 | 13.3.5.8 | SIT FM 1 Functional Test | 1d | 2004-02-02 | 2004-02-03 | 325 |  |  | 2003-12-17 | 2003-12-17 | 1d | 0d |  | STEREO | IMPACT | SEP Package | SIT | SIT | UMD |  |
| 327 | 13.3.6 | **FM 2** | 48d | 2003-11-20 | 2004-02-02 |  |  |  | 2003-08-12 | 2003-10-28 | 53.8d | 1.25d |  | STEREO | IMPACT | SEP Package | SIT | SIT | UMD |  |
| 328 | 13.3.6.1 | Integrate SIT FM 2 HVPS and SIT FM 2 Telescope Without Electronics | 3d | 2003-11-20 | 2003-11-25 | 285, 352 |  |  | 2003-08-12 | 2003-08-15 | 3d | 1.25d | 0d | STEREO | IMPACT | SEP Package | SIT | SIT | UMD |  |
| 329 | 13.3.6.2 | Integrate SIT FM 2 Telescope | 2d | 2003-11-28 | 2003-12-02 | 252, 276, 174, 95 |  |  | 2003-08-27 | 2003-08-28 | 2d | 1.25d | 0d | STEREO | IMPACT | SEP Package | SIT | SIT | UMD | FM 2 Integrated |
| 330 | 13.3.6.3 | SIT FM 2 Debug | 15d | 2003-12-02 | 2003-12-23 | 329 |  |  | 2003-08-29 | 2003-09-19 | 15d | 1.25d | 0d | STEREO | IMPACT | SEP Package | SIT | SIT | UMD |  |
| 331 | 13.3.6.4 | SIT FM 2 Bench Test | 10d | 2003-12-23 | 2004-01-08 | 330 |  |  | 2003-09-22 | 2003-10-03 | 10d | 1.25d | 0d | STEREO | IMPACT | SEP Package | SIT | SIT | UMD | FM 2 Tested |
| 332 | 13.3.6.5 | SIT FM 2 Alpha Test | 5d | 2004-01-08 | 2004-01-16 | 331 |  |  | 2003-10-07 | 2003-10-13 | 5d | 1.25d | 0d | STEREO | IMPACT | SEP Package | SIT | SIT | UMD |  |
| 333 | 13.3.6.6 | SIT FM 2 Thermal Test | 10d | 2004-01-16 | 2004-01-30 | 332 |  |  | 2003-10-14 | 2003-10-27 | 10d | 1.25d | 0d | STEREO | IMPACT | SEP Package | SIT | SIT | UMD | FM 2 Environmentally Tested |
| 334 | 13.3.6.7 | SIT FM 2 Functional Test | 1d | 2004-01-30 | 2004-02-02 | 333 |  |  | 2003-10-28 | 2003-10-28 | 1d | 1.25d |  | STEREO | IMPACT | SEP Package | SIT | SIT | UMD |  |
| 335 | 14 | **Emulators/Simulators/GSE** | 572.5d | 2001-11-02 A | 2004-02-18 |  | 51% | 281.62d | 2001-11-02 | 2004-01-06 | 544d | 8d |  | STEREO | IMPACT | SEP Package | SIT | SIT | UMD |  |
| 336 | 14.1 | **Simulators** | 9d | 2003-10-23 | 2003-11-05 |  |  |  | 2003-09-10 | 2003-09-23 | 9d | 77d |  | STEREO | IMPACT | SEP Package | SIT | SIT | UMD |  |
| 337 | 14.1.1 | CPU Simulator H/W Ready | 2d | 2003-10-23 | 2003-10-27 | 339SF+1d |  |  | 2003-09-10 | 2003-09-11 | 2d | 84d |  | STEREO | IMPACT | SEP Package | SIT | SIT | UMD |  |
| 338 | 14.1.2 | Labview CPU Ready | 2d | 2003-10-23 | 2003-10-27 | 339SF+1d |  |  | 2003-09-10 | 2003-09-11 | 2d | 84d |  | STEREO | IMPACT | SEP Package | SIT | SIT | UMD |  |
| 339 | 14.1.3 | Test Simulator | 8d | 2003-10-24 | 2003-11-05 | 322SF |  |  | 2003-09-11 | 2003-09-23 | 8d | 77d | 0d | STEREO | IMPACT | SEP Package | SIT | SIT | UMD |  |
| 340 | 14.2 | **GSE** | 572.5d | 2001-11-02 A | 2004-02-18 |  | 55% | 256.03d | 2001-11-02 | 2004-01-06 | 544d | 8d |  | STEREO | IMPACT | SEP Package | SIT | SIT | UMD |  |
| 341 | 14.2.1 | Pulse Generator | 60d | 2003-11-19 | 2004-02-18 | 56SF |  |  | 2003-10-09 | 2004-01-06 | 60d | 8d |  | STEREO | IMPACT | SEP Package | SIT | SIT | UMD |  |

| ID | WBS | Task | Duration | Start | Finish | Predecessors | Complete | Remaining | Baseline start | Baseline finish | Baseline duration | Total slack | Free slack | Constraint | Text11 | Text12 | Text13 | Text14 | Text16 | Text28 | Text17 |
| --- | --- | --- | --- | --- | --- | --- | --- | --- | --- | --- | --- | --- | --- | --- | --- | --- | --- | --- | --- | --- | --- |
| 342 | 14.2.2 | **TOF Board** | 445d | 2001-11-02 A | 2003-08-12 |  | 97% | 12.03d | 2001-11-02 | 2003-08-12 | 445d | 64.5d |  |  | STEREO | IMPACT | SEP Package | SIT | SIT | UMD |  |
| 343 | 14.2.2.1 | Construct & Test TOF GSE | 34d | 2001-11-02 A | 2001-12-21 A |  | 100% |  | 2001-11-02 | 2001-12-21 | 34d |  |  | start no earlier than 2001-11-02 | STEREO | IMPACT | SEP Package | SIT | SIT | UMD |  |
| 344 | 14.2.2.2 | Proto TOF Test Setup | 2d | 2002-01-03 A | 2002-01-04 A |  | 100% |  | 2002-01-03 | 2002-01-04 | 2d |  |  | start no earlier than 2002-01-03 | STEREO | IMPACT | SEP Package | SIT | SIT | UMD |  |
| 345 | 14.2.2.3 | Flight TOF Test Setup | 1d | 2003-08-12 | 2003-08-12 | 172 |  |  | 2003-08-12 | 2003-08-12 | 1d | 64.5d | 12d | start no earlier than 2002-11-30 | STEREO | IMPACT | SEP Package | SIT | SIT | UMD |  |
| 346 | 14.2.3 | **Energy Board** | 5d | 2002-03-29 A | 2002-04-04 A |  | 100% |  | 2002-03-29 | 2002-04-04 | 5d |  |  |  | STEREO | IMPACT | SEP Package | SIT | SIT | UMD |  |
| 347 | 14.2.3.1 | Proto E GSE | 5d | 2002-03-29 A | 2002-04-04 A | 180 | 100% |  | 2002-03-29 | 2002-04-04 | 5d |  |  |  | STEREO | IMPACT | SEP Package | SIT | SIT | UMD |  |
| 348 | 14.2.4 | **Energy Board / Logic Board GSE** | 2d | 2003-03-03 A | 2003-03-04 A |  | 100% |  | 2003-02-03 | 2003-02-04 | 2d |  |  |  | STEREO | IMPACT | SEP Package | SIT | SIT | UMD |  |
| 349 | 14.2.4.1 | Energy Board/Logic Board Test Setup | 2d | 2003-03-03 A | 2003-03-04 A |  | 100% |  | 2003-02-03 | 2003-02-04 | 2d |  |  | start no earlier than 2003-03-01 | STEREO | IMPACT | SEP Package | SIT | SIT | UMD |  |
| 350 | 14.2.5 | **HVPS Setup** | 188d | 2002-10-01 A | 2003-07-01 A |  | 100% |  | 2002-10-01 | 2003-06-04 | 169d |  |  |  | STEREO | IMPACT | SEP Package | SIT | SIT | UMD |  |
| 351 | 14.2.5.1 | ETU HVPS Test Setup Available | 1d | 2002-10-01 A | 2002-10-01 A |  | 100% |  | 2002-10-01 | 2002-10-01 | 1d |  |  | start no earlier than 2002-09-30 | STEREO | IMPACT | SEP Package | SIT | SIT | UMD |  |
| 352 | 14.2.5.2 | SIT FM 1 & FM 2 HVPS Test Setup Available | 2d | 2003-05-30 A | 2003-07-01 A |  | 100% |  | 2003-06-03 | 2003-06-04 | 2d |  |  |  | STEREO | IMPACT | SEP Package | SIT | SIT | UMD |  |
| 353 | 14.2.6 | **Software** | 189.6d | 2002-07-17 A | 2003-04-18 A |  | 100% |  | 2002-07-17 | 2003-02-21 | 149.6d |  |  |  | STEREO | IMPACT | SEP Package | SIT | SIT | UMD |  |
| 354 | 8.2.5 | Display HET Housekeeping Data | 10d | 2003-04-01 A | 2003-04-14 A |  | 100% |  | 2003-02-03 | 2003-02-14 | 10d |  |  | start no earlier than 2003-03-31 | STEREO | IMPACT | SEP Package | SIT | SIT | GSFC | SIT |
| 355 | 8.2.4 | Display HET Pulse-Height Data | 10d | 2002-07-02 A | 2002-08-07 A |  | 100% |  | 2002-07-02 | 2002-08-07 | 10d |  |  | start no earlier than 2002-07-01 | STEREO | IMPACT | SEP Package | SIT | SIT | UMD | SIT |
| 356 | 8.2.3 | Display HET Rates | 10d | 2002-07-02 A | 2002-07-16 A |  | 100% |  | 2002-07-02 | 2002-07-16 | 10d |  |  | start no earlier than 2002-07-01 | STEREO | IMPACT | SEP Package | SIT | SIT | UMD | SIT |
| 357 | 14.2.6.4 | Display SIT Rates | 9d | 2002-07-17 A | 2003-04-18 A | 354, 355, 356 | 100% |  | 2002-07-17 | 2003-02-21 | 9d |  |  |  | STEREO | IMPACT | SEP Package | SIT | SIT | GSFC |  |
| 358 | 14.2.6.5 | Display SIT Pulse-Height Data | 10.4d | 2002-07-30 A | 2002-08-30 A | 357 | 100% |  | 2002-07-30 | 2002-08-30 | 10.4d |  |  |  | STEREO | IMPACT | SEP Package | SIT | SIT | GSFC |  |
| 359 | 14.2.6.6 | Display SIT Housekeeping | 10d | 2003-03-03 A | 2003-03-14 A | 358 | 100% |  | 2003-02-03 | 2003-02-14 | 10d |  |  | start no earlier than 2003-03-01 | STEREO | IMPACT | SEP Package | SIT | SIT | GSFC |  |
